# MP16ADV_Module1

How a schedule from MS Project changed from version to version. A marks actual dates.

## Version 1 (saved 2018-07-21, file SubProject_Excavation.mpp)

| ID | WBS | Task | Duration | Start | Finish | Predecessors | Total float |
| --- | --- | --- | --- | --- | --- | --- | --- |
| 1 | 1 | **Scope** | 7d | 2018-05-01 | 2018-05-09 |  | 0d |
| 2 |  | Determine project scope | 2d | 2018-05-01 | 2018-05-02 |  | 0d |
| 3 |  | Secure project sponsorship | 1d | 2018-05-03 | 2018-05-03 | 2 | 0d |
| 4 |  | Define preliminary resources | 3d | 2018-05-04 | 2018-05-08 | 3 | 0d |
| 5 |  | Secure core resources | 1d | 2018-05-09 | 2018-05-09 | 4 | 0d |
| 6 |  | Scope complete | 0d | 2018-05-09 | 2018-05-09 | 5 | 0d |
| 7 | 2 | **Analysis/Software Requirements** | 10d | 2018-05-10 | 2018-05-23 |  | 0d |
| 8 |  | Conduct needs analysis | 1d | 2018-05-10 | 2018-05-10 | 6 | 0d |
| 9 |  | Draft preliminary software specifications | 4d | 2018-05-11 | 2018-05-16 | 8 | 0d |
| 10 |  | Develop preliminary budget | 2d | 2018-05-17 | 2018-05-18 | 9 | 0d |
| 11 |  | Review software specifications/budget with team | 1d | 2018-05-17 | 2018-05-17 | 10SS | 0d |
| 12 |  | Incorporate feedback on software specifications | 1d | 2018-05-18 | 2018-05-18 | 11 | 0d |
| 13 |  | Develop delivery timeline | 1d | 2018-05-21 | 2018-05-21 | 12 | 0d |
| 14 |  | Obtain approvals to proceed (concept, timeline, budget) | 1d | 2018-05-22 | 2018-05-22 | 13 | 0d |
| 15 |  | Secure required resources | 1d | 2018-05-23 | 2018-05-23 | 14 | 0d |
| 16 |  | Analysis complete | 0d | 2018-05-23 | 2018-05-23 | 15 | 0d |
| 17 | 3 | **Design** | 15d | 2018-05-24 | 2018-06-13 |  | 0d |
| 18 |  | Review preliminary software specifications | 2d | 2018-05-24 | 2018-05-25 | 16 | 0d |
| 19 |  | Develop functional specifications | 5d | 2018-05-28 | 2018-06-01 | 18 | 0d |
| 20 |  | Develop prototype based on functional specifications | 4d | 2018-06-04 | 2018-06-07 | 19 | 0d |
| 21 |  | Review functional specifications | 2d | 2018-06-08 | 2018-06-11 | 20 | 0d |
| 22 |  | Incorporate feedback into functional specifications | 1d | 2018-06-12 | 2018-06-12 | 21 | 0d |
| 23 |  | Obtain approval to proceed | 1d | 2018-06-13 | 2018-06-13 | 22 | 0d |
| 24 |  | Design complete | 0d | 2018-06-13 | 2018-06-13 | 23 | 0d |
| 25 | 4 | **Development** | 33d | 2018-06-14 | 2018-07-30 |  | 5d |
| 26 |  | Review functional specifications | 1d | 2018-06-14 | 2018-06-14 | 24 | 5d |
| 27 |  | Identify modular/tiered design parameters | 1d | 2018-06-15 | 2018-06-15 | 26 | 5d |
| 28 |  | Assign development staff | 1d | 2018-06-18 | 2018-06-18 | 27 | 5d |
| 29 |  | Develop code | 15d | 2018-06-19 | 2018-07-09 | 28 | 5d |
| 30 |  | Developer testing (primary debugging) | 15d | 2018-07-10 | 2018-07-30 | 29FS-7.5% | 5d |
| 31 |  | Development complete | 0d | 2018-07-30 | 2018-07-30 | 30 | 5d |
| 32 | 5 | **Testing** | 60d | 2018-06-14 | 2018-09-05 |  | 20d |
| 33 |  | Develop unit test plans using product specifications | 4d | 2018-06-14 | 2018-06-19 | 24 | 34d |
| 34 |  | Develop integration test plans using product specifications | 4d | 2018-06-25 | 2018-08-22 | 24 | 30d |
| 35 | 5.3 | **Unit Testing** | 15d | 2018-07-31 | 2018-08-20 |  | 5d |
| 36 |  | Review modular code | 5d | 2018-07-31 | 2018-08-06 | 33, 31 | 5d |
| 37 |  | Test component modules to product specifications | 2d | 2018-08-07 | 2018-08-08 | 31, 36 | 5d |
| 38 |  | Identify anomalies to product specifications | 3d | 2018-08-09 | 2018-08-13 | 37 | 5d |
| 39 |  | Modify code | 3d | 2018-08-14 | 2018-08-16 | 38 | 5d |
| 40 |  | Re-test modified code | 2d | 2018-08-17 | 2018-08-20 | 39 | 5d |
| 41 |  | Unit testing complete | 0d | 2018-08-20 | 2018-08-20 | 40 | 5d |
| 42 | 5.4 | **Integration Testing** | 12d | 2018-08-21 | 2018-09-05 |  | 5d |
| 43 |  | Test module integration | 5d | 2018-08-21 | 2018-08-27 | 41 | 5d |
| 44 |  | Identify anomalies to specifications | 2d | 2018-08-28 | 2018-08-29 | 43 | 5d |
| 45 |  | Modify code | 3d | 2018-08-30 | 2018-09-03 | 44 | 5d |
| 46 |  | Re-test modified code | 2d | 2018-09-04 | 2018-09-05 | 45 | 5d |
| 47 |  | Integration testing complete | 0d | 2018-09-05 | 2018-09-05 | 46 | 5d |
| 48 | 6 | **Training** | 32d | 2018-07-31 | 2018-09-12 |  | 0d |
| 49 |  | Develop training specifications for end users | 3d | 2018-07-31 | 2018-08-02 | 24 | 5d |
| 50 |  | Develop training specifications for helpdesk support staff | 3d | 2018-08-03 | 2018-08-07 | 24 | 2d |
| 51 |  | Identify training delivery methodology (computer based training, classroom, etc.) | 2d | 2018-08-08 | 2018-08-09 | 24 | 0d |
| 52 |  | Develop training materials | 3w | 2018-08-10 | 2018-08-30 | 49, 31, 50, 51 | 0d |
| 53 |  | Conduct training usability study | 4d | 2018-08-31 | 2018-09-05 | 52 | 0d |
| 54 |  | Finalize training materials | 3d | 2018-09-06 | 2018-09-10 | 53 | 0d |
| 55 |  | Develop training delivery mechanism | 2d | 2018-09-11 | 2018-09-12 | 54 | 0d |
| 56 |  | Training materials complete | 0d | 2018-09-12 | 2018-09-12 | 55 | 0d |
| 57 | 7 | **Documentation** | 45d | 2018-06-20 | 2018-08-21 |  | 16d |
| 58 |  | Develop Help specification | 1d | 2018-06-20 | 2018-06-20 | 24 | 23d |
| 59 |  | Develop Help system | 3w | 2018-06-28 | 2018-07-19 | 58, 29FS-5% | 17.5d |
| 60 |  | Review Help documentation | 3d | 2018-08-09 | 2018-08-14 | 59 | 17.5d |
| 61 |  | Incorporate Help documentation feedback | 2d | 2018-08-20 | 2018-08-21 | 60 | 16d |
| 62 |  | Develop user manuals specifications | 2d | 2018-06-21 | 2018-06-22 | 24 | 20d |
| 63 |  | Develop user manuals | 3w | 2018-07-19 | 2018-08-09 | 62, 29FS-5% | 16.5d |
| 64 |  | Review all user documentation | 2d | 2018-08-14 | 2018-08-16 | 63 | 17.5d |
| 65 |  | Incorporate user documentation feedback | 2d | 2018-08-16 | 2018-08-20 | 64 | 17.5d |
| 66 |  | Documentation complete | 0d | 2018-08-21 | 2018-08-21 | 65, 61 | 16d |
| 67 | 8 | **Pilot** | 87d | 2018-05-24 | 2018-09-21 |  | 0d |
| 68 |  | Identify test group | 1d | 2018-05-24 | 2018-05-24 | 16 | 78d |
| 69 |  | Develop software delivery mechanism | 1d | 2018-05-25 | 2018-05-25 | 68 | 78d |
| 70 |  | Install/deploy software | 1d | 2018-09-13 | 2018-09-13 | 47, 69, 66, 56 | 0d |

| ID | WBS | Task | Duration | Start | Finish | Predecessors | Total float |
| --- | --- | --- | --- | --- | --- | --- | --- |
| 71 |  | Obtain user feedback | 1w | 2018-09-14 | 2018-09-20 | 70 | 0d |
| 72 |  | Evaluate testing information | 1d | 2018-09-21 | 2018-09-21 | 71 | 0d |
| 73 |  | Pilot complete | 0d | 2018-09-21 | 2018-09-21 | 72 | 0d |
| 74 | 9 | **Deployment** | 5d | 2018-09-24 | 2018-09-28 |  | 0d |
| 75 |  | Determine final deployment strategy | 1d | 2018-09-24 | 2018-09-24 | 73 | 0d |
| 76 |  | Develop deployment methodology | 1d | 2018-09-25 | 2018-09-25 | 75 | 0d |
| 77 |  | Secure deployment resources | 1d | 2018-09-26 | 2018-09-26 | 76 | 0d |
| 78 |  | Train support staff | 1d | 2018-09-27 | 2018-09-27 | 77 | 0d |
| 79 |  | Deploy software | 1d | 2018-09-28 | 2018-09-28 | 78 | 0d |
| 80 |  | Deployment complete | 0d | 2018-09-28 | 2018-09-28 | 79 | 0d |
| 81 | 10 | **Post Implementation Review** | 3d | 2018-10-01 | 2018-10-03 |  | 0d |
| 82 |  | Document lessons learned | 1d | 2018-10-01 | 2018-10-01 | 80 | 0d |
| 83 |  | Distribute to team members | 1d | 2018-10-02 | 2018-10-02 | 82 | 0d |
| 84 |  | Create software maintenance team | 1d | 2018-10-03 | 2018-10-03 | 83 | 0d |
| 85 |  | Post implementation review complete | 0d | 2018-10-03 | 2018-10-03 | 84 | 0d |
| 86 |  | Software development template complete | 0d | 2018-10-03 | 2018-10-03 | 85 | 0d |

## Version 2 (saved 2019-01-13, file Importing.mpp)

Last finish 2018-10-03 → 2019-01-14 (+103d). Complete tasks 0 → 14.

Changed:

| ID | Task | Start | Finish | Duration | Complete | Total float | Other |
| --- | --- | --- | --- | --- | --- | --- | --- |
| 1 | **Scope** | 2018-05-01 → 2018-08-06 A (+97d) | 2018-05-09 → 2018-08-15 A (+98d) | 7d → 8d | 0% → 100% | 0d → none |  |
| 2 | Determine project scope | 2018-05-01 → 2018-08-06 A (+97d) | 2018-05-02 → 2018-08-06 A (+96d) | 2d → 1d | 0% → 100% | 0d → none |  |
| 3 | Secure project sponsorship | 2018-05-03 → 2018-08-07 A (+96d) | 2018-05-03 → 2018-08-09 A (+98d) | 1d → 3d | 0% → 100% | 0d → none |  |
| 4 | Define preliminary resources | 2018-05-04 → 2018-08-10 A (+98d) | 2018-05-08 → 2018-08-10 A (+94d) | 3d → 1d | 0% → 100% | 0d → none | resources Project Manager → Steve Masters |
| 5 | Secure core resources | 2018-05-09 → 2018-08-15 A (+98d) | 2018-05-09 → 2018-08-15 A (+98d) |  | 0% → 100% | 0d → none | resources Project Manager → Steve Masters |
| 6 | Scope complete | 2018-05-09 → 2018-08-15 A (+98d) | 2018-05-09 → 2018-08-15 A (+98d) |  | 0% → 100% | 0d → none |  |
| 7 | **Analysis/Software Requirements** | 2018-05-10 → 2018-08-16 A (+98d) | 2018-05-23 → 2018-08-31 A (+100d) | 10d → 12d | 0% → 100% | 0d → none |  |
| 8 | Conduct needs analysis | 2018-05-10 → 2018-08-16 A (+98d) | 2018-05-10 → 2018-08-17 A (+99d) | 1d → 2d | 0% → 100% | 0d → none |  |
| 9 | Draft preliminary software specifications | 2018-05-11 → 2018-08-20 A (+101d) | 2018-05-16 → 2018-08-21 A (+97d) | 4d → 2d | 0% → 100% | 0d → none |  |
| 10 | Develop preliminary budget | 2018-05-17 → 2018-08-22 A (+97d) | 2018-05-18 → 2018-08-23 A (+97d) |  | 0% → 100% | 0d → none |  |
| 11 | Review software specifications/budget with team | 2018-05-17 → 2018-08-22 A (+97d) | 2018-05-17 → 2018-08-22 A (+97d) |  | 0% → 100% | 0d → none |  |
| 12 | Incorporate feedback on software specifications | 2018-05-18 → 2018-08-23 A (+97d) | 2018-05-18 → 2018-08-27 A (+101d) | 1d → 3d | 0% → 100% | 0d → none |  |
| 13 | Develop delivery timeline | 2018-05-21 → 2018-08-28 A (+99d) | 2018-05-21 → 2018-08-29 A (+100d) | 1d → 2d | 0% → 100% | 0d → none |  |
| 14 | Obtain approvals to proceed (concept, timeline, budget) | 2018-05-22 → 2018-08-30 A (+100d) | 2018-05-22 → 2018-08-30 A (+100d) |  | 0% → 100% | 0d → none |  |
| 15 | Secure required resources | 2018-05-23 → 2018-08-31 A (+100d) | 2018-05-23 → 2018-08-31 A (+100d) |  | 0% → 100% | 0d → none |  |
| 16 | Analysis complete | 2018-05-23 → 2018-08-31 A (+100d) | 2018-05-23 → 2018-08-31 A (+100d) |  | 0% → 100% | 0d → none |  |
| 17 | **Design** | 2018-05-24 → 2018-09-03 (+102d) | 2018-06-13 → 2018-09-21 (+100d) |  |  |  |  |
| 18 | Review preliminary software specifications | 2018-05-24 → 2018-09-03 (+102d) | 2018-05-25 → 2018-09-04 (+102d) |  |  |  |  |
| 19 | Develop functional specifications | 2018-05-28 → 2018-09-05 (+100d) | 2018-06-01 → 2018-09-11 (+102d) |  |  |  |  |
| 20 | Develop prototype based on functional specifications | 2018-06-04 → 2018-09-12 (+100d) | 2018-06-07 → 2018-09-17 (+102d) |  |  |  |  |
| 21 | Review functional specifications | 2018-06-08 → 2018-09-18 (+102d) | 2018-06-11 → 2018-09-19 (+100d) |  |  |  |  |
| 22 | Incorporate feedback into functional specifications | 2018-06-12 → 2018-09-20 (+100d) | 2018-06-12 → 2018-09-20 (+100d) |  |  |  |  |
| 23 | Obtain approval to proceed | 2018-06-13 → 2018-09-21 (+100d) | 2018-06-13 → 2018-09-21 (+100d) |  |  |  |  |
| 24 | Design complete | 2018-06-13 → 2018-09-21 (+100d) | 2018-06-13 → 2018-09-21 (+100d) |  |  |  |  |
| 25 | **Development** | 2018-06-14 → 2018-09-24 (+102d) | 2018-07-30 → 2018-11-09 (+102d) | 33d → 35d |  | 5d → 4d |  |
| 26 | Review functional specifications | 2018-06-14 → 2018-09-24 (+102d) | 2018-06-14 → 2018-09-24 (+102d) |  |  | 5d → 4d |  |
| 27 | Identify modular/tiered design parameters | 2018-06-15 → 2018-09-25 (+102d) | 2018-06-15 → 2018-09-25 (+102d) |  |  | 5d → 4d |  |
| 28 | Assign development staff | 2018-06-18 → 2018-09-26 (+100d) | 2018-06-18 → 2018-09-26 (+100d) |  |  | 5d → 4d |  |
| 29 | Develop code | 2018-06-19 → 2018-09-27 (+100d) | 2018-07-09 → 2018-10-17 (+100d) |  |  | 5d → 4d |  |
| 30 | Developer testing (primary debugging) | 2018-07-10 → 2018-10-22 (+104d) | 2018-07-30 → 2018-11-09 (+102d) |  |  | 5d → 4d |  |
| 31 | Development complete | 2018-07-30 → 2018-11-09 (+102d) | 2018-07-30 → 2018-11-09 (+102d) |  |  | 5d → 4d |  |
| 32 | **Testing** | 2018-06-14 → 2018-09-24 (+102d) | 2018-09-05 → 2018-12-18 (+104d) | 60d → 62d |  | 20d → 19d |  |
| 33 | Develop unit test plans using product specifications | 2018-06-14 → 2018-09-24 (+102d) | 2018-06-19 → 2018-09-27 (+100d) |  |  | 34d → 35d |  |
| 34 | Develop integration test plans using product specifications | 2018-06-25 → 2018-10-03 (+100d) | 2018-08-22 → 2018-11-30 (+100d) |  |  | 30d → 31d |  |
| 35 | **Unit Testing** | 2018-07-31 → 2018-11-12 (+104d) | 2018-08-20 → 2018-11-30 (+102d) |  |  | 5d → 4d |  |
| 36 | Review modular code | 2018-07-31 → 2018-11-12 (+104d) | 2018-08-06 → 2018-11-16 (+102d) |  |  | 5d → 4d |  |
| 37 | Test component modules to product specifications | 2018-08-07 → 2018-11-19 (+104d) | 2018-08-08 → 2018-11-20 (+104d) |  |  | 5d → 4d |  |
| 38 | Identify anomalies to product specifications | 2018-08-09 → 2018-11-21 (+104d) | 2018-08-13 → 2018-11-23 (+102d) |  |  | 5d → 4d |  |
| 39 | Modify code | 2018-08-14 → 2018-11-26 (+104d) | 2018-08-16 → 2018-11-28 (+104d) |  |  | 5d → 4d |  |
| 40 | Re-test modified code | 2018-08-17 → 2018-11-29 (+104d) | 2018-08-20 → 2018-11-30 (+102d) |  |  | 5d → 4d |  |
| 41 | Unit testing complete | 2018-08-20 → 2018-11-30 (+102d) | 2018-08-20 → 2018-11-30 (+102d) |  |  | 5d → 4d |  |
| 42 | **Integration Testing** | 2018-08-21 → 2018-12-03 (+104d) | 2018-09-05 → 2018-12-18 (+104d) |  |  | 5d → 4d |  |
| 43 | Test module integration | 2018-08-21 → 2018-12-03 (+104d) | 2018-08-27 → 2018-12-07 (+102d) |  |  | 5d → 4d |  |
| 44 | Identify anomalies to specifications | 2018-08-28 → 2018-12-10 (+104d) | 2018-08-29 → 2018-12-11 (+104d) |  |  | 5d → 4d |  |
| 45 | Modify code | 2018-08-30 → 2018-12-12 (+104d) | 2018-09-03 → 2018-12-14 (+102d) |  |  | 5d → 4d |  |
| 46 | Re-test modified code | 2018-09-04 → 2018-12-17 (+104d) | 2018-09-05 → 2018-12-18 (+104d) |  |  | 5d → 4d |  |
| 47 | Integration testing complete | 2018-09-05 → 2018-12-18 (+104d) | 2018-09-05 → 2018-12-18 (+104d) |  |  | 5d → 4d |  |
| 48 | **Training** | 2018-07-31 → 2018-11-12 (+104d) | 2018-09-12 → 2018-12-24 (+103d) | 32d → 31d |  |  |  |
| 49 | Develop training specifications for end users | 2018-07-31 → 2018-11-12 (+104d) | 2018-08-02 → 2018-11-14 (+104d) |  |  | 5d → 4d |  |
| 50 | Develop training specifications for helpdesk support staff | 2018-08-03 → 2018-11-13 (+102d) | 2018-08-07 → 2018-11-15 (+100d) |  |  | 2d → 3d |  |
| 51 | Identify training delivery methodology (computer based training, classroom, etc.) | 2018-08-08 → 2018-11-19 (+103d) | 2018-08-09 → 2018-11-20 (+103d) |  |  |  |  |
| 52 | Develop training materials | 2018-08-10 → 2018-11-21 (+103d) | 2018-08-30 → 2018-12-11 (+103d) |  |  |  |  |
| 53 | Conduct training usability study | 2018-08-31 → 2018-12-12 (+103d) | 2018-09-05 → 2018-12-17 (+103d) |  |  |  |  |
| 54 | Finalize training materials | 2018-09-06 → 2018-12-18 (+103d) | 2018-09-10 → 2018-12-20 (+101d) |  |  |  |  |
| 55 | Develop training delivery mechanism | 2018-09-11 → 2018-12-21 (+101d) | 2018-09-12 → 2018-12-24 (+103d) |  |  |  |  |
| 56 | Training materials complete | 2018-09-12 → 2018-12-24 (+103d) | 2018-09-12 → 2018-12-24 (+103d) |  |  |  |  |
| 57 | **Documentation** | 2018-06-20 → 2018-10-01 (+103d) | 2018-08-21 → 2018-11-29 (+100d) | 45d → 44d |  | 16d → 17d |  |
| 58 | Develop Help specification | 2018-06-20 → 2018-10-01 (+103d) | 2018-06-20 → 2018-10-01 (+103d) |  |  | 23d → 21d |  |
| 59 | Develop Help system | 2018-06-28 → 2018-10-08 (+102d) | 2018-07-19 → 2018-10-29 (+102d) |  |  | 17.5d → 16.5d |  |
| 60 | Review Help documentation | 2018-08-09 → 2018-11-19 (+102d) | 2018-08-14 → 2018-11-22 (+100d) |  |  | 17.5d → 16.5d |  |
| 61 | Incorporate Help documentation feedback | 2018-08-20 → 2018-11-26 (+98d) | 2018-08-21 → 2018-11-28 (+99d) |  |  | 16d → 18.5d |  |
| 62 | Develop user manuals specifications | 2018-06-21 → 2018-10-01 (+102d) | 2018-06-22 → 2018-10-02 (+102d) |  |  | 20d → 22d |  |
| 63 | Develop user manuals | 2018-07-19 → 2018-10-29 (+102d) | 2018-08-09 → 2018-11-19 (+102d) |  |  | 16.5d → 18.5d |  |
| 64 | Review all user documentation | 2018-08-14 → 2018-11-26 (+104d) | 2018-08-16 → 2018-11-27 (+103d) |  |  | 17.5d → 17d |  |
| 65 | Incorporate user documentation feedback | 2018-08-16 → 2018-11-28 (+104d) | 2018-08-20 → 2018-11-29 (+101d) |  |  | 17.5d → 17d |  |
| 66 | Documentation complete | 2018-08-21 → 2018-11-29 (+100d) | 2018-08-21 → 2018-11-29 (+100d) |  |  | 16d → 17d |  |
| 67 | **Pilot** | 2018-05-24 → 2018-09-03 (+102d) | 2018-09-21 → 2019-01-02 (+103d) | 87d → 88d |  |  |  |
| 68 | Identify test group | 2018-05-24 → 2018-09-03 (+102d) | 2018-05-24 → 2018-09-03 (+102d) |  |  | 78d → 79d |  |
| 69 | Develop software delivery mechanism | 2018-05-25 → 2018-09-04 (+102d) | 2018-05-25 → 2018-09-04 (+102d) |  |  | 78d → 79d |  |
| 70 | Install/deploy software | 2018-09-13 → 2018-12-25 (+103d) | 2018-09-13 → 2018-12-25 (+103d) |  |  |  |  |

| ID | Task | Start | Finish |
| --- | --- | --- | --- |
| 71 | Obtain user feedback | 2018-09-14 → 2018-12-26 (+103d) | 2018-09-20 → 2019-01-01 (+103d) |
| 72 | Evaluate testing information | 2018-09-21 → 2019-01-02 (+103d) | 2018-09-21 → 2019-01-02 (+103d) |
| 73 | Pilot complete | 2018-09-21 → 2019-01-02 (+103d) | 2018-09-21 → 2019-01-02 (+103d) |
| 74 | **Deployment** | 2018-09-24 → 2019-01-03 (+101d) | 2018-09-28 → 2019-01-09 (+103d) |
| 75 | Determine final deployment strategy | 2018-09-24 → 2019-01-03 (+101d) | 2018-09-24 → 2019-01-03 (+101d) |
| 76 | Develop deployment methodology | 2018-09-25 → 2019-01-04 (+101d) | 2018-09-25 → 2019-01-04 (+101d) |
| 77 | Secure deployment resources | 2018-09-26 → 2019-01-07 (+103d) | 2018-09-26 → 2019-01-07 (+103d) |
| 78 | Train support staff | 2018-09-27 → 2019-01-08 (+103d) | 2018-09-27 → 2019-01-08 (+103d) |
| 79 | Deploy software | 2018-09-28 → 2019-01-09 (+103d) | 2018-09-28 → 2019-01-09 (+103d) |
| 80 | Deployment complete | 2018-09-28 → 2019-01-09 (+103d) | 2018-09-28 → 2019-01-09 (+103d) |
| 81 | **Post Implementation Review** | 2018-10-01 → 2019-01-10 (+101d) | 2018-10-03 → 2019-01-14 (+103d) |
| 82 | Document lessons learned | 2018-10-01 → 2019-01-10 (+101d) | 2018-10-01 → 2019-01-10 (+101d) |
| 83 | Distribute to team members | 2018-10-02 → 2019-01-11 (+101d) | 2018-10-02 → 2019-01-11 (+101d) |
| 84 | Create software maintenance team | 2018-10-03 → 2019-01-14 (+103d) | 2018-10-03 → 2019-01-14 (+103d) |
| 85 | Post implementation review complete | 2018-10-03 → 2019-01-14 (+103d) | 2018-10-03 → 2019-01-14 (+103d) |
| 86 | Software development template complete | 2018-10-03 → 2019-01-14 (+103d) | 2018-10-03 → 2019-01-14 (+103d) |

## Version 3 (saved 2019-03-10, file Templates.mpt)

Last finish stays 2019-01-14. Complete tasks 14 → 0.

Changed:

| ID | Task | Start | Finish | Complete | Total float | Other |
| --- | --- | --- | --- | --- | --- | --- |
| 1 | **Scope** | 2018-08-06 A → 2018-08-06 | 2018-08-15 A → 2018-08-15 | 100% → 0% | none → 0d | baseline start 2018-05-01 → none; baseline finish 2018-05-04 → none |
| 2 | Determine project scope | 2018-08-06 A → 2018-08-06 | 2018-08-06 A → 2018-08-06 | 100% → 0% | none → 0d | baseline start 2018-05-01 → none; baseline finish 2018-05-01 → none |
| 3 | Secure project sponsorship | 2018-08-07 A → 2018-08-07 | 2018-08-09 A → 2018-08-09 | 100% → 0% | none → 0d | baseline start 2018-05-02 → none; baseline finish 2018-05-02 → none |
| 4 | Define preliminary resources | 2018-08-10 A → 2018-08-10 | 2018-08-10 A → 2018-08-10 | 100% → 0% | none → 0d | baseline start 2018-05-03 → none; baseline finish 2018-05-03 → none |
| 5 | Secure core resources | 2018-08-15 A → 2018-08-15 | 2018-08-15 A → 2018-08-15 | 100% → 0% | none → 0d | baseline start 2018-05-04 → none; baseline finish 2018-05-04 → none |
| 6 | Scope complete | 2018-08-15 A → 2018-08-15 | 2018-08-15 A → 2018-08-15 | 100% → 0% | none → 0d | baseline start 2018-05-04 → none; baseline finish 2018-05-04 → none |
| 7 | **Analysis/Software Requirements** | 2018-08-16 A → 2018-08-16 | 2018-08-31 A → 2018-08-31 | 100% → 0% | none → 0d | baseline start 2018-05-07 → none; baseline finish 2018-05-23 → none |
| 8 | Conduct needs analysis | 2018-08-16 A → 2018-08-16 | 2018-08-17 A → 2018-08-17 | 100% → 0% | none → 0d | baseline start 2018-05-07 → none; baseline finish 2018-05-09 → none |
| 9 | Draft preliminary software specifications | 2018-08-20 A → 2018-08-20 | 2018-08-21 A → 2018-08-21 | 100% → 0% | none → 0d | baseline start 2018-05-10 → none; baseline finish 2018-05-15 → none |
| 10 | Develop preliminary budget | 2018-08-22 A → 2018-08-22 | 2018-08-23 A → 2018-08-23 | 100% → 0% | none → 0d | baseline start 2018-05-16 → none; baseline finish 2018-05-17 → none |
| 11 | Review software specifications/budget with team | 2018-08-22 A → 2018-08-22 | 2018-08-22 A → 2018-08-22 | 100% → 0% | none → 0d | baseline start 2018-05-16 → none; baseline finish 2018-05-16 → none |
| 12 | Incorporate feedback on software specifications | 2018-08-23 A → 2018-08-23 | 2018-08-27 A → 2018-08-27 | 100% → 0% | none → 0d | baseline start 2018-05-18 → none; baseline finish 2018-05-18 → none |
| 13 | Develop delivery timeline | 2018-08-28 A → 2018-08-28 | 2018-08-29 A → 2018-08-29 | 100% → 0% | none → 0d | baseline start 2018-05-21 → none; baseline finish 2018-05-21 → none |
| 14 | Obtain approvals to proceed (concept, timeline, budget) | 2018-08-30 A → 2018-08-30 | 2018-08-30 A → 2018-08-30 | 100% → 0% | none → 0d | baseline start 2018-05-22 → none; baseline finish 2018-05-22 → none |
| 15 | Secure required resources | 2018-08-31 A → 2018-08-31 | 2018-08-31 A → 2018-08-31 | 100% → 0% | none → 0d | baseline start 2018-05-23 → none; baseline finish 2018-05-23 → none |
| 16 | Analysis complete | 2018-08-31 A → 2018-08-31 | 2018-08-31 A → 2018-08-31 | 100% → 0% | none → 0d | baseline start 2018-05-23 → none; baseline finish 2018-05-23 → none |
| 17 | **Design** |  |  |  |  | baseline start 2018-05-24 → none; baseline finish 2018-06-13 → none |
| 18 | Review preliminary software specifications |  |  |  |  | baseline start 2018-05-24 → none; baseline finish 2018-05-25 → none |
| 19 | Develop functional specifications |  |  |  |  | baseline start 2018-05-28 → none; baseline finish 2018-06-01 → none |
| 20 | Develop prototype based on functional specifications |  |  |  |  | baseline start 2018-06-04 → none; baseline finish 2018-06-07 → none |
| 21 | Review functional specifications |  |  |  |  | baseline start 2018-06-08 → none; baseline finish 2018-06-11 → none |
| 22 | Incorporate feedback into functional specifications |  |  |  |  | baseline start 2018-06-12 → none; baseline finish 2018-06-12 → none |
| 23 | Obtain approval to proceed |  |  |  |  | baseline start 2018-06-13 → none; baseline finish 2018-06-13 → none |
| 24 | Design complete |  |  |  |  | baseline start 2018-06-13 → none; baseline finish 2018-06-13 → none |
| 25 | **Development** |  |  |  |  | baseline start 2018-06-14 → none; baseline finish 2018-07-30 → none |
| 26 | Review functional specifications |  |  |  |  | baseline start 2018-06-14 → none; baseline finish 2018-06-14 → none |
| 27 | Identify modular/tiered design parameters |  |  |  |  | baseline start 2018-06-15 → none; baseline finish 2018-06-15 → none |
| 28 | Assign development staff |  |  |  |  | baseline start 2018-06-18 → none; baseline finish 2018-06-18 → none |
| 29 | Develop code |  |  |  |  | baseline start 2018-06-19 → none; baseline finish 2018-07-09 → none |
| 30 | Developer testing (primary debugging) |  |  |  |  | baseline start 2018-07-10 → none; baseline finish 2018-07-30 → none |
| 31 | Development complete |  |  |  |  | baseline start 2018-07-30 → none; baseline finish 2018-07-30 → none |
| 32 | **Testing** |  |  |  |  | baseline start 2018-06-14 → none; baseline finish 2018-09-05 → none |
| 33 | Develop unit test plans using product specifications |  |  |  |  | baseline start 2018-06-14 → none; baseline finish 2018-06-19 → none |
| 34 | Develop integration test plans using product specifications |  |  |  |  | baseline start 2018-06-25 → none; baseline finish 2018-08-22 → none |
| 35 | **Unit Testing** |  |  |  |  | baseline start 2018-07-31 → none; baseline finish 2018-08-20 → none |
| 36 | Review modular code |  |  |  |  | baseline start 2018-07-31 → none; baseline finish 2018-08-06 → none |
| 37 | Test component modules to product specifications |  |  |  |  | baseline start 2018-08-07 → none; baseline finish 2018-08-08 → none |
| 38 | Identify anomalies to product specifications |  |  |  |  | baseline start 2018-08-09 → none; baseline finish 2018-08-13 → none |
| 39 | Modify code |  |  |  |  | baseline start 2018-08-14 → none; baseline finish 2018-08-16 → none |
| 40 | Re-test modified code |  |  |  |  | baseline start 2018-08-17 → none; baseline finish 2018-08-20 → none |
| 41 | Unit testing complete |  |  |  |  | baseline start 2018-08-20 → none; baseline finish 2018-08-20 → none |
| 42 | **Integration Testing** |  |  |  |  | baseline start 2018-08-21 → none; baseline finish 2018-09-05 → none |
| 43 | Test module integration |  |  |  |  | baseline start 2018-08-21 → none; baseline finish 2018-08-27 → none |
| 44 | Identify anomalies to specifications |  |  |  |  | baseline start 2018-08-28 → none; baseline finish 2018-08-29 → none |
| 45 | Modify code |  |  |  |  | baseline start 2018-08-30 → none; baseline finish 2018-09-03 → none |
| 46 | Re-test modified code |  |  |  |  | baseline start 2018-09-04 → none; baseline finish 2018-09-05 → none |
| 47 | Integration testing complete |  |  |  |  | baseline start 2018-09-05 → none; baseline finish 2018-09-05 → none |
| 48 | **Training** |  |  |  |  | baseline start 2018-07-31 → none; baseline finish 2018-09-12 → none |
| 49 | Develop training specifications for end users |  |  |  |  | baseline start 2018-07-31 → none; baseline finish 2018-08-02 → none |
| 50 | Develop training specifications for helpdesk support staff |  |  |  |  | baseline start 2018-08-03 → none; baseline finish 2018-08-07 → none |
| 51 | Identify training delivery methodology (computer based training, classroom, etc.) |  |  |  |  | baseline start 2018-08-08 → none; baseline finish 2018-08-09 → none |
| 52 | Develop training materials |  |  |  |  | baseline start 2018-08-10 → none; baseline finish 2018-08-30 → none |
| 53 | Conduct training usability study |  |  |  |  | baseline start 2018-08-31 → none; baseline finish 2018-09-05 → none |
| 54 | Finalize training materials |  |  |  |  | baseline start 2018-09-06 → none; baseline finish 2018-09-10 → none |
| 55 | Develop training delivery mechanism |  |  |  |  | baseline start 2018-09-11 → none; baseline finish 2018-09-12 → none |
| 56 | Training materials complete |  |  |  |  | baseline start 2018-09-12 → none; baseline finish 2018-09-12 → none |
| 57 | **Documentation** |  |  |  |  | baseline start 2018-06-20 → none; baseline finish 2018-08-21 → none |
| 58 | Develop Help specification |  |  |  |  | baseline start 2018-06-20 → none; baseline finish 2018-06-20 → none |
| 59 | Develop Help system |  |  |  |  | baseline start 2018-06-28 → none; baseline finish 2018-07-19 → none |
| 60 | Review Help documentation |  |  |  |  | baseline start 2018-08-09 → none; baseline finish 2018-08-14 → none |
| 61 | Incorporate Help documentation feedback |  |  |  |  | baseline start 2018-08-20 → none; baseline finish 2018-08-21 → none |
| 62 | Develop user manuals specifications |  |  |  |  | baseline start 2018-06-21 → none; baseline finish 2018-06-22 → none |
| 63 | Develop user manuals |  |  |  |  | baseline start 2018-07-19 → none; baseline finish 2018-08-09 → none |
| 64 | Review all user documentation |  |  |  |  | baseline start 2018-08-14 → none; baseline finish 2018-08-16 → none |
| 65 | Incorporate user documentation feedback |  |  |  |  | baseline start 2018-08-16 → none; baseline finish 2018-08-20 → none |
| 66 | Documentation complete |  |  |  |  | baseline start 2018-08-21 → none; baseline finish 2018-08-21 → none |
| 67 | **Pilot** |  |  |  |  | baseline start 2018-05-24 → none; baseline finish 2018-09-21 → none |
| 68 | Identify test group |  |  |  |  | baseline start 2018-05-24 → none; baseline finish 2018-05-24 → none |
| 69 | Develop software delivery mechanism |  |  |  |  | baseline start 2018-05-25 → none; baseline finish 2018-05-25 → none |
| 70 | Install/deploy software |  |  |  |  | baseline start 2018-09-13 → none; baseline finish 2018-09-13 → none |

| ID | Task | Other |
| --- | --- | --- |
| 71 | Obtain user feedback | baseline start 2018-09-14 → none; baseline finish 2018-09-20 → none |
| 72 | Evaluate testing information | baseline start 2018-09-21 → none; baseline finish 2018-09-21 → none |
| 73 | Pilot complete | baseline start 2018-09-21 → none; baseline finish 2018-09-21 → none |
| 74 | **Deployment** | baseline start 2018-09-24 → none; baseline finish 2018-09-28 → none |
| 75 | Determine final deployment strategy | baseline start 2018-09-24 → none; baseline finish 2018-09-24 → none |
| 76 | Develop deployment methodology | baseline start 2018-09-25 → none; baseline finish 2018-09-25 → none |
| 77 | Secure deployment resources | baseline start 2018-09-26 → none; baseline finish 2018-09-26 → none |
| 78 | Train support staff | baseline start 2018-09-27 → none; baseline finish 2018-09-27 → none |
| 79 | Deploy software | baseline start 2018-09-28 → none; baseline finish 2018-09-28 → none |
| 80 | Deployment complete | baseline start 2018-09-28 → none; baseline finish 2018-09-28 → none |
| 81 | **Post Implementation Review** | baseline start 2018-10-01 → none; baseline finish 2018-10-03 → none |
| 82 | Document lessons learned | baseline start 2018-10-01 → none; baseline finish 2018-10-01 → none |
| 83 | Distribute to team members | baseline start 2018-10-02 → none; baseline finish 2018-10-02 → none |
| 84 | Create software maintenance team | baseline start 2018-10-03 → none; baseline finish 2018-10-03 → none |
| 85 | Post implementation review complete | baseline start 2018-10-03 → none; baseline finish 2018-10-03 → none |
| 86 | Software development template complete | baseline start 2018-10-03 → none; baseline finish 2018-10-03 → none |

## Version 4 (saved 2019-03-10, file SubProject_Construction.mpp)

Last finish 2019-01-14 → 2019-08-06 (+204d).

Changed:

| ID | Task | Start | Finish | Duration | Total float | Other |
| --- | --- | --- | --- | --- | --- | --- |
| 1 | **Scope** | 2018-08-06 → 2019-03-04 (+210d) | 2018-08-15 → 2019-03-12 (+209d) | 8d → 7d |  | baseline start none → 2018-05-01; baseline finish none → 2018-05-04 |
| 2 | Determine project scope | 2018-08-06 → 2019-03-04 (+210d) | 2018-08-06 → 2019-03-05 (+211d) | 1d → 2d |  | baseline start none → 2018-05-01; baseline finish none → 2018-05-01 |
| 3 | Secure project sponsorship | 2018-08-07 → 2019-03-06 (+211d) | 2018-08-09 → 2019-03-06 (+209d) | 3d → 1d |  | baseline start none → 2018-05-02; baseline finish none → 2018-05-02 |
| 4 | Define preliminary resources | 2018-08-10 → 2019-03-07 (+209d) | 2018-08-10 → 2019-03-11 (+213d) | 1d → 3d |  | resources Steve Masters → Project Manager; baseline start none → 2018-05-03; baseline finish none → 2018-05-03 |
| 5 | Secure core resources | 2018-08-15 → 2019-03-12 (+209d) | 2018-08-15 → 2019-03-12 (+209d) |  |  | resources Steve Masters → Project Manager; baseline start none → 2018-05-04; baseline finish none → 2018-05-04 |
| 6 | Scope complete | 2018-08-15 → 2019-03-12 (+209d) | 2018-08-15 → 2019-03-12 (+209d) |  |  | baseline start none → 2018-05-04; baseline finish none → 2018-05-04 |
| 7 | **Analysis/Software Requirements** | 2018-08-16 → 2019-03-13 (+209d) | 2018-08-31 → 2019-03-26 (+207d) | 12d → 10d |  | baseline start none → 2018-05-07; baseline finish none → 2018-05-23 |
| 8 | Conduct needs analysis | 2018-08-16 → 2019-03-13 (+209d) | 2018-08-17 → 2019-03-13 (+208d) | 2d → 1d |  | baseline start none → 2018-05-07; baseline finish none → 2018-05-09 |
| 9 | Draft preliminary software specifications | 2018-08-20 → 2019-03-14 (+206d) | 2018-08-21 → 2019-03-19 (+210d) | 2d → 4d |  | baseline start none → 2018-05-10; baseline finish none → 2018-05-15 |
| 10 | Develop preliminary budget | 2018-08-22 → 2019-03-20 (+210d) | 2018-08-23 → 2019-03-21 (+210d) |  |  | baseline start none → 2018-05-16; baseline finish none → 2018-05-17 |
| 11 | Review software specifications/budget with team | 2018-08-22 → 2019-03-20 (+210d) | 2018-08-22 → 2019-03-20 (+210d) |  |  | baseline start none → 2018-05-16; baseline finish none → 2018-05-16 |
| 12 | Incorporate feedback on software specifications | 2018-08-23 → 2019-03-21 (+210d) | 2018-08-27 → 2019-03-21 (+206d) | 3d → 1d |  | baseline start none → 2018-05-18; baseline finish none → 2018-05-18 |
| 13 | Develop delivery timeline | 2018-08-28 → 2019-03-22 (+206d) | 2018-08-29 → 2019-03-22 (+205d) | 2d → 1d |  | baseline start none → 2018-05-21; baseline finish none → 2018-05-21 |
| 14 | Obtain approvals to proceed (concept, timeline, budget) | 2018-08-30 → 2019-03-25 (+207d) | 2018-08-30 → 2019-03-25 (+207d) |  |  | baseline start none → 2018-05-22; baseline finish none → 2018-05-22 |
| 15 | Secure required resources | 2018-08-31 → 2019-03-26 (+207d) | 2018-08-31 → 2019-03-26 (+207d) |  |  | baseline start none → 2018-05-23; baseline finish none → 2018-05-23 |
| 16 | Analysis complete | 2018-08-31 → 2019-03-26 (+207d) | 2018-08-31 → 2019-03-26 (+207d) |  |  | baseline start none → 2018-05-23; baseline finish none → 2018-05-23 |
| 17 | **Design** | 2018-09-03 → 2019-03-27 (+205d) | 2018-09-21 → 2019-04-16 (+207d) |  |  | baseline start none → 2018-05-24; baseline finish none → 2018-06-13 |
| 18 | Review preliminary software specifications | 2018-09-03 → 2019-03-27 (+205d) | 2018-09-04 → 2019-03-28 (+205d) |  |  | baseline start none → 2018-05-24; baseline finish none → 2018-05-25 |
| 19 | Develop functional specifications | 2018-09-05 → 2019-03-29 (+205d) | 2018-09-11 → 2019-04-04 (+205d) |  |  | baseline start none → 2018-05-28; baseline finish none → 2018-06-01 |
| 20 | Develop prototype based on functional specifications | 2018-09-12 → 2019-04-05 (+205d) | 2018-09-17 → 2019-04-10 (+205d) |  |  | baseline start none → 2018-06-04; baseline finish none → 2018-06-07 |
| 21 | Review functional specifications | 2018-09-18 → 2019-04-11 (+205d) | 2018-09-19 → 2019-04-12 (+205d) |  |  | baseline start none → 2018-06-08; baseline finish none → 2018-06-11 |
| 22 | Incorporate feedback into functional specifications | 2018-09-20 → 2019-04-15 (+207d) | 2018-09-20 → 2019-04-15 (+207d) |  |  | baseline start none → 2018-06-12; baseline finish none → 2018-06-12 |
| 23 | Obtain approval to proceed | 2018-09-21 → 2019-04-16 (+207d) | 2018-09-21 → 2019-04-16 (+207d) |  |  | baseline start none → 2018-06-13; baseline finish none → 2018-06-13 |
| 24 | Design complete | 2018-09-21 → 2019-04-16 (+207d) | 2018-09-21 → 2019-04-16 (+207d) |  |  | baseline start none → 2018-06-13; baseline finish none → 2018-06-13 |
| 25 | **Development** | 2018-09-24 → 2019-04-17 (+205d) | 2018-11-09 → 2019-05-31 (+203d) | 35d → 33d | 4d → 5d | baseline start none → 2018-06-14; baseline finish none → 2018-07-30 |
| 26 | Review functional specifications | 2018-09-24 → 2019-04-17 (+205d) | 2018-09-24 → 2019-04-17 (+205d) |  | 4d → 5d | baseline start none → 2018-06-14; baseline finish none → 2018-06-14 |
| 27 | Identify modular/tiered design parameters | 2018-09-25 → 2019-04-18 (+205d) | 2018-09-25 → 2019-04-18 (+205d) |  | 4d → 5d | baseline start none → 2018-06-15; baseline finish none → 2018-06-15 |
| 28 | Assign development staff | 2018-09-26 → 2019-04-19 (+205d) | 2018-09-26 → 2019-04-19 (+205d) |  | 4d → 5d | baseline start none → 2018-06-18; baseline finish none → 2018-06-18 |
| 29 | Develop code | 2018-09-27 → 2019-04-22 (+207d) | 2018-10-17 → 2019-05-10 (+205d) |  | 4d → 5d | baseline start none → 2018-06-19; baseline finish none → 2018-07-09 |
| 30 | Developer testing (primary debugging) | 2018-10-22 → 2019-05-13 (+203d) | 2018-11-09 → 2019-05-31 (+203d) |  | 4d → 5d | baseline start none → 2018-07-10; baseline finish none → 2018-07-30 |
| 31 | Development complete | 2018-11-09 → 2019-05-31 (+203d) | 2018-11-09 → 2019-05-31 (+203d) |  | 4d → 5d | baseline start none → 2018-07-30; baseline finish none → 2018-07-30 |
| 32 | **Testing** | 2018-09-24 → 2019-04-17 (+205d) | 2018-12-18 → 2019-07-09 (+203d) | 62d → 60d | 19d → 20d | baseline start none → 2018-06-14; baseline finish none → 2018-09-05 |
| 33 | Develop unit test plans using product specifications | 2018-09-24 → 2019-04-17 (+205d) | 2018-09-27 → 2019-04-22 (+207d) |  | 35d → 34d | baseline start none → 2018-06-14; baseline finish none → 2018-06-19 |
| 34 | Develop integration test plans using product specifications | 2018-10-03 → 2019-04-26 (+205d) | 2018-11-30 → 2019-06-25 (+207d) |  | 31d → 30d | baseline start none → 2018-06-25; baseline finish none → 2018-08-22 |
| 35 | **Unit Testing** | 2018-11-12 → 2019-06-03 (+203d) | 2018-11-30 → 2019-06-21 (+203d) |  | 4d → 5d | baseline start none → 2018-07-31; baseline finish none → 2018-08-20 |
| 36 | Review modular code | 2018-11-12 → 2019-06-03 (+203d) | 2018-11-16 → 2019-06-07 (+203d) |  | 4d → 5d | baseline start none → 2018-07-31; baseline finish none → 2018-08-06 |
| 37 | Test component modules to product specifications | 2018-11-19 → 2019-06-10 (+203d) | 2018-11-20 → 2019-06-11 (+203d) |  | 4d → 5d | baseline start none → 2018-08-07; baseline finish none → 2018-08-08 |
| 38 | Identify anomalies to product specifications | 2018-11-21 → 2019-06-12 (+203d) | 2018-11-23 → 2019-06-14 (+203d) |  | 4d → 5d | baseline start none → 2018-08-09; baseline finish none → 2018-08-13 |
| 39 | Modify code | 2018-11-26 → 2019-06-17 (+203d) | 2018-11-28 → 2019-06-19 (+203d) |  | 4d → 5d | baseline start none → 2018-08-14; baseline finish none → 2018-08-16 |
| 40 | Re-test modified code | 2018-11-29 → 2019-06-20 (+203d) | 2018-11-30 → 2019-06-21 (+203d) |  | 4d → 5d | baseline start none → 2018-08-17; baseline finish none → 2018-08-20 |
| 41 | Unit testing complete | 2018-11-30 → 2019-06-21 (+203d) | 2018-11-30 → 2019-06-21 (+203d) |  | 4d → 5d | baseline start none → 2018-08-20; baseline finish none → 2018-08-20 |
| 42 | **Integration Testing** | 2018-12-03 → 2019-06-24 (+203d) | 2018-12-18 → 2019-07-09 (+203d) |  | 4d → 5d | baseline start none → 2018-08-21; baseline finish none → 2018-09-05 |
| 43 | Test module integration | 2018-12-03 → 2019-06-24 (+203d) | 2018-12-07 → 2019-06-28 (+203d) |  | 4d → 5d | baseline start none → 2018-08-21; baseline finish none → 2018-08-27 |
| 44 | Identify anomalies to specifications | 2018-12-10 → 2019-07-01 (+203d) | 2018-12-11 → 2019-07-02 (+203d) |  | 4d → 5d | baseline start none → 2018-08-28; baseline finish none → 2018-08-29 |
| 45 | Modify code | 2018-12-12 → 2019-07-03 (+203d) | 2018-12-14 → 2019-07-05 (+203d) |  | 4d → 5d | baseline start none → 2018-08-30; baseline finish none → 2018-09-03 |
| 46 | Re-test modified code | 2018-12-17 → 2019-07-08 (+203d) | 2018-12-18 → 2019-07-09 (+203d) |  | 4d → 5d | baseline start none → 2018-09-04; baseline finish none → 2018-09-05 |
| 47 | Integration testing complete | 2018-12-18 → 2019-07-09 (+203d) | 2018-12-18 → 2019-07-09 (+203d) |  | 4d → 5d | baseline start none → 2018-09-05; baseline finish none → 2018-09-05 |
| 48 | **Training** | 2018-11-12 → 2019-06-03 (+203d) | 2018-12-24 → 2019-07-16 (+204d) | 31d → 32d |  | baseline start none → 2018-07-31; baseline finish none → 2018-09-12 |
| 49 | Develop training specifications for end users | 2018-11-12 → 2019-06-03 (+203d) | 2018-11-14 → 2019-06-05 (+203d) |  | 4d → 5d | baseline start none → 2018-07-31; baseline finish none → 2018-08-02 |
| 50 | Develop training specifications for helpdesk support staff | 2018-11-13 → 2019-06-06 (+205d) | 2018-11-15 → 2019-06-10 (+207d) |  | 3d → 2d | baseline start none → 2018-08-03; baseline finish none → 2018-08-07 |
| 51 | Identify training delivery methodology (computer based training, classroom, etc.) | 2018-11-19 → 2019-06-11 (+204d) | 2018-11-20 → 2019-06-12 (+204d) |  |  | baseline start none → 2018-08-08; baseline finish none → 2018-08-09 |
| 52 | Develop training materials | 2018-11-21 → 2019-06-13 (+204d) | 2018-12-11 → 2019-07-03 (+204d) |  |  | baseline start none → 2018-08-10; baseline finish none → 2018-08-30 |
| 53 | Conduct training usability study | 2018-12-12 → 2019-07-04 (+204d) | 2018-12-17 → 2019-07-09 (+204d) |  |  | baseline start none → 2018-08-31; baseline finish none → 2018-09-05 |
| 54 | Finalize training materials | 2018-12-18 → 2019-07-10 (+204d) | 2018-12-20 → 2019-07-12 (+204d) |  |  | baseline start none → 2018-09-06; baseline finish none → 2018-09-10 |
| 55 | Develop training delivery mechanism | 2018-12-21 → 2019-07-15 (+206d) | 2018-12-24 → 2019-07-16 (+204d) |  |  | baseline start none → 2018-09-11; baseline finish none → 2018-09-12 |
| 56 | Training materials complete | 2018-12-24 → 2019-07-16 (+204d) | 2018-12-24 → 2019-07-16 (+204d) |  |  | baseline start none → 2018-09-12; baseline finish none → 2018-09-12 |
| 57 | **Documentation** | 2018-10-01 → 2019-04-23 (+204d) | 2018-11-29 → 2019-06-25 (+208d) | 44d → 45.5d | 17d → 15.5d | baseline start none → 2018-06-20; baseline finish none → 2018-08-21 |
| 58 | Develop Help specification | 2018-10-01 → 2019-04-23 (+204d) | 2018-10-01 → 2019-04-23 (+204d) |  | 21d → 23d | baseline start none → 2018-06-20; baseline finish none → 2018-06-20 |
| 59 | Develop Help system | 2018-10-08 → 2019-05-01 (+205d) | 2018-10-29 → 2019-05-22 (+205d) |  | 16.5d → 17.5d | baseline start none → 2018-06-28; baseline finish none → 2018-07-19 |
| 60 | Review Help documentation | 2018-11-19 → 2019-06-12 (+205d) | 2018-11-22 → 2019-06-17 (+207d) |  | 16.5d → 17.5d | baseline start none → 2018-08-09; baseline finish none → 2018-08-14 |
| 61 | Incorporate Help documentation feedback | 2018-11-26 → 2019-06-21 (+207d) | 2018-11-28 → 2019-06-25 (+209d) |  | 18.5d → 15.5d | baseline start none → 2018-08-20; baseline finish none → 2018-08-21 |
| 62 | Develop user manuals specifications | 2018-10-01 → 2019-04-24 (+205d) | 2018-10-02 → 2019-04-25 (+205d) |  | 22d → 21d | baseline start none → 2018-06-21; baseline finish none → 2018-06-22 |
| 63 | Develop user manuals | 2018-10-29 → 2019-05-22 (+205d) | 2018-11-19 → 2019-06-12 (+205d) |  | 18.5d → 17.5d | baseline start none → 2018-07-19; baseline finish none → 2018-08-09 |
| 64 | Review all user documentation | 2018-11-26 → 2019-06-17 (+203d) | 2018-11-27 → 2019-06-19 (+204d) |  | 17d → 17.5d | baseline start none → 2018-08-14; baseline finish none → 2018-08-16 |
| 65 | Incorporate user documentation feedback | 2018-11-28 → 2019-06-19 (+203d) | 2018-11-29 → 2019-06-21 (+204d) |  | 17d → 17.5d | baseline start none → 2018-08-16; baseline finish none → 2018-08-20 |
| 66 | Documentation complete | 2018-11-29 → 2019-06-25 (+208d) | 2018-11-29 → 2019-06-25 (+208d) |  | 17d → 15.5d | baseline start none → 2018-08-21; baseline finish none → 2018-08-21 |
| 67 | **Pilot** | 2018-09-03 → 2019-03-27 (+205d) | 2019-01-02 → 2019-07-25 (+204d) | 88d → 87d |  | baseline start none → 2018-05-24; baseline finish none → 2018-09-21 |
| 68 | Identify test group | 2018-09-03 → 2019-03-27 (+205d) | 2018-09-03 → 2019-03-27 (+205d) |  | 79d → 78d | baseline start none → 2018-05-24; baseline finish none → 2018-05-24 |
| 69 | Develop software delivery mechanism | 2018-09-04 → 2019-03-28 (+205d) | 2018-09-04 → 2019-03-28 (+205d) |  | 79d → 78d | baseline start none → 2018-05-25; baseline finish none → 2018-05-25 |
| 70 | Install/deploy software | 2018-12-25 → 2019-07-17 (+204d) | 2018-12-25 → 2019-07-17 (+204d) |  |  | baseline start none → 2018-09-13; baseline finish none → 2018-09-13 |

| ID | Task | Start | Finish | Other |
| --- | --- | --- | --- | --- |
| 71 | Obtain user feedback | 2018-12-26 → 2019-07-18 (+204d) | 2019-01-01 → 2019-07-24 (+204d) | baseline start none → 2018-09-14; baseline finish none → 2018-09-20 |
| 72 | Evaluate testing information | 2019-01-02 → 2019-07-25 (+204d) | 2019-01-02 → 2019-07-25 (+204d) | baseline start none → 2018-09-21; baseline finish none → 2018-09-21 |
| 73 | Pilot complete | 2019-01-02 → 2019-07-25 (+204d) | 2019-01-02 → 2019-07-25 (+204d) | baseline start none → 2018-09-21; baseline finish none → 2018-09-21 |
| 74 | **Deployment** | 2019-01-03 → 2019-07-26 (+204d) | 2019-01-09 → 2019-08-01 (+204d) | baseline start none → 2018-09-24; baseline finish none → 2018-09-28 |
| 75 | Determine final deployment strategy | 2019-01-03 → 2019-07-26 (+204d) | 2019-01-03 → 2019-07-26 (+204d) | baseline start none → 2018-09-24; baseline finish none → 2018-09-24 |
| 76 | Develop deployment methodology | 2019-01-04 → 2019-07-29 (+206d) | 2019-01-04 → 2019-07-29 (+206d) | baseline start none → 2018-09-25; baseline finish none → 2018-09-25 |
| 77 | Secure deployment resources | 2019-01-07 → 2019-07-30 (+204d) | 2019-01-07 → 2019-07-30 (+204d) | baseline start none → 2018-09-26; baseline finish none → 2018-09-26 |
| 78 | Train support staff | 2019-01-08 → 2019-07-31 (+204d) | 2019-01-08 → 2019-07-31 (+204d) | baseline start none → 2018-09-27; baseline finish none → 2018-09-27 |
| 79 | Deploy software | 2019-01-09 → 2019-08-01 (+204d) | 2019-01-09 → 2019-08-01 (+204d) | baseline start none → 2018-09-28; baseline finish none → 2018-09-28 |
| 80 | Deployment complete | 2019-01-09 → 2019-08-01 (+204d) | 2019-01-09 → 2019-08-01 (+204d) | baseline start none → 2018-09-28; baseline finish none → 2018-09-28 |
| 81 | **Post Implementation Review** | 2019-01-10 → 2019-08-02 (+204d) | 2019-01-14 → 2019-08-06 (+204d) | baseline start none → 2018-10-01; baseline finish none → 2018-10-03 |
| 82 | Document lessons learned | 2019-01-10 → 2019-08-02 (+204d) | 2019-01-10 → 2019-08-02 (+204d) | baseline start none → 2018-10-01; baseline finish none → 2018-10-01 |
| 83 | Distribute to team members | 2019-01-11 → 2019-08-05 (+206d) | 2019-01-11 → 2019-08-05 (+206d) | baseline start none → 2018-10-02; baseline finish none → 2018-10-02 |
| 84 | Create software maintenance team | 2019-01-14 → 2019-08-06 (+204d) | 2019-01-14 → 2019-08-06 (+204d) | baseline start none → 2018-10-03; baseline finish none → 2018-10-03 |
| 85 | Post implementation review complete | 2019-01-14 → 2019-08-06 (+204d) | 2019-01-14 → 2019-08-06 (+204d) | baseline start none → 2018-10-03; baseline finish none → 2018-10-03 |
| 86 | Software development template complete | 2019-01-14 → 2019-08-06 (+204d) | 2019-01-14 → 2019-08-06 (+204d) | baseline start none → 2018-10-03; baseline finish none → 2018-10-03 |

## Version 5 (saved 2019-03-10, file SubProject_Development.mpp)

Last finish 2019-08-06 → 2019-09-23 (+48d).

Removed: 1 Scope; 2 Determine project scope; 3 Secure project sponsorship; 4 Define preliminary resources; 5 Secure core resources; 6 Scope complete; 7 Analysis/Software Requirements; 8 Conduct needs analysis; 9 Draft preliminary software specifications; 10 Develop preliminary budget; 11 Review software specifications/budget with team; 12 Incorporate feedback on software specifications; 13 Develop delivery timeline; 14 Obtain approvals to proceed (concept, timeline, budget); 15 Secure required resources; 16 Analysis complete; 17 Design; 18 Review preliminary software specifications; 19 Develop functional specifications; 20 Develop prototype based on functional specifications; 21 Review functional specifications; 22 Incorporate feedback into functional specifications; 23 Obtain approval to proceed; 24 Design complete

Changed:

| ID | Task | Start | Finish | Duration | Total float | Predecessors |
| --- | --- | --- | --- | --- | --- | --- |
| 1 | **Development** | 2019-04-17 → 2019-06-03 (+47d) | 2019-05-31 → 2019-07-19 (+49d) | 33d → 35d | 5d → 4d |  |
| 2 | Review functional specifications | 2019-04-17 → 2019-06-03 (+47d) | 2019-04-17 → 2019-06-03 (+47d) |  | 5d → 4d | Design complete → none |
| 3 | Identify modular/tiered design parameters | 2019-04-18 → 2019-06-04 (+47d) | 2019-04-18 → 2019-06-04 (+47d) |  | 5d → 4d |  |
| 4 | Assign development staff | 2019-04-19 → 2019-06-05 (+47d) | 2019-04-19 → 2019-06-05 (+47d) |  | 5d → 4d |  |
| 5 | Develop code | 2019-04-22 → 2019-06-06 (+45d) | 2019-05-10 → 2019-06-26 (+47d) |  | 5d → 4d |  |
| 6 | Developer testing (primary debugging) | 2019-05-13 → 2019-07-01 (+49d) | 2019-05-31 → 2019-07-19 (+49d) |  | 5d → 4d |  |
| 7 | Development complete | 2019-05-31 → 2019-07-19 (+49d) | 2019-05-31 → 2019-07-19 (+49d) |  | 5d → 4d |  |
| 8 | **Testing** | 2019-04-17 → 2019-06-03 (+47d) | 2019-07-09 → 2019-08-27 (+49d) | 60d → 62d | 20d → 19d |  |
| 9 | Develop unit test plans using product specifications | 2019-04-17 → 2019-06-03 (+47d) | 2019-04-22 → 2019-06-06 (+45d) |  | 34d → 35d | Design complete → none |
| 10 | Develop integration test plans using product specifications | 2019-04-26 → 2019-06-12 (+47d) | 2019-06-25 → 2019-08-09 (+45d) |  | 30d → 31d | Design complete → none |
| 11 | **Unit Testing** | 2019-06-03 → 2019-07-22 (+49d) | 2019-06-21 → 2019-08-09 (+49d) |  | 5d → 4d |  |
| 12 | Review modular code | 2019-06-03 → 2019-07-22 (+49d) | 2019-06-07 → 2019-07-26 (+49d) |  | 5d → 4d |  |
| 13 | Test component modules to product specifications | 2019-06-10 → 2019-07-29 (+49d) | 2019-06-11 → 2019-07-30 (+49d) |  | 5d → 4d |  |
| 14 | Identify anomalies to product specifications | 2019-06-12 → 2019-07-31 (+49d) | 2019-06-14 → 2019-08-02 (+49d) |  | 5d → 4d |  |
| 15 | Modify code | 2019-06-17 → 2019-08-05 (+49d) | 2019-06-19 → 2019-08-07 (+49d) |  | 5d → 4d |  |
| 16 | Re-test modified code | 2019-06-20 → 2019-08-08 (+49d) | 2019-06-21 → 2019-08-09 (+49d) |  | 5d → 4d |  |
| 17 | Unit testing complete | 2019-06-21 → 2019-08-09 (+49d) | 2019-06-21 → 2019-08-09 (+49d) |  | 5d → 4d |  |
| 18 | **Integration Testing** | 2019-06-24 → 2019-08-12 (+49d) | 2019-07-09 → 2019-08-27 (+49d) |  | 5d → 4d |  |
| 19 | Test module integration | 2019-06-24 → 2019-08-12 (+49d) | 2019-06-28 → 2019-08-16 (+49d) |  | 5d → 4d |  |
| 20 | Identify anomalies to specifications | 2019-07-01 → 2019-08-19 (+49d) | 2019-07-02 → 2019-08-20 (+49d) |  | 5d → 4d |  |
| 21 | Modify code | 2019-07-03 → 2019-08-21 (+49d) | 2019-07-05 → 2019-08-23 (+49d) |  | 5d → 4d |  |
| 22 | Re-test modified code | 2019-07-08 → 2019-08-26 (+49d) | 2019-07-09 → 2019-08-27 (+49d) |  | 5d → 4d |  |
| 23 | Integration testing complete | 2019-07-09 → 2019-08-27 (+49d) | 2019-07-09 → 2019-08-27 (+49d) |  | 5d → 4d |  |
| 24 | **Training** | 2019-06-03 → 2019-07-22 (+49d) | 2019-07-16 → 2019-09-02 (+48d) | 32d → 31d |  |  |
| 25 | Develop training specifications for end users | 2019-06-03 → 2019-07-22 (+49d) | 2019-06-05 → 2019-07-24 (+49d) |  | 5d → 4d | Design complete → none |
| 26 | Develop training specifications for helpdesk support staff | 2019-06-06 → 2019-07-23 (+47d) | 2019-06-10 → 2019-07-25 (+45d) |  | 2d → 3d | Design complete → none |
| 27 | Identify training delivery methodology (computer based training, classroom, etc.) | 2019-06-11 → 2019-07-29 (+48d) | 2019-06-12 → 2019-07-30 (+48d) |  |  | Design complete → none |
| 28 | Develop training materials | 2019-06-13 → 2019-07-31 (+48d) | 2019-07-03 → 2019-08-20 (+48d) |  |  |  |
| 29 | Conduct training usability study | 2019-07-04 → 2019-08-21 (+48d) | 2019-07-09 → 2019-08-26 (+48d) |  |  |  |
| 30 | Finalize training materials | 2019-07-10 → 2019-08-27 (+48d) | 2019-07-12 → 2019-08-29 (+48d) |  |  |  |
| 31 | Develop training delivery mechanism | 2019-07-15 → 2019-08-30 (+46d) | 2019-07-16 → 2019-09-02 (+48d) |  |  |  |
| 32 | Training materials complete | 2019-07-16 → 2019-09-02 (+48d) | 2019-07-16 → 2019-09-02 (+48d) |  |  |  |
| 33 | **Documentation** | 2019-04-23 → 2019-06-10 (+48d) | 2019-06-25 → 2019-08-08 (+44d) | 45.5d → 44d | 15.5d → 17d |  |
| 34 | Develop Help specification | 2019-04-23 → 2019-06-10 (+48d) | 2019-04-23 → 2019-06-10 (+48d) |  | 23d → 21d | Design complete → none |
| 35 | Develop Help system | 2019-05-01 → 2019-06-17 (+47d) | 2019-05-22 → 2019-07-08 (+47d) |  | 17.5d → 16.5d |  |
| 36 | Review Help documentation | 2019-06-12 → 2019-07-29 (+47d) | 2019-06-17 → 2019-08-01 (+45d) |  | 17.5d → 16.5d |  |
| 37 | Incorporate Help documentation feedback | 2019-06-21 → 2019-08-05 (+45d) | 2019-06-25 → 2019-08-07 (+43d) |  | 15.5d → 18.5d |  |
| 38 | Develop user manuals specifications | 2019-04-24 → 2019-06-10 (+47d) | 2019-04-25 → 2019-06-11 (+47d) |  | 21d → 22d | Design complete → none |
| 39 | Develop user manuals | 2019-05-22 → 2019-07-08 (+47d) | 2019-06-12 → 2019-07-29 (+47d) |  | 17.5d → 18.5d |  |
| 40 | Review all user documentation | 2019-06-17 → 2019-08-05 (+49d) | 2019-06-19 → 2019-08-06 (+48d) |  | 17.5d → 17d |  |
| 41 | Incorporate user documentation feedback | 2019-06-19 → 2019-08-07 (+49d) | 2019-06-21 → 2019-08-08 (+48d) |  | 17.5d → 17d |  |
| 42 | Documentation complete | 2019-06-25 → 2019-08-08 (+44d) | 2019-06-25 → 2019-08-08 (+44d) |  | 15.5d → 17d |  |
| 43 | **Pilot** | 2019-03-27 → 2019-06-03 (+68d) | 2019-07-25 → 2019-09-11 (+48d) | 87d → 73d |  |  |
| 44 | Identify test group | 2019-03-27 → 2019-06-03 (+68d) | 2019-03-27 → 2019-06-03 (+68d) |  | 78d → 64d | Analysis complete → none |
| 45 | Develop software delivery mechanism | 2019-03-28 → 2019-06-04 (+68d) | 2019-03-28 → 2019-06-04 (+68d) |  | 78d → 64d |  |
| 46 | Install/deploy software | 2019-07-17 → 2019-09-03 (+48d) | 2019-07-17 → 2019-09-03 (+48d) |  |  |  |
| 47 | Obtain user feedback | 2019-07-18 → 2019-09-04 (+48d) | 2019-07-24 → 2019-09-10 (+48d) |  |  |  |
| 48 | Evaluate testing information | 2019-07-25 → 2019-09-11 (+48d) | 2019-07-25 → 2019-09-11 (+48d) |  |  |  |
| 49 | Pilot complete | 2019-07-25 → 2019-09-11 (+48d) | 2019-07-25 → 2019-09-11 (+48d) |  |  |  |
| 50 | **Deployment** | 2019-07-26 → 2019-09-12 (+48d) | 2019-08-01 → 2019-09-18 (+48d) |  |  |  |
| 51 | Determine final deployment strategy | 2019-07-26 → 2019-09-12 (+48d) | 2019-07-26 → 2019-09-12 (+48d) |  |  |  |
| 52 | Develop deployment methodology | 2019-07-29 → 2019-09-13 (+46d) | 2019-07-29 → 2019-09-13 (+46d) |  |  |  |
| 53 | Secure deployment resources | 2019-07-30 → 2019-09-16 (+48d) | 2019-07-30 → 2019-09-16 (+48d) |  |  |  |
| 54 | Train support staff | 2019-07-31 → 2019-09-17 (+48d) | 2019-07-31 → 2019-09-17 (+48d) |  |  |  |
| 55 | Deploy software | 2019-08-01 → 2019-09-18 (+48d) | 2019-08-01 → 2019-09-18 (+48d) |  |  |  |
| 56 | Deployment complete | 2019-08-01 → 2019-09-18 (+48d) | 2019-08-01 → 2019-09-18 (+48d) |  |  |  |
| 57 | **Post Implementation Review** | 2019-08-02 → 2019-09-19 (+48d) | 2019-08-06 → 2019-09-23 (+48d) |  |  |  |
| 58 | Document lessons learned | 2019-08-02 → 2019-09-19 (+48d) | 2019-08-02 → 2019-09-19 (+48d) |  |  |  |
| 59 | Distribute to team members | 2019-08-05 → 2019-09-20 (+46d) | 2019-08-05 → 2019-09-20 (+46d) |  |  |  |
| 60 | Create software maintenance team | 2019-08-06 → 2019-09-23 (+48d) | 2019-08-06 → 2019-09-23 (+48d) |  |  |  |
| 61 | Post implementation review complete | 2019-08-06 → 2019-09-23 (+48d) | 2019-08-06 → 2019-09-23 (+48d) |  |  |  |
| 62 | Software development template complete | 2019-08-06 → 2019-09-23 (+48d) | 2019-08-06 → 2019-09-23 (+48d) |  |  |  |

## Version 6 (saved 2019-03-14, file AdvancedReports.mpp)

Last finish 2019-09-23 → 2019-06-12 (-103d). Complete tasks 0 → 14.

Added:

| ID | Task | Duration | Start | Finish | Predecessors | Resources |
| --- | --- | --- | --- | --- | --- | --- |
| 1 | **Scope** | 5d | 2019-01-07 A | 2019-01-11 A |  |  |
| 2 | Determine project scope | 1d | 2019-01-07 A | 2019-01-07 A |  | Steve Masters |
| 3 | Secure project sponsorship | 2d | 2019-01-08 A | 2019-01-09 A | 2 | Steve Masters [25%]; Flight [0.6%] |
| 4 | Define preliminary resources | 1d | 2019-01-10 A | 2019-01-10 A | 3 | Steve Masters |
| 5 | Secure core resources | 1d | 2019-01-11 A | 2019-01-11 A | 4 | Steve Masters |
| 6 | Scope complete | 0d | 2019-01-11 A | 2019-01-11 A | 5 |  |
| 7 | **Analysis/Software Requirements** | 12d | 2019-01-15 A | 2019-01-30 A |  |  |
| 8 | Conduct needs analysis | 2d | 2019-01-15 A | 2019-01-16 A | 6 | Kim Ralls; Rob Young |
| 9 | Draft preliminary software specifications | 2d | 2019-01-17 A | 2019-01-18 A | 8 | Kim Ralls [50%]; Rob Young [50%] |
| 10 | Develop preliminary budget | 3d | 2019-01-22 A | 2019-01-24 A | 9 | Kim Ralls [50%]; Rob Young |
| 11 | Review software specifications/budget with team | 1d | 2019-01-22 A | 2019-01-22 A | 10SS | Steve Masters |
| 12 | Incorporate feedback on software specifications | 3d | 2019-01-23 A | 2019-01-25 A | 11 | Kim Ralls |
| 13 | Develop delivery timeline | 1d | 2019-01-28 A | 2019-01-28 A | 12 | Kim Ralls |
| 14 | Obtain approvals to proceed (concept, timeline, budget) | 1d | 2019-01-29 A | 2019-01-29 A | 13 | Kim Ralls |
| 15 | Secure required resources | 1d | 2019-01-30 A | 2019-01-30 A | 14 | Kim Ralls |
| 16 | Analysis complete | 0d | 2019-01-30 A | 2019-01-30 A | 15 |  |
| 17 | **Design** | 15d | 2019-01-31 | 2019-02-20 |  |  |
| 18 | Review preliminary software specifications | 2d | 2019-01-31 | 2019-02-01 | 16 | Kim Ralls |
| 19 | Develop functional specifications | 5d | 2019-02-04 | 2019-02-08 | 18 | Kim Ralls |
| 20 | Develop prototype based on functional specifications | 4d | 2019-02-11 | 2019-02-14 | 19 | Kim Ralls |
| 21 | Review functional specifications | 2d | 2019-02-15 | 2019-02-18 | 20 | Kim Ralls |
| 22 | Incorporate feedback into functional specifications | 1d | 2019-02-19 | 2019-02-19 | 21 | Kim Ralls |
| 23 | Obtain approval to proceed | 1d | 2019-02-20 | 2019-02-20 | 22 | Kim Ralls |
| 24 | Design complete | 0d | 2019-02-20 | 2019-02-20 | 23 |  |

Changed:

| ID | Task | Start | Finish | Duration | Total float | Predecessors | Other |
| --- | --- | --- | --- | --- | --- | --- | --- |
| 25 | **Development** | 2019-06-03 → 2019-02-21 (-102d) | 2019-07-19 → 2019-04-08 (-102d) | 35d → 33d | 4d → 5d |  | baseline start 2018-06-14 → 2019-02-21; baseline finish 2018-07-30 → 2019-04-08 |
| 26 | Review functional specifications | 2019-06-03 → 2019-02-21 (-102d) | 2019-06-03 → 2019-02-21 (-102d) |  | 4d → 5d | none → 24 | baseline start 2018-06-14 → 2019-02-21; baseline finish 2018-06-14 → 2019-02-21 |
| 27 | Identify modular/tiered design parameters | 2019-06-04 → 2019-02-22 (-102d) | 2019-06-04 → 2019-02-22 (-102d) |  | 4d → 5d |  | baseline start 2018-06-15 → 2019-02-22; baseline finish 2018-06-15 → 2019-02-22 |
| 28 | Assign development staff | 2019-06-05 → 2019-02-25 (-100d) | 2019-06-05 → 2019-02-25 (-100d) |  | 4d → 5d |  | baseline start 2018-06-18 → 2019-02-25; baseline finish 2018-06-18 → 2019-02-25 |
| 29 | Develop code | 2019-06-06 → 2019-02-26 (-100d) | 2019-06-26 → 2019-03-18 (-100d) |  | 4d → 5d |  | baseline start 2018-06-19 → 2019-02-26; baseline finish 2018-07-09 → 2019-03-18 |
| 30 | Developer testing (primary debugging) | 2019-07-01 → 2019-03-19 (-104d) | 2019-07-19 → 2019-04-08 (-102d) |  | 4d → 5d |  | baseline start 2018-07-10 → 2019-03-19; baseline finish 2018-07-30 → 2019-04-08 |
| 31 | Development complete | 2019-07-19 → 2019-04-08 (-102d) | 2019-07-19 → 2019-04-08 (-102d) |  | 4d → 5d |  | baseline start 2018-07-30 → 2019-04-08; baseline finish 2018-07-30 → 2019-04-08 |
| 32 | **Testing** | 2019-06-03 → 2019-02-21 (-102d) | 2019-08-27 → 2019-05-15 (-104d) | 62d → 60d | 19d → 20d |  | baseline start 2018-06-14 → 2019-02-21; baseline finish 2018-09-05 → 2019-05-15 |
| 33 | Develop unit test plans using product specifications | 2019-06-03 → 2019-02-21 (-102d) | 2019-06-06 → 2019-02-26 (-100d) |  | 35d → 34d | none → 24 | baseline start 2018-06-14 → 2019-02-21; baseline finish 2018-06-19 → 2019-02-26 |
| 34 | Develop integration test plans using product specifications | 2019-06-12 → 2019-03-04 (-100d) | 2019-08-09 → 2019-05-01 (-100d) |  | 31d → 30d | none → 24 | baseline start 2018-06-25 → 2019-03-04; baseline finish 2018-08-22 → 2019-05-01 |
| 35 | **Unit Testing** | 2019-07-22 → 2019-04-09 (-104d) | 2019-08-09 → 2019-04-29 (-102d) |  | 4d → 5d |  | baseline start 2018-07-31 → 2019-04-09; baseline finish 2018-08-20 → 2019-04-29 |
| 36 | Review modular code | 2019-07-22 → 2019-04-09 (-104d) | 2019-07-26 → 2019-04-15 (-102d) |  | 4d → 5d |  | baseline start 2018-07-31 → 2019-04-09; baseline finish 2018-08-06 → 2019-04-15 |
| 37 | Test component modules to product specifications | 2019-07-29 → 2019-04-16 (-104d) | 2019-07-30 → 2019-04-17 (-104d) |  | 4d → 5d |  | baseline start 2018-08-07 → 2019-04-16; baseline finish 2018-08-08 → 2019-04-17 |
| 38 | Identify anomalies to product specifications | 2019-07-31 → 2019-04-18 (-104d) | 2019-08-02 → 2019-04-22 (-102d) |  | 4d → 5d |  | baseline start 2018-08-09 → 2019-04-18; baseline finish 2018-08-13 → 2019-04-22 |
| 39 | Modify code | 2019-08-05 → 2019-04-23 (-104d) | 2019-08-07 → 2019-04-25 (-104d) |  | 4d → 5d |  | baseline start 2018-08-14 → 2019-04-23; baseline finish 2018-08-16 → 2019-04-25 |
| 40 | Re-test modified code | 2019-08-08 → 2019-04-26 (-104d) | 2019-08-09 → 2019-04-29 (-102d) |  | 4d → 5d |  | baseline start 2018-08-17 → 2019-04-26; baseline finish 2018-08-20 → 2019-04-29 |
| 41 | Unit testing complete | 2019-08-09 → 2019-04-29 (-102d) | 2019-08-09 → 2019-04-29 (-102d) |  | 4d → 5d |  | baseline start 2018-08-20 → 2019-04-29; baseline finish 2018-08-20 → 2019-04-29 |
| 42 | **Integration Testing** | 2019-08-12 → 2019-04-30 (-104d) | 2019-08-27 → 2019-05-15 (-104d) |  | 4d → 5d |  | baseline start 2018-08-21 → 2019-04-30; baseline finish 2018-09-05 → 2019-05-15 |
| 43 | Test module integration | 2019-08-12 → 2019-04-30 (-104d) | 2019-08-16 → 2019-05-06 (-102d) |  | 4d → 5d |  | baseline start 2018-08-21 → 2019-04-30; baseline finish 2018-08-27 → 2019-05-06 |
| 44 | Identify anomalies to specifications | 2019-08-19 → 2019-05-07 (-104d) | 2019-08-20 → 2019-05-08 (-104d) |  | 4d → 5d |  | baseline start 2018-08-28 → 2019-05-07; baseline finish 2018-08-29 → 2019-05-08 |
| 45 | Modify code | 2019-08-21 → 2019-05-09 (-104d) | 2019-08-23 → 2019-05-13 (-102d) |  | 4d → 5d |  | baseline start 2018-08-30 → 2019-05-09; baseline finish 2018-09-03 → 2019-05-13 |
| 46 | Re-test modified code | 2019-08-26 → 2019-05-14 (-104d) | 2019-08-27 → 2019-05-15 (-104d) |  | 4d → 5d |  | baseline start 2018-09-04 → 2019-05-14; baseline finish 2018-09-05 → 2019-05-15 |
| 47 | Integration testing complete | 2019-08-27 → 2019-05-15 (-104d) | 2019-08-27 → 2019-05-15 (-104d) |  | 4d → 5d |  | baseline start 2018-09-05 → 2019-05-15; baseline finish 2018-09-05 → 2019-05-15 |
| 48 | **Training** | 2019-07-22 → 2019-04-09 (-104d) | 2019-09-02 → 2019-05-22 (-103d) | 31d → 32d |  |  | baseline start 2018-07-31 → 2019-04-09; baseline finish 2018-09-12 → 2019-05-22 |
| 49 | Develop training specifications for end users | 2019-07-22 → 2019-04-09 (-104d) | 2019-07-24 → 2019-04-11 (-104d) |  | 4d → 5d | none → 24 | baseline start 2018-07-31 → 2019-04-09; baseline finish 2018-08-02 → 2019-04-11 |
| 50 | Develop training specifications for helpdesk support staff | 2019-07-23 → 2019-04-12 (-102d) | 2019-07-25 → 2019-04-16 (-100d) |  | 3d → 2d | none → 24 | baseline start 2018-08-03 → 2019-04-12; baseline finish 2018-08-07 → 2019-04-16 |
| 51 | Identify training delivery methodology (computer based training, classroom, etc.) | 2019-07-29 → 2019-04-17 (-103d) | 2019-07-30 → 2019-04-18 (-103d) |  |  | none → 24 | baseline start 2018-08-08 → 2019-04-17; baseline finish 2018-08-09 → 2019-04-18 |
| 52 | Develop training materials | 2019-07-31 → 2019-04-19 (-103d) | 2019-08-20 → 2019-05-09 (-103d) |  |  |  | baseline start 2018-08-10 → 2019-04-19; baseline finish 2018-08-30 → 2019-05-09 |
| 53 | Conduct training usability study | 2019-08-21 → 2019-05-10 (-103d) | 2019-08-26 → 2019-05-15 (-103d) |  |  |  | baseline start 2018-08-31 → 2019-05-10; baseline finish 2018-09-05 → 2019-05-15 |
| 54 | Finalize training materials | 2019-08-27 → 2019-05-16 (-103d) | 2019-08-29 → 2019-05-20 (-101d) |  |  |  | baseline start 2018-09-06 → 2019-05-16; baseline finish 2018-09-10 → 2019-05-20 |
| 55 | Develop training delivery mechanism | 2019-08-30 → 2019-05-21 (-101d) | 2019-09-02 → 2019-05-22 (-103d) |  |  |  | baseline start 2018-09-11 → 2019-05-21; baseline finish 2018-09-12 → 2019-05-22 |
| 56 | Training materials complete | 2019-09-02 → 2019-05-22 (-103d) | 2019-09-02 → 2019-05-22 (-103d) |  |  |  | baseline start 2018-09-12 → 2019-05-22; baseline finish 2018-09-12 → 2019-05-22 |
| 57 | **Documentation** | 2019-06-10 → 2019-02-27 (-103d) | 2019-08-08 → 2019-04-30 (-100d) | 44d → 45d | 17d → 14d |  | baseline start 2018-06-20 → 2019-02-27; baseline finish 2018-08-21 → 2019-04-30 |
| 58 | Develop Help specification | 2019-06-10 → 2019-02-27 (-103d) | 2019-06-10 → 2019-02-27 (-103d) |  | 21d → 19d | none → 24 | baseline start 2018-06-20 → 2019-02-27; baseline finish 2018-06-20 → 2019-02-27 |
| 59 | Develop Help system | 2019-06-17 → 2019-03-07 (-102d) | 2019-07-08 → 2019-03-28 (-102d) |  | 16.5d → 13.5d |  | baseline start 2018-06-28 → 2019-03-07; baseline finish 2018-07-19 → 2019-03-28 |
| 60 | Review Help documentation | 2019-07-29 → 2019-04-18 (-102d) | 2019-08-01 → 2019-04-23 (-100d) |  | 16.5d → 13.5d |  | baseline start 2018-08-09 → 2019-04-18; baseline finish 2018-08-14 → 2019-04-23 |
| 61 | Incorporate Help documentation feedback | 2019-08-05 → 2019-04-29 (-98d) | 2019-08-07 → 2019-04-30 (-99d) |  | 18.5d → 14d |  | baseline start 2018-08-20 → 2019-04-29; baseline finish 2018-08-21 → 2019-04-30 |
| 62 | Develop user manuals specifications | 2019-06-10 → 2019-02-28 (-102d) | 2019-06-11 → 2019-03-01 (-102d) |  | 22d → 19d | none → 24 | baseline start 2018-06-21 → 2019-02-28; baseline finish 2018-06-22 → 2019-03-01 |
| 63 | Develop user manuals | 2019-07-08 → 2019-03-28 (-102d) | 2019-07-29 → 2019-04-18 (-102d) |  | 18.5d → 15.5d |  | baseline start 2018-07-19 → 2019-03-28; baseline finish 2018-08-09 → 2019-04-18 |
| 64 | Review all user documentation | 2019-08-05 → 2019-04-23 (-104d) | 2019-08-06 → 2019-04-25 (-103d) |  | 17d → 15.5d |  | baseline start 2018-08-14 → 2019-04-23; baseline finish 2018-08-16 → 2019-04-25 |
| 65 | Incorporate user documentation feedback | 2019-08-07 → 2019-04-25 (-104d) | 2019-08-08 → 2019-04-29 (-101d) |  | 17d → 15.5d |  | baseline start 2018-08-16 → 2019-04-25; baseline finish 2018-08-20 → 2019-04-29 |
| 66 | Documentation complete | 2019-08-08 → 2019-04-30 (-100d) | 2019-08-08 → 2019-04-30 (-100d) |  | 17d → 14d |  | baseline start 2018-08-21 → 2019-04-30; baseline finish 2018-08-21 → 2019-04-30 |
| 67 | **Pilot** | 2019-06-03 → 2019-05-01 (-33d) | 2019-09-11 → 2019-05-31 (-103d) | 73d → 23d |  |  | baseline start 2018-05-24 → 2019-05-01; baseline finish 2018-09-21 → 2019-05-31 |
| 68 | Identify test group | 2019-06-03 → 2019-05-01 (-33d) | 2019-06-03 → 2019-05-01 (-33d) |  | 64d → 14d | none → 66 | baseline start 2018-05-24 → 2019-05-01; baseline finish 2018-05-24 → 2019-05-01 |
| 69 | Develop software delivery mechanism | 2019-06-04 → 2019-05-02 (-33d) | 2019-06-04 → 2019-05-02 (-33d) |  | 64d → 14d |  | baseline start 2018-05-25 → 2019-05-02; baseline finish 2018-05-25 → 2019-05-02 |
| 70 | Install/deploy software | 2019-09-03 → 2019-05-23 (-103d) | 2019-09-03 → 2019-05-23 (-103d) |  |  |  | baseline start 2018-09-13 → 2019-05-23; baseline finish 2018-09-13 → 2019-05-23 |
| 71 | Obtain user feedback | 2019-09-04 → 2019-05-24 (-103d) | 2019-09-10 → 2019-05-30 (-103d) |  |  |  | baseline start 2018-09-14 → 2019-05-24; baseline finish 2018-09-20 → 2019-05-30 |
| 72 | Evaluate testing information | 2019-09-11 → 2019-05-31 (-103d) | 2019-09-11 → 2019-05-31 (-103d) |  |  |  | baseline start 2018-09-21 → 2019-05-31; baseline finish 2018-09-21 → 2019-05-31 |
| 73 | Pilot complete | 2019-09-11 → 2019-05-31 (-103d) | 2019-09-11 → 2019-05-31 (-103d) |  |  |  | baseline start 2018-09-21 → 2019-05-31; baseline finish 2018-09-21 → 2019-05-31 |
| 74 | **Deployment** | 2019-09-12 → 2019-06-03 (-101d) | 2019-09-18 → 2019-06-07 (-103d) |  |  |  | baseline start 2018-09-24 → 2019-06-03; baseline finish 2018-09-28 → 2019-06-07 |
| 75 | Determine final deployment strategy | 2019-09-12 → 2019-06-03 (-101d) | 2019-09-12 → 2019-06-03 (-101d) |  |  |  | baseline start 2018-09-24 → 2019-06-03; baseline finish 2018-09-24 → 2019-06-03 |
| 76 | Develop deployment methodology | 2019-09-13 → 2019-06-04 (-101d) | 2019-09-13 → 2019-06-04 (-101d) |  |  |  | baseline start 2018-09-25 → 2019-06-04; baseline finish 2018-09-25 → 2019-06-04 |
| 77 | Secure deployment resources | 2019-09-16 → 2019-06-05 (-103d) | 2019-09-16 → 2019-06-05 (-103d) |  |  |  | baseline start 2018-09-26 → 2019-06-05; baseline finish 2018-09-26 → 2019-06-05 |
| 78 | Train support staff | 2019-09-17 → 2019-06-06 (-103d) | 2019-09-17 → 2019-06-06 (-103d) |  |  |  | baseline start 2018-09-27 → 2019-06-06; baseline finish 2018-09-27 → 2019-06-06 |
| 79 | Deploy software | 2019-09-18 → 2019-06-07 (-103d) | 2019-09-18 → 2019-06-07 (-103d) |  |  |  | baseline start 2018-09-28 → 2019-06-07; baseline finish 2018-09-28 → 2019-06-07 |
| 80 | Deployment complete | 2019-09-18 → 2019-06-07 (-103d) | 2019-09-18 → 2019-06-07 (-103d) |  |  |  | baseline start 2018-09-28 → 2019-06-07; baseline finish 2018-09-28 → 2019-06-07 |
| 81 | **Post Implementation Review** | 2019-09-19 → 2019-06-10 (-101d) | 2019-09-23 → 2019-06-12 (-103d) |  |  |  | baseline start 2018-10-01 → 2019-06-10; baseline finish 2018-10-03 → 2019-06-12 |
| 82 | Document lessons learned | 2019-09-19 → 2019-06-10 (-101d) | 2019-09-19 → 2019-06-10 (-101d) |  |  |  | baseline start 2018-10-01 → 2019-06-10; baseline finish 2018-10-01 → 2019-06-10 |
| 83 | Distribute to team members | 2019-09-20 → 2019-06-11 (-101d) | 2019-09-20 → 2019-06-11 (-101d) |  |  |  | baseline start 2018-10-02 → 2019-06-11; baseline finish 2018-10-02 → 2019-06-11 |
| 84 | Create software maintenance team | 2019-09-23 → 2019-06-12 (-103d) | 2019-09-23 → 2019-06-12 (-103d) |  |  |  | baseline start 2018-10-03 → 2019-06-12; baseline finish 2018-10-03 → 2019-06-12 |
| 85 | Post implementation review complete | 2019-09-23 → 2019-06-12 (-103d) | 2019-09-23 → 2019-06-12 (-103d) |  |  |  | baseline start 2018-10-03 → 2019-06-12; baseline finish 2018-10-03 → 2019-06-12 |
| 86 | Software development complete | 2019-09-23 → 2019-06-12 (-103d) | 2019-09-23 → 2019-06-12 (-103d) |  |  |  | was named Software development template complete; baseline start 2018-10-03 → 2019-06-12; baseline finish 2018-10-03 → 2019-06-12 |

## Version 7 (saved 2019-03-14, file TrackingProgress.mpp)

Last finish 2019-06-12 → 2019-06-10 (-2d). Complete tasks 14 → 0.

Changed:

| ID | Task | Start | Finish | Duration | Complete | Total float | Other |
| --- | --- | --- | --- | --- | --- | --- | --- |
| 1 | **Scope** | 2019-01-07 A → 2019-01-07 | 2019-01-11 A → 2019-01-11 |  | 100% → 0% | none → 0d | baseline start 2019-01-07 → none; baseline finish 2019-01-14 → none |
| 2 | Determine project scope | 2019-01-07 A → 2019-01-07 | 2019-01-07 A → 2019-01-07 |  | 100% → 0% | none → 0d | baseline start 2019-01-07 → none; baseline finish 2019-01-07 → none |
| 3 | Secure project sponsorship | 2019-01-08 A → 2019-01-08 | 2019-01-09 A → 2019-01-09 |  | 100% → 0% | none → 0d | baseline start 2019-01-08 → none; baseline finish 2019-01-10 → none |
| 4 | Define preliminary resources | 2019-01-10 A → 2019-01-10 | 2019-01-10 A → 2019-01-10 |  | 100% → 0% | none → 0d | baseline start 2019-01-11 → none; baseline finish 2019-01-11 → none |
| 5 | Secure core resources | 2019-01-11 A → 2019-01-11 | 2019-01-11 A → 2019-01-11 |  | 100% → 0% | none → 0d | baseline start 2019-01-14 → none; baseline finish 2019-01-14 → none |
| 6 | Scope complete | 2019-01-11 A → 2019-01-11 | 2019-01-11 A → 2019-01-11 |  | 100% → 0% | none → 0d | baseline start 2019-01-14 → none; baseline finish 2019-01-14 → none |
| 7 | **Analysis/Software Requirements** | 2019-01-15 A → 2019-01-14 (-1d) | 2019-01-30 A → 2019-01-28 (-2d) | 12d → 11d | 100% → 0% | none → 0d | baseline start 2019-01-15 → none; baseline finish 2019-01-30 → none |
| 8 | Conduct needs analysis | 2019-01-15 A → 2019-01-14 (-1d) | 2019-01-16 A → 2019-01-15 (-1d) |  | 100% → 0% | none → 0d | baseline start 2019-01-15 → none; baseline finish 2019-01-16 → none |
| 9 | Draft preliminary software specifications | 2019-01-17 A → 2019-01-16 (-1d) | 2019-01-18 A → 2019-01-17 (-1d) |  | 100% → 0% | none → 0d | baseline start 2019-01-17 → none; baseline finish 2019-01-18 → none |
| 10 | Develop preliminary budget | 2019-01-22 A → 2019-01-18 (-4d) | 2019-01-24 A → 2019-01-22 (-2d) |  | 100% → 0% | none → 0d | baseline start 2019-01-21 → none; baseline finish 2019-01-22 → none |
| 11 | Review software specifications/budget with team | 2019-01-22 A → 2019-01-18 (-4d) | 2019-01-22 A → 2019-01-18 (-4d) |  | 100% → 0% | none → 0d | baseline start 2019-01-21 → none; baseline finish 2019-01-21 → none |
| 12 | Incorporate feedback on software specifications | 2019-01-23 A → 2019-01-21 (-2d) | 2019-01-25 A → 2019-01-23 (-2d) |  | 100% → 0% | none → 0d | baseline start 2019-01-22 → none; baseline finish 2019-01-24 → none |
| 13 | Develop delivery timeline | 2019-01-28 A → 2019-01-24 (-4d) | 2019-01-28 A → 2019-01-24 (-4d) |  | 100% → 0% | none → 0d | baseline start 2019-01-25 → none; baseline finish 2019-01-28 → none |
| 14 | Obtain approvals to proceed (concept, timeline, budget) | 2019-01-29 A → 2019-01-25 (-4d) | 2019-01-29 A → 2019-01-25 (-4d) |  | 100% → 0% | none → 0d | baseline start 2019-01-29 → none; baseline finish 2019-01-29 → none |
| 15 | Secure required resources | 2019-01-30 A → 2019-01-28 (-2d) | 2019-01-30 A → 2019-01-28 (-2d) |  | 100% → 0% | none → 0d | baseline start 2019-01-30 → none; baseline finish 2019-01-30 → none |
| 16 | Analysis complete | 2019-01-30 A → 2019-01-28 (-2d) | 2019-01-30 A → 2019-01-28 (-2d) |  | 100% → 0% | none → 0d | baseline start 2019-01-30 → none; baseline finish 2019-01-30 → none |
| 17 | **Design** | 2019-01-31 → 2019-01-29 (-2d) | 2019-02-20 → 2019-02-18 (-2d) |  |  |  | baseline start 2019-01-31 → none; baseline finish 2019-02-20 → none |
| 18 | Review preliminary software specifications | 2019-01-31 → 2019-01-29 (-2d) | 2019-02-01 → 2019-01-30 (-2d) |  |  |  | baseline start 2019-01-31 → none; baseline finish 2019-02-01 → none |
| 19 | Develop functional specifications | 2019-02-04 → 2019-01-31 (-4d) | 2019-02-08 → 2019-02-06 (-2d) |  |  |  | baseline start 2019-02-04 → none; baseline finish 2019-02-08 → none |
| 20 | Develop prototype based on functional specifications | 2019-02-11 → 2019-02-07 (-4d) | 2019-02-14 → 2019-02-12 (-2d) |  |  |  | baseline start 2019-02-11 → none; baseline finish 2019-02-14 → none |
| 21 | Review functional specifications | 2019-02-15 → 2019-02-13 (-2d) | 2019-02-18 → 2019-02-14 (-4d) |  |  |  | baseline start 2019-02-15 → none; baseline finish 2019-02-18 → none |
| 22 | Incorporate feedback into functional specifications | 2019-02-19 → 2019-02-15 (-4d) | 2019-02-19 → 2019-02-15 (-4d) |  |  |  | baseline start 2019-02-19 → none; baseline finish 2019-02-19 → none |
| 23 | Obtain approval to proceed | 2019-02-20 → 2019-02-18 (-2d) | 2019-02-20 → 2019-02-18 (-2d) |  |  |  | baseline start 2019-02-20 → none; baseline finish 2019-02-20 → none |
| 24 | Design complete | 2019-02-20 → 2019-02-18 (-2d) | 2019-02-20 → 2019-02-18 (-2d) |  |  |  | baseline start 2019-02-20 → none; baseline finish 2019-02-20 → none |
| 25 | **Development** | 2019-02-21 → 2019-02-19 (-2d) | 2019-04-08 → 2019-04-05 (-3d) | 33d → 34d |  | 5d → 3d |  |
| 26 | Review functional specifications | 2019-02-21 → 2019-02-19 (-2d) | 2019-02-21 → 2019-02-19 (-2d) |  |  | 5d → 3d | baseline start 2019-02-21 → none; baseline finish 2019-02-21 → none |
| 27 | Identify modular/tiered design parameters | 2019-02-22 → 2019-02-20 (-2d) | 2019-02-22 → 2019-02-20 (-2d) |  |  | 5d → 3d | baseline start 2019-02-22 → none; baseline finish 2019-02-22 → none |
| 28 | Assign development staff | 2019-02-25 → 2019-02-21 (-4d) | 2019-02-25 → 2019-02-21 (-4d) |  |  | 5d → 3d | baseline start 2019-02-25 → none; baseline finish 2019-02-25 → none |
| 29 | Develop code | 2019-02-26 → 2019-02-22 (-4d) | 2019-03-18 → 2019-03-14 (-4d) |  |  | 5d → 3d | baseline start 2019-02-26 → none; baseline finish 2019-03-18 → none |
| 30 | Developer testing (primary debugging) | 2019-03-19 → 2019-03-18 (-1d) | 2019-04-08 → 2019-04-05 (-3d) |  |  | 5d → 4d | baseline start 2019-03-19 → none; baseline finish 2019-04-08 → none |
| 31 | Development complete | 2019-04-08 → 2019-04-05 (-3d) | 2019-04-08 → 2019-04-05 (-3d) |  |  | 5d → 4d | baseline start 2019-04-08 → none; baseline finish 2019-04-08 → none |
| 32 | **Testing** | 2019-02-21 → 2019-02-19 (-2d) | 2019-05-15 → 2019-05-14 (-1d) | 60d → 61d |  | 20d → 19d |  |
| 33 | Develop unit test plans using product specifications | 2019-02-21 → 2019-02-19 (-2d) | 2019-02-26 → 2019-02-22 (-4d) |  |  |  | baseline start 2019-02-21 → none; baseline finish 2019-02-26 → none |
| 34 | Develop integration test plans using product specifications | 2019-03-04 → 2019-02-28 (-4d) | 2019-05-01 → 2019-04-29 (-2d) |  |  |  | baseline start 2019-03-04 → none; baseline finish 2019-05-01 → none |
| 35 | **Unit Testing** | 2019-04-09 → 2019-04-08 (-1d) | 2019-04-29 → 2019-04-26 (-3d) |  |  | 5d → 4d |  |
| 36 | Review modular code | 2019-04-09 → 2019-04-08 (-1d) | 2019-04-15 → 2019-04-12 (-3d) |  |  | 5d → 4d | baseline start 2019-04-09 → none; baseline finish 2019-04-15 → none |
| 37 | Test component modules to product specifications | 2019-04-16 → 2019-04-15 (-1d) | 2019-04-17 → 2019-04-16 (-1d) |  |  | 5d → 4d | baseline start 2019-04-16 → none; baseline finish 2019-04-17 → none |
| 38 | Identify anomalies to product specifications | 2019-04-18 → 2019-04-17 (-1d) | 2019-04-22 → 2019-04-19 (-3d) |  |  | 5d → 4d | baseline start 2019-04-18 → none; baseline finish 2019-04-22 → none |
| 39 | Modify code | 2019-04-23 → 2019-04-22 (-1d) | 2019-04-25 → 2019-04-24 (-1d) |  |  | 5d → 4d | baseline start 2019-04-23 → none; baseline finish 2019-04-25 → none |
| 40 | Re-test modified code | 2019-04-26 → 2019-04-25 (-1d) | 2019-04-29 → 2019-04-26 (-3d) |  |  | 5d → 4d | baseline start 2019-04-26 → none; baseline finish 2019-04-29 → none |
| 41 | Unit testing complete | 2019-04-29 → 2019-04-26 (-3d) | 2019-04-29 → 2019-04-26 (-3d) |  |  | 5d → 4d | baseline start 2019-04-29 → none; baseline finish 2019-04-29 → none |
| 42 | **Integration Testing** | 2019-04-30 → 2019-04-29 (-1d) | 2019-05-15 → 2019-05-14 (-1d) |  |  | 5d → 4d |  |
| 43 | Test module integration | 2019-04-30 → 2019-04-29 (-1d) | 2019-05-06 → 2019-05-03 (-3d) |  |  | 5d → 4d | baseline start 2019-04-30 → none; baseline finish 2019-05-06 → none |
| 44 | Identify anomalies to specifications | 2019-05-07 → 2019-05-06 (-1d) | 2019-05-08 → 2019-05-07 (-1d) |  |  | 5d → 4d | baseline start 2019-05-07 → none; baseline finish 2019-05-08 → none |
| 45 | Modify code | 2019-05-09 → 2019-05-08 (-1d) | 2019-05-13 → 2019-05-10 (-3d) |  |  | 5d → 4d | baseline start 2019-05-09 → none; baseline finish 2019-05-13 → none |
| 46 | Re-test modified code | 2019-05-14 → 2019-05-13 (-1d) | 2019-05-15 → 2019-05-14 (-1d) |  |  | 5d → 4d | baseline start 2019-05-14 → none; baseline finish 2019-05-15 → none |
| 47 | Integration testing complete | 2019-05-15 → 2019-05-14 (-1d) | 2019-05-15 → 2019-05-14 (-1d) |  |  | 5d → 4d | baseline start 2019-05-15 → none; baseline finish 2019-05-15 → none |
| 48 | **Training** | 2019-04-09 → 2019-04-08 (-1d) | 2019-05-22 → 2019-05-20 (-2d) | 32d → 31d |  |  |  |
| 49 | Develop training specifications for end users | 2019-04-09 → 2019-04-08 (-1d) | 2019-04-11 → 2019-04-10 (-1d) |  |  | 5d → 4d | baseline start 2019-04-09 → none; baseline finish 2019-04-11 → none |
| 50 | Develop training specifications for helpdesk support staff | 2019-04-12 → 2019-04-10 (-2d) | 2019-04-16 → 2019-04-12 (-4d) |  |  |  | baseline start 2019-04-12 → none; baseline finish 2019-04-16 → none |
| 51 | Identify training delivery methodology (computer based training, classroom, etc.) | 2019-04-17 → 2019-04-15 (-2d) | 2019-04-18 → 2019-04-16 (-2d) |  |  |  | baseline start 2019-04-17 → none; baseline finish 2019-04-18 → none |
| 52 | Develop training materials | 2019-04-19 → 2019-04-17 (-2d) | 2019-05-09 → 2019-05-07 (-2d) |  |  |  | baseline start 2019-04-19 → none; baseline finish 2019-05-09 → none |
| 53 | Conduct training usability study | 2019-05-10 → 2019-05-08 (-2d) | 2019-05-15 → 2019-05-13 (-2d) |  |  |  | baseline start 2019-05-10 → none; baseline finish 2019-05-15 → none |
| 54 | Finalize training materials | 2019-05-16 → 2019-05-14 (-2d) | 2019-05-20 → 2019-05-16 (-4d) |  |  |  | baseline start 2019-05-16 → none; baseline finish 2019-05-20 → none |
| 55 | Develop training delivery mechanism | 2019-05-21 → 2019-05-17 (-4d) | 2019-05-22 → 2019-05-20 (-2d) |  |  |  | baseline start 2019-05-21 → none; baseline finish 2019-05-22 → none |
| 56 | Training materials complete | 2019-05-22 → 2019-05-20 (-2d) | 2019-05-22 → 2019-05-20 (-2d) |  |  |  | baseline start 2019-05-22 → none; baseline finish 2019-05-22 → none |
| 57 | **Documentation** | 2019-02-27 → 2019-02-25 (-2d) | 2019-04-30 → 2019-04-25 (-5d) | 45d → 44d |  | 14d → 15d |  |
| 58 | Develop Help specification | 2019-02-27 → 2019-02-25 (-2d) | 2019-02-27 → 2019-02-25 (-2d) |  |  | 19d → 21d | baseline start 2019-02-27 → none; baseline finish 2019-02-27 → none |
| 59 | Develop Help system | 2019-03-07 → 2019-03-05 (-2d) | 2019-03-28 → 2019-03-26 (-2d) |  |  | 13.5d → 15.5d | baseline start 2019-03-07 → none; baseline finish 2019-03-28 → none |
| 60 | Review Help documentation | 2019-04-18 → 2019-04-16 (-2d) | 2019-04-23 → 2019-04-19 (-4d) |  |  | 13.5d → 15.5d | baseline start 2019-04-18 → none; baseline finish 2019-04-23 → none |
| 61 | Incorporate Help documentation feedback | 2019-04-29 → 2019-04-23 (-6d) | 2019-04-30 → 2019-04-25 (-5d) |  |  | 14d → 15.5d | baseline start 2019-04-29 → none; baseline finish 2019-04-30 → none |
| 62 | Develop user manuals specifications | 2019-02-28 → 2019-02-26 (-2d) | 2019-03-01 → 2019-02-27 (-2d) |  |  |  | baseline start 2019-02-28 → none; baseline finish 2019-03-01 → none |
| 63 | Develop user manuals | 2019-03-28 → 2019-03-26 (-2d) | 2019-04-18 → 2019-04-16 (-2d) |  |  |  | baseline start 2019-03-28 → none; baseline finish 2019-04-18 → none |
| 64 | Review all user documentation | 2019-04-23 → 2019-04-22 (-1d) | 2019-04-25 → 2019-04-23 (-2d) |  |  | 15.5d → 15d | baseline start 2019-04-23 → none; baseline finish 2019-04-25 → none |
| 65 | Incorporate user documentation feedback | 2019-04-25 → 2019-04-24 (-1d) | 2019-04-29 → 2019-04-25 (-4d) |  |  | 15.5d → 15d | baseline start 2019-04-25 → none; baseline finish 2019-04-29 → none |
| 66 | Documentation complete | 2019-04-30 → 2019-04-25 (-5d) | 2019-04-30 → 2019-04-25 (-5d) |  |  | 14d → 15d | baseline start 2019-04-30 → none; baseline finish 2019-04-30 → none |
| 67 | **Pilot** | 2019-05-01 → 2019-04-26 (-5d) | 2019-05-31 → 2019-05-29 (-2d) | 23d → 24d |  |  |  |
| 68 | Identify test group | 2019-05-01 → 2019-04-26 (-5d) | 2019-05-01 → 2019-04-26 (-5d) |  |  | 14d → 15d | baseline start 2019-05-01 → none; baseline finish 2019-05-01 → none |
| 69 | Develop software delivery mechanism | 2019-05-02 → 2019-04-29 (-3d) | 2019-05-02 → 2019-04-29 (-3d) |  |  | 14d → 15d | baseline start 2019-05-02 → none; baseline finish 2019-05-02 → none |
| 70 | Install/deploy software | 2019-05-23 → 2019-05-21 (-2d) | 2019-05-23 → 2019-05-21 (-2d) |  |  |  | baseline start 2019-05-23 → none; baseline finish 2019-05-23 → none |

| ID | Task | Start | Finish | Other |
| --- | --- | --- | --- | --- |
| 71 | Obtain user feedback | 2019-05-24 → 2019-05-22 (-2d) | 2019-05-30 → 2019-05-28 (-2d) | baseline start 2019-05-24 → none; baseline finish 2019-05-30 → none |
| 72 | Evaluate testing information | 2019-05-31 → 2019-05-29 (-2d) | 2019-05-31 → 2019-05-29 (-2d) | baseline start 2019-05-31 → none; baseline finish 2019-05-31 → none |
| 73 | Pilot complete | 2019-05-31 → 2019-05-29 (-2d) | 2019-05-31 → 2019-05-29 (-2d) | baseline start 2019-05-31 → none; baseline finish 2019-05-31 → none |
| 74 | **Deployment** | 2019-06-03 → 2019-05-30 (-4d) | 2019-06-07 → 2019-06-05 (-2d) |  |
| 75 | Determine final deployment strategy | 2019-06-03 → 2019-05-30 (-4d) | 2019-06-03 → 2019-05-30 (-4d) | baseline start 2019-06-03 → none; baseline finish 2019-06-03 → none |
| 76 | Develop deployment methodology | 2019-06-04 → 2019-05-31 (-4d) | 2019-06-04 → 2019-05-31 (-4d) | baseline start 2019-06-04 → none; baseline finish 2019-06-04 → none |
| 77 | Secure deployment resources | 2019-06-05 → 2019-06-03 (-2d) | 2019-06-05 → 2019-06-03 (-2d) | baseline start 2019-06-05 → none; baseline finish 2019-06-05 → none |
| 78 | Train support staff | 2019-06-06 → 2019-06-04 (-2d) | 2019-06-06 → 2019-06-04 (-2d) | baseline start 2019-06-06 → none; baseline finish 2019-06-06 → none |
| 79 | Deploy software | 2019-06-07 → 2019-06-05 (-2d) | 2019-06-07 → 2019-06-05 (-2d) | baseline start 2019-06-07 → none; baseline finish 2019-06-07 → none |
| 80 | Deployment complete | 2019-06-07 → 2019-06-05 (-2d) | 2019-06-07 → 2019-06-05 (-2d) | baseline start 2019-06-07 → none; baseline finish 2019-06-07 → none |
| 81 | **Post Implementation Review** | 2019-06-10 → 2019-06-06 (-4d) | 2019-06-12 → 2019-06-10 (-2d) |  |
| 82 | Document lessons learned | 2019-06-10 → 2019-06-06 (-4d) | 2019-06-10 → 2019-06-06 (-4d) | baseline start 2019-06-10 → none; baseline finish 2019-06-10 → none |
| 83 | Distribute to team members | 2019-06-11 → 2019-06-07 (-4d) | 2019-06-11 → 2019-06-07 (-4d) | baseline start 2019-06-11 → none; baseline finish 2019-06-11 → none |
| 84 | Create software maintenance team | 2019-06-12 → 2019-06-10 (-2d) | 2019-06-12 → 2019-06-10 (-2d) | baseline start 2019-06-12 → none; baseline finish 2019-06-12 → none |
| 85 | Post implementation review complete | 2019-06-12 → 2019-06-10 (-2d) | 2019-06-12 → 2019-06-10 (-2d) | baseline start 2019-06-12 → none; baseline finish 2019-06-12 → none |
| 86 | Software development complete | 2019-06-12 → 2019-06-10 (-2d) | 2019-06-12 → 2019-06-10 (-2d) | baseline start 2019-06-12 → none; baseline finish 2019-06-12 → none |

## Version 8 (saved 2019-03-14, file EVM.mpp)

Last finish 2019-06-10 → 2019-06-12 (+2d). Complete tasks 0 → 14.

Changed:

| ID | Task | Start | Finish | Duration | Complete | Total float | Other |
| --- | --- | --- | --- | --- | --- | --- | --- |
| 1 | **Scope** | 2019-01-07 A | 2019-01-11 A |  | 0% → 100% | 0d → none | baseline start none → 2019-01-07; baseline finish none → 2019-01-14 |
| 2 | Determine project scope | 2019-01-07 A | 2019-01-07 A |  | 0% → 100% | 0d → none | baseline start none → 2019-01-07; baseline finish none → 2019-01-07 |
| 3 | Secure project sponsorship | 2019-01-08 A | 2019-01-09 A |  | 0% → 100% | 0d → none | baseline start none → 2019-01-08; baseline finish none → 2019-01-10 |
| 4 | Define preliminary resources | 2019-01-10 A | 2019-01-10 A |  | 0% → 100% | 0d → none | baseline start none → 2019-01-11; baseline finish none → 2019-01-11 |
| 5 | Secure core resources | 2019-01-11 A | 2019-01-11 A |  | 0% → 100% | 0d → none | baseline start none → 2019-01-14; baseline finish none → 2019-01-14 |
| 6 | Scope complete | 2019-01-11 A | 2019-01-11 A |  | 0% → 100% | 0d → none | baseline start none → 2019-01-14; baseline finish none → 2019-01-14 |
| 7 | **Analysis/Software Requirements** | 2019-01-14 → 2019-01-15 A (+1d) | 2019-01-28 → 2019-01-30 A (+2d) | 11d → 12d | 0% → 100% | 0d → none | baseline start none → 2019-01-15; baseline finish none → 2019-01-30 |
| 8 | Conduct needs analysis | 2019-01-14 → 2019-01-15 A (+1d) | 2019-01-15 → 2019-01-16 A (+1d) |  | 0% → 100% | 0d → none | baseline start none → 2019-01-15; baseline finish none → 2019-01-16 |
| 9 | Draft preliminary software specifications | 2019-01-16 → 2019-01-17 A (+1d) | 2019-01-17 → 2019-01-18 A (+1d) |  | 0% → 100% | 0d → none | baseline start none → 2019-01-17; baseline finish none → 2019-01-18 |
| 10 | Develop preliminary budget | 2019-01-18 → 2019-01-22 A (+4d) | 2019-01-22 → 2019-01-24 A (+2d) |  | 0% → 100% | 0d → none | baseline start none → 2019-01-21; baseline finish none → 2019-01-22 |
| 11 | Review software specifications/budget with team | 2019-01-18 → 2019-01-22 A (+4d) | 2019-01-18 → 2019-01-22 A (+4d) |  | 0% → 100% | 0d → none | baseline start none → 2019-01-21; baseline finish none → 2019-01-21 |
| 12 | Incorporate feedback on software specifications | 2019-01-21 → 2019-01-23 A (+2d) | 2019-01-23 → 2019-01-25 A (+2d) |  | 0% → 100% | 0d → none | baseline start none → 2019-01-22; baseline finish none → 2019-01-24 |
| 13 | Develop delivery timeline | 2019-01-24 → 2019-01-28 A (+4d) | 2019-01-24 → 2019-01-28 A (+4d) |  | 0% → 100% | 0d → none | baseline start none → 2019-01-25; baseline finish none → 2019-01-28 |
| 14 | Obtain approvals to proceed (concept, timeline, budget) | 2019-01-25 → 2019-01-29 A (+4d) | 2019-01-25 → 2019-01-29 A (+4d) |  | 0% → 100% | 0d → none | baseline start none → 2019-01-29; baseline finish none → 2019-01-29 |
| 15 | Secure required resources | 2019-01-28 → 2019-01-30 A (+2d) | 2019-01-28 → 2019-01-30 A (+2d) |  | 0% → 100% | 0d → none | baseline start none → 2019-01-30; baseline finish none → 2019-01-30 |
| 16 | Analysis complete | 2019-01-28 → 2019-01-30 A (+2d) | 2019-01-28 → 2019-01-30 A (+2d) |  | 0% → 100% | 0d → none | baseline start none → 2019-01-30; baseline finish none → 2019-01-30 |
| 17 | **Design** | 2019-01-29 → 2019-01-31 (+2d) | 2019-02-18 → 2019-02-20 (+2d) |  |  |  | baseline start none → 2019-01-31; baseline finish none → 2019-02-20 |
| 18 | Review preliminary software specifications | 2019-01-29 → 2019-01-31 (+2d) | 2019-01-30 → 2019-02-01 (+2d) |  |  |  | baseline start none → 2019-01-31; baseline finish none → 2019-02-01 |
| 19 | Develop functional specifications | 2019-01-31 → 2019-02-04 (+4d) | 2019-02-06 → 2019-02-08 (+2d) |  |  |  | baseline start none → 2019-02-04; baseline finish none → 2019-02-08 |
| 20 | Develop prototype based on functional specifications | 2019-02-07 → 2019-02-11 (+4d) | 2019-02-12 → 2019-02-14 (+2d) |  |  |  | baseline start none → 2019-02-11; baseline finish none → 2019-02-14 |
| 21 | Review functional specifications | 2019-02-13 → 2019-02-15 (+2d) | 2019-02-14 → 2019-02-18 (+4d) |  |  |  | baseline start none → 2019-02-15; baseline finish none → 2019-02-18 |
| 22 | Incorporate feedback into functional specifications | 2019-02-15 → 2019-02-19 (+4d) | 2019-02-15 → 2019-02-19 (+4d) |  |  |  | baseline start none → 2019-02-19; baseline finish none → 2019-02-19 |
| 23 | Obtain approval to proceed | 2019-02-18 → 2019-02-20 (+2d) | 2019-02-18 → 2019-02-20 (+2d) |  |  |  | baseline start none → 2019-02-20; baseline finish none → 2019-02-20 |
| 24 | Design complete | 2019-02-18 → 2019-02-20 (+2d) | 2019-02-18 → 2019-02-20 (+2d) |  |  |  | baseline start none → 2019-02-20; baseline finish none → 2019-02-20 |
| 25 | **Development** | 2019-02-19 → 2019-02-21 (+2d) | 2019-04-05 → 2019-04-08 (+3d) | 34d → 33d |  | 3d → 5d |  |
| 26 | Review functional specifications | 2019-02-19 → 2019-02-21 (+2d) | 2019-02-19 → 2019-02-21 (+2d) |  |  | 3d → 5d | baseline start none → 2019-02-21; baseline finish none → 2019-02-21 |
| 27 | Identify modular/tiered design parameters | 2019-02-20 → 2019-02-22 (+2d) | 2019-02-20 → 2019-02-22 (+2d) |  |  | 3d → 5d | baseline start none → 2019-02-22; baseline finish none → 2019-02-22 |
| 28 | Assign development staff | 2019-02-21 → 2019-02-25 (+4d) | 2019-02-21 → 2019-02-25 (+4d) |  |  | 3d → 5d | baseline start none → 2019-02-25; baseline finish none → 2019-02-25 |
| 29 | Develop code | 2019-02-22 → 2019-02-26 (+4d) | 2019-03-14 → 2019-03-18 (+4d) |  |  | 3d → 5d | baseline start none → 2019-02-26; baseline finish none → 2019-03-18 |
| 30 | Developer testing (primary debugging) | 2019-03-18 → 2019-03-19 (+1d) | 2019-04-05 → 2019-04-08 (+3d) |  |  | 4d → 5d | baseline start none → 2019-03-19; baseline finish none → 2019-04-08 |
| 31 | Development complete | 2019-04-05 → 2019-04-08 (+3d) | 2019-04-05 → 2019-04-08 (+3d) |  |  | 4d → 5d | baseline start none → 2019-04-08; baseline finish none → 2019-04-08 |
| 32 | **Testing** | 2019-02-19 → 2019-02-21 (+2d) | 2019-05-14 → 2019-05-15 (+1d) | 61d → 60d |  | 19d → 20d |  |
| 33 | Develop unit test plans using product specifications | 2019-02-19 → 2019-02-21 (+2d) | 2019-02-22 → 2019-02-26 (+4d) |  |  |  | baseline start none → 2019-02-21; baseline finish none → 2019-02-26 |
| 34 | Develop integration test plans using product specifications | 2019-02-28 → 2019-03-04 (+4d) | 2019-04-29 → 2019-05-01 (+2d) |  |  |  | baseline start none → 2019-03-04; baseline finish none → 2019-05-01 |
| 35 | **Unit Testing** | 2019-04-08 → 2019-04-09 (+1d) | 2019-04-26 → 2019-04-29 (+3d) |  |  | 4d → 5d |  |
| 36 | Review modular code | 2019-04-08 → 2019-04-09 (+1d) | 2019-04-12 → 2019-04-15 (+3d) |  |  | 4d → 5d | baseline start none → 2019-04-09; baseline finish none → 2019-04-15 |
| 37 | Test component modules to product specifications | 2019-04-15 → 2019-04-16 (+1d) | 2019-04-16 → 2019-04-17 (+1d) |  |  | 4d → 5d | baseline start none → 2019-04-16; baseline finish none → 2019-04-17 |
| 38 | Identify anomalies to product specifications | 2019-04-17 → 2019-04-18 (+1d) | 2019-04-19 → 2019-04-22 (+3d) |  |  | 4d → 5d | baseline start none → 2019-04-18; baseline finish none → 2019-04-22 |
| 39 | Modify code | 2019-04-22 → 2019-04-23 (+1d) | 2019-04-24 → 2019-04-25 (+1d) |  |  | 4d → 5d | baseline start none → 2019-04-23; baseline finish none → 2019-04-25 |
| 40 | Re-test modified code | 2019-04-25 → 2019-04-26 (+1d) | 2019-04-26 → 2019-04-29 (+3d) |  |  | 4d → 5d | baseline start none → 2019-04-26; baseline finish none → 2019-04-29 |
| 41 | Unit testing complete | 2019-04-26 → 2019-04-29 (+3d) | 2019-04-26 → 2019-04-29 (+3d) |  |  | 4d → 5d | baseline start none → 2019-04-29; baseline finish none → 2019-04-29 |
| 42 | **Integration Testing** | 2019-04-29 → 2019-04-30 (+1d) | 2019-05-14 → 2019-05-15 (+1d) |  |  | 4d → 5d |  |
| 43 | Test module integration | 2019-04-29 → 2019-04-30 (+1d) | 2019-05-03 → 2019-05-06 (+3d) |  |  | 4d → 5d | baseline start none → 2019-04-30; baseline finish none → 2019-05-06 |
| 44 | Identify anomalies to specifications | 2019-05-06 → 2019-05-07 (+1d) | 2019-05-07 → 2019-05-08 (+1d) |  |  | 4d → 5d | baseline start none → 2019-05-07; baseline finish none → 2019-05-08 |
| 45 | Modify code | 2019-05-08 → 2019-05-09 (+1d) | 2019-05-10 → 2019-05-13 (+3d) |  |  | 4d → 5d | baseline start none → 2019-05-09; baseline finish none → 2019-05-13 |
| 46 | Re-test modified code | 2019-05-13 → 2019-05-14 (+1d) | 2019-05-14 → 2019-05-15 (+1d) |  |  | 4d → 5d | baseline start none → 2019-05-14; baseline finish none → 2019-05-15 |
| 47 | Integration testing complete | 2019-05-14 → 2019-05-15 (+1d) | 2019-05-14 → 2019-05-15 (+1d) |  |  | 4d → 5d | baseline start none → 2019-05-15; baseline finish none → 2019-05-15 |
| 48 | **Training** | 2019-04-08 → 2019-04-09 (+1d) | 2019-05-20 → 2019-05-22 (+2d) | 31d → 32d |  |  |  |
| 49 | Develop training specifications for end users | 2019-04-08 → 2019-04-09 (+1d) | 2019-04-10 → 2019-04-11 (+1d) |  |  | 4d → 5d | baseline start none → 2019-04-09; baseline finish none → 2019-04-11 |
| 50 | Develop training specifications for helpdesk support staff | 2019-04-10 → 2019-04-12 (+2d) | 2019-04-12 → 2019-04-16 (+4d) |  |  |  | baseline start none → 2019-04-12; baseline finish none → 2019-04-16 |
| 51 | Identify training delivery methodology (computer based training, classroom, etc.) | 2019-04-15 → 2019-04-17 (+2d) | 2019-04-16 → 2019-04-18 (+2d) |  |  |  | baseline start none → 2019-04-17; baseline finish none → 2019-04-18 |
| 52 | Develop training materials | 2019-04-17 → 2019-04-19 (+2d) | 2019-05-07 → 2019-05-09 (+2d) |  |  |  | baseline start none → 2019-04-19; baseline finish none → 2019-05-09 |
| 53 | Conduct training usability study | 2019-05-08 → 2019-05-10 (+2d) | 2019-05-13 → 2019-05-15 (+2d) |  |  |  | baseline start none → 2019-05-10; baseline finish none → 2019-05-15 |
| 54 | Finalize training materials | 2019-05-14 → 2019-05-16 (+2d) | 2019-05-16 → 2019-05-20 (+4d) |  |  |  | baseline start none → 2019-05-16; baseline finish none → 2019-05-20 |
| 55 | Develop training delivery mechanism | 2019-05-17 → 2019-05-21 (+4d) | 2019-05-20 → 2019-05-22 (+2d) |  |  |  | baseline start none → 2019-05-21; baseline finish none → 2019-05-22 |
| 56 | Training materials complete | 2019-05-20 → 2019-05-22 (+2d) | 2019-05-20 → 2019-05-22 (+2d) |  |  |  | baseline start none → 2019-05-22; baseline finish none → 2019-05-22 |
| 57 | **Documentation** | 2019-02-25 → 2019-02-27 (+2d) | 2019-04-25 → 2019-04-30 (+5d) | 44d → 45d |  | 15d → 14d |  |
| 58 | Develop Help specification | 2019-02-25 → 2019-02-27 (+2d) | 2019-02-25 → 2019-02-27 (+2d) |  |  | 21d → 19d | baseline start none → 2019-02-27; baseline finish none → 2019-02-27 |
| 59 | Develop Help system | 2019-03-05 → 2019-03-07 (+2d) | 2019-03-26 → 2019-03-28 (+2d) |  |  | 15.5d → 13.5d | baseline start none → 2019-03-07; baseline finish none → 2019-03-28 |
| 60 | Review Help documentation | 2019-04-16 → 2019-04-18 (+2d) | 2019-04-19 → 2019-04-23 (+4d) |  |  | 15.5d → 13.5d | baseline start none → 2019-04-18; baseline finish none → 2019-04-23 |
| 61 | Incorporate Help documentation feedback | 2019-04-23 → 2019-04-29 (+6d) | 2019-04-25 → 2019-04-30 (+5d) |  |  | 15.5d → 14d | baseline start none → 2019-04-29; baseline finish none → 2019-04-30 |
| 62 | Develop user manuals specifications | 2019-02-26 → 2019-02-28 (+2d) | 2019-02-27 → 2019-03-01 (+2d) |  |  |  | baseline start none → 2019-02-28; baseline finish none → 2019-03-01 |
| 63 | Develop user manuals | 2019-03-26 → 2019-03-28 (+2d) | 2019-04-16 → 2019-04-18 (+2d) |  |  |  | baseline start none → 2019-03-28; baseline finish none → 2019-04-18 |
| 64 | Review all user documentation | 2019-04-22 → 2019-04-23 (+1d) | 2019-04-23 → 2019-04-25 (+2d) |  |  | 15d → 15.5d | baseline start none → 2019-04-23; baseline finish none → 2019-04-25 |
| 65 | Incorporate user documentation feedback | 2019-04-24 → 2019-04-25 (+1d) | 2019-04-25 → 2019-04-29 (+4d) |  |  | 15d → 15.5d | baseline start none → 2019-04-25; baseline finish none → 2019-04-29 |
| 66 | Documentation complete | 2019-04-25 → 2019-04-30 (+5d) | 2019-04-25 → 2019-04-30 (+5d) |  |  | 15d → 14d | baseline start none → 2019-04-30; baseline finish none → 2019-04-30 |
| 67 | **Pilot** | 2019-04-26 → 2019-05-01 (+5d) | 2019-05-29 → 2019-05-31 (+2d) | 24d → 23d |  |  |  |
| 68 | Identify test group | 2019-04-26 → 2019-05-01 (+5d) | 2019-04-26 → 2019-05-01 (+5d) |  |  | 15d → 14d | baseline start none → 2019-05-01; baseline finish none → 2019-05-01 |
| 69 | Develop software delivery mechanism | 2019-04-29 → 2019-05-02 (+3d) | 2019-04-29 → 2019-05-02 (+3d) |  |  | 15d → 14d | baseline start none → 2019-05-02; baseline finish none → 2019-05-02 |
| 70 | Install/deploy software | 2019-05-21 → 2019-05-23 (+2d) | 2019-05-21 → 2019-05-23 (+2d) |  |  |  | baseline start none → 2019-05-23; baseline finish none → 2019-05-23 |

| ID | Task | Start | Finish | Other |
| --- | --- | --- | --- | --- |
| 71 | Obtain user feedback | 2019-05-22 → 2019-05-24 (+2d) | 2019-05-28 → 2019-05-30 (+2d) | baseline start none → 2019-05-24; baseline finish none → 2019-05-30 |
| 72 | Evaluate testing information | 2019-05-29 → 2019-05-31 (+2d) | 2019-05-29 → 2019-05-31 (+2d) | baseline start none → 2019-05-31; baseline finish none → 2019-05-31 |
| 73 | Pilot complete | 2019-05-29 → 2019-05-31 (+2d) | 2019-05-29 → 2019-05-31 (+2d) | baseline start none → 2019-05-31; baseline finish none → 2019-05-31 |
| 74 | **Deployment** | 2019-05-30 → 2019-06-03 (+4d) | 2019-06-05 → 2019-06-07 (+2d) |  |
| 75 | Determine final deployment strategy | 2019-05-30 → 2019-06-03 (+4d) | 2019-05-30 → 2019-06-03 (+4d) | baseline start none → 2019-06-03; baseline finish none → 2019-06-03 |
| 76 | Develop deployment methodology | 2019-05-31 → 2019-06-04 (+4d) | 2019-05-31 → 2019-06-04 (+4d) | baseline start none → 2019-06-04; baseline finish none → 2019-06-04 |
| 77 | Secure deployment resources | 2019-06-03 → 2019-06-05 (+2d) | 2019-06-03 → 2019-06-05 (+2d) | baseline start none → 2019-06-05; baseline finish none → 2019-06-05 |
| 78 | Train support staff | 2019-06-04 → 2019-06-06 (+2d) | 2019-06-04 → 2019-06-06 (+2d) | baseline start none → 2019-06-06; baseline finish none → 2019-06-06 |
| 79 | Deploy software | 2019-06-05 → 2019-06-07 (+2d) | 2019-06-05 → 2019-06-07 (+2d) | baseline start none → 2019-06-07; baseline finish none → 2019-06-07 |
| 80 | Deployment complete | 2019-06-05 → 2019-06-07 (+2d) | 2019-06-05 → 2019-06-07 (+2d) | baseline start none → 2019-06-07; baseline finish none → 2019-06-07 |
| 81 | **Post Implementation Review** | 2019-06-06 → 2019-06-10 (+4d) | 2019-06-10 → 2019-06-12 (+2d) |  |
| 82 | Document lessons learned | 2019-06-06 → 2019-06-10 (+4d) | 2019-06-06 → 2019-06-10 (+4d) | baseline start none → 2019-06-10; baseline finish none → 2019-06-10 |
| 83 | Distribute to team members | 2019-06-07 → 2019-06-11 (+4d) | 2019-06-07 → 2019-06-11 (+4d) | baseline start none → 2019-06-11; baseline finish none → 2019-06-11 |
| 84 | Create software maintenance team | 2019-06-10 → 2019-06-12 (+2d) | 2019-06-10 → 2019-06-12 (+2d) | baseline start none → 2019-06-12; baseline finish none → 2019-06-12 |
| 85 | Post implementation review complete | 2019-06-10 → 2019-06-12 (+2d) | 2019-06-10 → 2019-06-12 (+2d) | baseline start none → 2019-06-12; baseline finish none → 2019-06-12 |
| 86 | Software development complete | 2019-06-10 → 2019-06-12 (+2d) | 2019-06-10 → 2019-06-12 (+2d) | baseline start none → 2019-06-12; baseline finish none → 2019-06-12 |

## Version 9 (saved 2019-03-14, file Macros.mpp)

Last finish 2019-06-12 → 2018-10-03 (-252d). Complete tasks 14 → 0.

Changed:

| ID | Task | Start | Finish | Duration | Complete | Total float | Predecessors | Other |
| --- | --- | --- | --- | --- | --- | --- | --- | --- |
| 1 | **Scope** | 2019-01-07 A → 2018-05-01 (-251d) | 2019-01-11 A → 2018-05-09 (-247d) | 5d → 7d | 100% → 0% | none → 0d |  | baseline start 2019-01-07 → 2018-05-01; baseline finish 2019-01-14 → 2018-05-04 |
| 2 | Determine project scope | 2019-01-07 A → 2018-05-01 (-251d) | 2019-01-07 A → 2018-05-02 (-250d) | 1d → 2d | 100% → 0% | none → 0d |  | baseline start 2019-01-07 → 2018-05-01; baseline finish 2019-01-07 → 2018-05-01 |
| 3 | Secure project sponsorship | 2019-01-08 A → 2018-05-03 (-250d) | 2019-01-09 A → 2018-05-03 (-251d) | 2d → 1d | 100% → 0% | none → 0d |  | baseline start 2019-01-08 → 2018-05-02; baseline finish 2019-01-10 → 2018-05-02 |
| 4 | Define preliminary resources | 2019-01-10 A → 2018-05-04 (-251d) | 2019-01-10 A → 2018-05-08 (-247d) | 1d → 3d | 100% → 0% | none → 0d |  | resources Steve Masters → Project Manager; baseline start 2019-01-11 → 2018-05-03; baseline finish 2019-01-11 → 2018-05-03 |
| 5 | Secure core resources | 2019-01-11 A → 2018-05-09 (-247d) | 2019-01-11 A → 2018-05-09 (-247d) |  | 100% → 0% | none → 0d |  | resources Steve Masters → Project Manager; baseline start 2019-01-14 → 2018-05-04; baseline finish 2019-01-14 → 2018-05-04 |
| 6 | Scope complete | 2019-01-11 A → 2018-05-09 (-247d) | 2019-01-11 A → 2018-05-09 (-247d) |  | 100% → 0% | none → 0d |  | baseline start 2019-01-14 → 2018-05-04; baseline finish 2019-01-14 → 2018-05-04 |
| 7 | **Analysis/Software Requirements** | 2019-01-15 A → 2018-05-10 (-250d) | 2019-01-30 A → 2018-05-23 (-252d) | 12d → 10d | 100% → 0% | none → 0d |  | baseline start 2019-01-15 → 2018-05-07; baseline finish 2019-01-30 → 2018-05-23 |
| 8 | Conduct needs analysis | 2019-01-15 A → 2018-05-10 (-250d) | 2019-01-16 A → 2018-05-10 (-251d) | 2d → 1d | 100% → 0% | none → 0d |  | baseline start 2019-01-15 → 2018-05-07; baseline finish 2019-01-16 → 2018-05-09 |
| 9 | Draft preliminary software specifications | 2019-01-17 A → 2018-05-11 (-251d) | 2019-01-18 A → 2018-05-16 (-247d) | 2d → 4d | 100% → 0% | none → 0d |  | baseline start 2019-01-17 → 2018-05-10; baseline finish 2019-01-18 → 2018-05-15 |
| 10 | Develop preliminary budget | 2019-01-22 A → 2018-05-17 (-250d) | 2019-01-24 A → 2018-05-18 (-251d) | 3d → 2d | 100% → 0% | none → 0d |  | baseline start 2019-01-21 → 2018-05-16; baseline finish 2019-01-22 → 2018-05-17 |
| 11 | Review software specifications/budget with team | 2019-01-22 A → 2018-05-17 (-250d) | 2019-01-22 A → 2018-05-17 (-250d) |  | 100% → 0% | none → 0d |  | baseline start 2019-01-21 → 2018-05-16; baseline finish 2019-01-21 → 2018-05-16 |
| 12 | Incorporate feedback on software specifications | 2019-01-23 A → 2018-05-18 (-250d) | 2019-01-25 A → 2018-05-18 (-252d) | 3d → 1d | 100% → 0% | none → 0d |  | baseline start 2019-01-22 → 2018-05-18; baseline finish 2019-01-24 → 2018-05-18 |
| 13 | Develop delivery timeline | 2019-01-28 A → 2018-05-21 (-252d) | 2019-01-28 A → 2018-05-21 (-252d) |  | 100% → 0% | none → 0d |  | baseline start 2019-01-25 → 2018-05-21; baseline finish 2019-01-28 → 2018-05-21 |
| 14 | Obtain approvals to proceed (concept, timeline, budget) | 2019-01-29 A → 2018-05-22 (-252d) | 2019-01-29 A → 2018-05-22 (-252d) |  | 100% → 0% | none → 0d |  | baseline start 2019-01-29 → 2018-05-22; baseline finish 2019-01-29 → 2018-05-22 |
| 15 | Secure required resources | 2019-01-30 A → 2018-05-23 (-252d) | 2019-01-30 A → 2018-05-23 (-252d) |  | 100% → 0% | none → 0d |  | baseline start 2019-01-30 → 2018-05-23; baseline finish 2019-01-30 → 2018-05-23 |
| 16 | Analysis complete | 2019-01-30 A → 2018-05-23 (-252d) | 2019-01-30 A → 2018-05-23 (-252d) |  | 100% → 0% | none → 0d |  | baseline start 2019-01-30 → 2018-05-23; baseline finish 2019-01-30 → 2018-05-23 |
| 17 | **Design** | 2019-01-31 → 2018-05-24 (-252d) | 2019-02-20 → 2018-06-13 (-252d) |  |  |  |  | baseline start 2019-01-31 → 2018-05-24; baseline finish 2019-02-20 → 2018-06-13 |
| 18 | Review preliminary software specifications | 2019-01-31 → 2018-05-24 (-252d) | 2019-02-01 → 2018-05-25 (-252d) |  |  |  |  | baseline start 2019-01-31 → 2018-05-24; baseline finish 2019-02-01 → 2018-05-25 |
| 19 | Develop functional specifications | 2019-02-04 → 2018-05-28 (-252d) | 2019-02-08 → 2018-06-01 (-252d) |  |  |  |  | baseline start 2019-02-04 → 2018-05-28; baseline finish 2019-02-08 → 2018-06-01 |
| 20 | Develop prototype based on functional specifications | 2019-02-11 → 2018-06-04 (-252d) | 2019-02-14 → 2018-06-07 (-252d) |  |  |  |  | baseline start 2019-02-11 → 2018-06-04; baseline finish 2019-02-14 → 2018-06-07 |
| 21 | Review functional specifications | 2019-02-15 → 2018-06-08 (-252d) | 2019-02-18 → 2018-06-11 (-252d) |  |  |  |  | baseline start 2019-02-15 → 2018-06-08; baseline finish 2019-02-18 → 2018-06-11 |
| 22 | Incorporate feedback into functional specifications | 2019-02-19 → 2018-06-12 (-252d) | 2019-02-19 → 2018-06-12 (-252d) |  |  |  |  | baseline start 2019-02-19 → 2018-06-12; baseline finish 2019-02-19 → 2018-06-12 |
| 23 | Obtain approval to proceed | 2019-02-20 → 2018-06-13 (-252d) | 2019-02-20 → 2018-06-13 (-252d) |  |  |  |  | baseline start 2019-02-20 → 2018-06-13; baseline finish 2019-02-20 → 2018-06-13 |
| 24 | Design complete | 2019-02-20 → 2018-06-13 (-252d) | 2019-02-20 → 2018-06-13 (-252d) |  |  |  |  | baseline start 2019-02-20 → 2018-06-13; baseline finish 2019-02-20 → 2018-06-13 |
| 25 | **Development** | 2019-02-21 → 2018-06-14 (-252d) | 2019-04-08 → 2018-07-30 (-252d) |  |  |  |  | baseline start 2019-02-21 → 2018-06-14; baseline finish 2019-04-08 → 2018-07-30 |
| 26 | Review functional specifications | 2019-02-21 → 2018-06-14 (-252d) | 2019-02-21 → 2018-06-14 (-252d) |  |  |  |  | baseline start 2019-02-21 → 2018-06-14; baseline finish 2019-02-21 → 2018-06-14 |
| 27 | Identify modular/tiered design parameters | 2019-02-22 → 2018-06-15 (-252d) | 2019-02-22 → 2018-06-15 (-252d) |  |  |  |  | baseline start 2019-02-22 → 2018-06-15; baseline finish 2019-02-22 → 2018-06-15 |
| 28 | Assign development staff | 2019-02-25 → 2018-06-18 (-252d) | 2019-02-25 → 2018-06-18 (-252d) |  |  |  |  | baseline start 2019-02-25 → 2018-06-18; baseline finish 2019-02-25 → 2018-06-18 |
| 29 | Develop code | 2019-02-26 → 2018-06-19 (-252d) | 2019-03-18 → 2018-07-09 (-252d) |  |  |  |  | baseline start 2019-02-26 → 2018-06-19; baseline finish 2019-03-18 → 2018-07-09 |
| 30 | Developer testing (primary debugging) | 2019-03-19 → 2018-07-10 (-252d) | 2019-04-08 → 2018-07-30 (-252d) |  |  |  |  | baseline start 2019-03-19 → 2018-07-10; baseline finish 2019-04-08 → 2018-07-30 |
| 31 | Development complete | 2019-04-08 → 2018-07-30 (-252d) | 2019-04-08 → 2018-07-30 (-252d) |  |  |  |  | baseline start 2019-04-08 → 2018-07-30; baseline finish 2019-04-08 → 2018-07-30 |
| 32 | **Testing** | 2019-02-21 → 2018-06-14 (-252d) | 2019-05-15 → 2018-09-05 (-252d) |  |  |  |  | baseline start 2019-02-21 → 2018-06-14; baseline finish 2019-05-15 → 2018-09-05 |
| 33 | Develop unit test plans using product specifications | 2019-02-21 → 2018-06-14 (-252d) | 2019-02-26 → 2018-06-19 (-252d) |  |  |  |  | baseline start 2019-02-21 → 2018-06-14; baseline finish 2019-02-26 → 2018-06-19 |
| 34 | Develop integration test plans using product specifications | 2019-03-04 → 2018-06-25 (-252d) | 2019-05-01 → 2018-08-22 (-252d) |  |  |  |  | baseline start 2019-03-04 → 2018-06-25; baseline finish 2019-05-01 → 2018-08-22 |
| 35 | **Unit Testing** | 2019-04-09 → 2018-07-31 (-252d) | 2019-04-29 → 2018-08-20 (-252d) |  |  |  |  | baseline start 2019-04-09 → 2018-07-31; baseline finish 2019-04-29 → 2018-08-20 |
| 36 | Review modular code | 2019-04-09 → 2018-07-31 (-252d) | 2019-04-15 → 2018-08-06 (-252d) |  |  |  |  | baseline start 2019-04-09 → 2018-07-31; baseline finish 2019-04-15 → 2018-08-06 |
| 37 | Test component modules to product specifications | 2019-04-16 → 2018-08-07 (-252d) | 2019-04-17 → 2018-08-08 (-252d) |  |  |  |  | baseline start 2019-04-16 → 2018-08-07; baseline finish 2019-04-17 → 2018-08-08 |
| 38 | Identify anomalies to product specifications | 2019-04-18 → 2018-08-09 (-252d) | 2019-04-22 → 2018-08-13 (-252d) |  |  |  |  | baseline start 2019-04-18 → 2018-08-09; baseline finish 2019-04-22 → 2018-08-13 |
| 39 | Modify code | 2019-04-23 → 2018-08-14 (-252d) | 2019-04-25 → 2018-08-16 (-252d) |  |  |  |  | baseline start 2019-04-23 → 2018-08-14; baseline finish 2019-04-25 → 2018-08-16 |
| 40 | Re-test modified code | 2019-04-26 → 2018-08-17 (-252d) | 2019-04-29 → 2018-08-20 (-252d) |  |  |  |  | baseline start 2019-04-26 → 2018-08-17; baseline finish 2019-04-29 → 2018-08-20 |
| 41 | Unit testing complete | 2019-04-29 → 2018-08-20 (-252d) | 2019-04-29 → 2018-08-20 (-252d) |  |  |  |  | baseline start 2019-04-29 → 2018-08-20; baseline finish 2019-04-29 → 2018-08-20 |
| 42 | **Integration Testing** | 2019-04-30 → 2018-08-21 (-252d) | 2019-05-15 → 2018-09-05 (-252d) |  |  |  |  | baseline start 2019-04-30 → 2018-08-21; baseline finish 2019-05-15 → 2018-09-05 |
| 43 | Test module integration | 2019-04-30 → 2018-08-21 (-252d) | 2019-05-06 → 2018-08-27 (-252d) |  |  |  |  | baseline start 2019-04-30 → 2018-08-21; baseline finish 2019-05-06 → 2018-08-27 |
| 44 | Identify anomalies to specifications | 2019-05-07 → 2018-08-28 (-252d) | 2019-05-08 → 2018-08-29 (-252d) |  |  |  |  | baseline start 2019-05-07 → 2018-08-28; baseline finish 2019-05-08 → 2018-08-29 |
| 45 | Modify code | 2019-05-09 → 2018-08-30 (-252d) | 2019-05-13 → 2018-09-03 (-252d) |  |  |  |  | baseline start 2019-05-09 → 2018-08-30; baseline finish 2019-05-13 → 2018-09-03 |
| 46 | Re-test modified code | 2019-05-14 → 2018-09-04 (-252d) | 2019-05-15 → 2018-09-05 (-252d) |  |  |  |  | baseline start 2019-05-14 → 2018-09-04; baseline finish 2019-05-15 → 2018-09-05 |
| 47 | Integration testing complete | 2019-05-15 → 2018-09-05 (-252d) | 2019-05-15 → 2018-09-05 (-252d) |  |  |  |  | baseline start 2019-05-15 → 2018-09-05; baseline finish 2019-05-15 → 2018-09-05 |
| 48 | **Training** | 2019-04-09 → 2018-07-31 (-252d) | 2019-05-22 → 2018-09-12 (-252d) |  |  |  |  | baseline start 2019-04-09 → 2018-07-31; baseline finish 2019-05-22 → 2018-09-12 |
| 49 | Develop training specifications for end users | 2019-04-09 → 2018-07-31 (-252d) | 2019-04-11 → 2018-08-02 (-252d) |  |  |  |  | baseline start 2019-04-09 → 2018-07-31; baseline finish 2019-04-11 → 2018-08-02 |
| 50 | Develop training specifications for helpdesk support staff | 2019-04-12 → 2018-08-03 (-252d) | 2019-04-16 → 2018-08-07 (-252d) |  |  |  |  | baseline start 2019-04-12 → 2018-08-03; baseline finish 2019-04-16 → 2018-08-07 |
| 51 | Identify training delivery methodology (computer based training, classroom, etc.) | 2019-04-17 → 2018-08-08 (-252d) | 2019-04-18 → 2018-08-09 (-252d) |  |  |  |  | baseline start 2019-04-17 → 2018-08-08; baseline finish 2019-04-18 → 2018-08-09 |
| 52 | Develop training materials | 2019-04-19 → 2018-08-10 (-252d) | 2019-05-09 → 2018-08-30 (-252d) |  |  |  |  | baseline start 2019-04-19 → 2018-08-10; baseline finish 2019-05-09 → 2018-08-30 |
| 53 | Conduct training usability study | 2019-05-10 → 2018-08-31 (-252d) | 2019-05-15 → 2018-09-05 (-252d) |  |  |  |  | baseline start 2019-05-10 → 2018-08-31; baseline finish 2019-05-15 → 2018-09-05 |
| 54 | Finalize training materials | 2019-05-16 → 2018-09-06 (-252d) | 2019-05-20 → 2018-09-10 (-252d) |  |  |  |  | baseline start 2019-05-16 → 2018-09-06; baseline finish 2019-05-20 → 2018-09-10 |
| 55 | Develop training delivery mechanism | 2019-05-21 → 2018-09-11 (-252d) | 2019-05-22 → 2018-09-12 (-252d) |  |  |  |  | baseline start 2019-05-21 → 2018-09-11; baseline finish 2019-05-22 → 2018-09-12 |
| 56 | Training materials complete | 2019-05-22 → 2018-09-12 (-252d) | 2019-05-22 → 2018-09-12 (-252d) |  |  |  |  | baseline start 2019-05-22 → 2018-09-12; baseline finish 2019-05-22 → 2018-09-12 |
| 57 | **Documentation** | 2019-02-27 → 2018-06-20 (-252d) | 2019-04-30 → 2018-08-21 (-252d) |  |  | 14d → 16d |  | baseline start 2019-02-27 → 2018-06-20; baseline finish 2019-04-30 → 2018-08-21 |
| 58 | Develop Help specification | 2019-02-27 → 2018-06-20 (-252d) | 2019-02-27 → 2018-06-20 (-252d) |  |  | 19d → 23d |  | baseline start 2019-02-27 → 2018-06-20; baseline finish 2019-02-27 → 2018-06-20 |
| 59 | Develop Help system | 2019-03-07 → 2018-06-28 (-252d) | 2019-03-28 → 2018-07-19 (-252d) |  |  | 13.5d → 17.5d |  | baseline start 2019-03-07 → 2018-06-28; baseline finish 2019-03-28 → 2018-07-19 |
| 60 | Review Help documentation | 2019-04-18 → 2018-08-09 (-252d) | 2019-04-23 → 2018-08-14 (-252d) |  |  | 13.5d → 17.5d |  | baseline start 2019-04-18 → 2018-08-09; baseline finish 2019-04-23 → 2018-08-14 |
| 61 | Incorporate Help documentation feedback | 2019-04-29 → 2018-08-20 (-252d) | 2019-04-30 → 2018-08-21 (-252d) |  |  | 14d → 16d |  | baseline start 2019-04-29 → 2018-08-20; baseline finish 2019-04-30 → 2018-08-21 |
| 62 | Develop user manuals specifications | 2019-02-28 → 2018-06-21 (-252d) | 2019-03-01 → 2018-06-22 (-252d) |  |  | 19d → 20d |  | baseline start 2019-02-28 → 2018-06-21; baseline finish 2019-03-01 → 2018-06-22 |
| 63 | Develop user manuals | 2019-03-28 → 2018-07-19 (-252d) | 2019-04-18 → 2018-08-09 (-252d) |  |  | 15.5d → 16.5d |  | baseline start 2019-03-28 → 2018-07-19; baseline finish 2019-04-18 → 2018-08-09 |
| 64 | Review all user documentation | 2019-04-23 → 2018-08-14 (-252d) | 2019-04-25 → 2018-08-16 (-252d) |  |  | 15.5d → 17.5d |  | baseline start 2019-04-23 → 2018-08-14; baseline finish 2019-04-25 → 2018-08-16 |
| 65 | Incorporate user documentation feedback | 2019-04-25 → 2018-08-16 (-252d) | 2019-04-29 → 2018-08-20 (-252d) |  |  | 15.5d → 17.5d |  | baseline start 2019-04-25 → 2018-08-16; baseline finish 2019-04-29 → 2018-08-20 |
| 66 | Documentation complete | 2019-04-30 → 2018-08-21 (-252d) | 2019-04-30 → 2018-08-21 (-252d) |  |  | 14d → 16d |  | baseline start 2019-04-30 → 2018-08-21; baseline finish 2019-04-30 → 2018-08-21 |
| 67 | **Pilot** | 2019-05-01 → 2018-05-24 (-342d) | 2019-05-31 → 2018-09-21 (-252d) | 23d → 87d |  |  |  | baseline start 2019-05-01 → 2018-05-24; baseline finish 2019-05-31 → 2018-09-21 |
| 68 | Identify test group | 2019-05-01 → 2018-05-24 (-342d) | 2019-05-01 → 2018-05-24 (-342d) |  |  | 14d → 78d | 66 → 16 | baseline start 2019-05-01 → 2018-05-24; baseline finish 2019-05-01 → 2018-05-24 |
| 69 | Develop software delivery mechanism | 2019-05-02 → 2018-05-25 (-342d) | 2019-05-02 → 2018-05-25 (-342d) |  |  | 14d → 78d |  | baseline start 2019-05-02 → 2018-05-25; baseline finish 2019-05-02 → 2018-05-25 |
| 70 | Install/deploy software | 2019-05-23 → 2018-09-13 (-252d) | 2019-05-23 → 2018-09-13 (-252d) |  |  |  |  | baseline start 2019-05-23 → 2018-09-13; baseline finish 2019-05-23 → 2018-09-13 |

| ID | Task | Start | Finish | Other |
| --- | --- | --- | --- | --- |
| 71 | Obtain user feedback | 2019-05-24 → 2018-09-14 (-252d) | 2019-05-30 → 2018-09-20 (-252d) | baseline start 2019-05-24 → 2018-09-14; baseline finish 2019-05-30 → 2018-09-20 |
| 72 | Evaluate testing information | 2019-05-31 → 2018-09-21 (-252d) | 2019-05-31 → 2018-09-21 (-252d) | baseline start 2019-05-31 → 2018-09-21; baseline finish 2019-05-31 → 2018-09-21 |
| 73 | Pilot complete | 2019-05-31 → 2018-09-21 (-252d) | 2019-05-31 → 2018-09-21 (-252d) | baseline start 2019-05-31 → 2018-09-21; baseline finish 2019-05-31 → 2018-09-21 |
| 74 | **Deployment** | 2019-06-03 → 2018-09-24 (-252d) | 2019-06-07 → 2018-09-28 (-252d) | baseline start 2019-06-03 → 2018-09-24; baseline finish 2019-06-07 → 2018-09-28 |
| 75 | Determine final deployment strategy | 2019-06-03 → 2018-09-24 (-252d) | 2019-06-03 → 2018-09-24 (-252d) | baseline start 2019-06-03 → 2018-09-24; baseline finish 2019-06-03 → 2018-09-24 |
| 76 | Develop deployment methodology | 2019-06-04 → 2018-09-25 (-252d) | 2019-06-04 → 2018-09-25 (-252d) | baseline start 2019-06-04 → 2018-09-25; baseline finish 2019-06-04 → 2018-09-25 |
| 77 | Secure deployment resources | 2019-06-05 → 2018-09-26 (-252d) | 2019-06-05 → 2018-09-26 (-252d) | baseline start 2019-06-05 → 2018-09-26; baseline finish 2019-06-05 → 2018-09-26 |
| 78 | Train support staff | 2019-06-06 → 2018-09-27 (-252d) | 2019-06-06 → 2018-09-27 (-252d) | baseline start 2019-06-06 → 2018-09-27; baseline finish 2019-06-06 → 2018-09-27 |
| 79 | Deploy software | 2019-06-07 → 2018-09-28 (-252d) | 2019-06-07 → 2018-09-28 (-252d) | baseline start 2019-06-07 → 2018-09-28; baseline finish 2019-06-07 → 2018-09-28 |
| 80 | Deployment complete | 2019-06-07 → 2018-09-28 (-252d) | 2019-06-07 → 2018-09-28 (-252d) | baseline start 2019-06-07 → 2018-09-28; baseline finish 2019-06-07 → 2018-09-28 |
| 81 | **Post Implementation Review** | 2019-06-10 → 2018-10-01 (-252d) | 2019-06-12 → 2018-10-03 (-252d) | baseline start 2019-06-10 → 2018-10-01; baseline finish 2019-06-12 → 2018-10-03 |
| 82 | Document lessons learned | 2019-06-10 → 2018-10-01 (-252d) | 2019-06-10 → 2018-10-01 (-252d) | baseline start 2019-06-10 → 2018-10-01; baseline finish 2019-06-10 → 2018-10-01 |
| 83 | Distribute to team members | 2019-06-11 → 2018-10-02 (-252d) | 2019-06-11 → 2018-10-02 (-252d) | baseline start 2019-06-11 → 2018-10-02; baseline finish 2019-06-11 → 2018-10-02 |
| 84 | Create software maintenance team | 2019-06-12 → 2018-10-03 (-252d) | 2019-06-12 → 2018-10-03 (-252d) | baseline start 2019-06-12 → 2018-10-03; baseline finish 2019-06-12 → 2018-10-03 |
| 85 | Post implementation review complete | 2019-06-12 → 2018-10-03 (-252d) | 2019-06-12 → 2018-10-03 (-252d) | baseline start 2019-06-12 → 2018-10-03; baseline finish 2019-06-12 → 2018-10-03 |
| 86 | Software development template complete | 2019-06-12 → 2018-10-03 (-252d) | 2019-06-12 → 2018-10-03 (-252d) | was named Software development complete; baseline start 2019-06-12 → 2018-10-03; baseline finish 2019-06-12 → 2018-10-03 |

## Version 10 (saved 2019-04-13, file ExploringProject.mpp)

Last finish 2018-10-03 → 2019-08-13 (+314d).

Changed:

| ID | Task | Start | Finish | Duration | Total float | Predecessors | Other |
| --- | --- | --- | --- | --- | --- | --- | --- |
| 1 | **Scope** | 2018-05-01 → 2019-04-01 (+335d) | 2018-05-09 → 2019-04-04 (+330d) | 7d → 4d |  |  | baseline start 2018-05-01 → none; baseline finish 2018-05-04 → none |
| 2 | Determine project scope | 2018-05-01 → 2019-04-01 (+335d) | 2018-05-02 → 2019-04-01 (+334d) | 2d → 1d |  |  | resources Steve Masters → Management; baseline start 2018-05-01 → none; baseline finish 2018-05-01 → none |
| 3 | Secure project sponsorship | 2018-05-03 → 2019-04-02 (+334d) | 2018-05-03 → 2019-04-02 (+334d) |  |  |  | resources Steve Masters [25%]; Flight [0.6%] → Management; baseline start 2018-05-02 → none; baseline finish 2018-05-02 → none |
| 4 | Define preliminary resources | 2018-05-04 → 2019-04-03 (+334d) | 2018-05-08 → 2019-04-03 (+330d) | 3d → 1d |  |  | baseline start 2018-05-03 → none; baseline finish 2018-05-03 → none |
| 5 | Secure core resources | 2018-05-09 → 2019-04-04 (+330d) | 2018-05-09 → 2019-04-04 (+330d) |  |  |  | baseline start 2018-05-04 → none; baseline finish 2018-05-04 → none |
| 6 | Scope complete | 2018-05-09 → 2019-04-04 (+330d) | 2018-05-09 → 2019-04-04 (+330d) |  |  |  | baseline start 2018-05-04 → none; baseline finish 2018-05-04 → none |
| 7 | **Analysis/Software Requirements** | 2018-05-10 → 2019-04-05 (+330d) | 2018-05-23 → 2019-04-24 (+336d) | 10d → 14d |  |  | baseline start 2018-05-07 → none; baseline finish 2018-05-23 → none |
| 8 | Conduct needs analysis | 2018-05-10 → 2019-04-05 (+330d) | 2018-05-10 → 2019-04-11 (+336d) | 1d → 5d |  |  | resources Kim Ralls; Rob Young → Analyst; baseline start 2018-05-07 → none; baseline finish 2018-05-09 → none |
| 9 | Draft preliminary software specifications | 2018-05-11 → 2019-04-12 (+336d) | 2018-05-16 → 2019-04-16 (+335d) | 4d → 3d |  |  | resources Kim Ralls [50%]; Rob Young [50%] → Analyst; baseline start 2018-05-10 → none; baseline finish 2018-05-15 → none |
| 10 | Develop preliminary budget | 2018-05-17 → 2019-04-17 (+335d) | 2018-05-18 → 2019-04-18 (+335d) |  |  |  | resources Kim Ralls [50%]; Rob Young → Project Manager; baseline start 2018-05-16 → none; baseline finish 2018-05-17 → none |
| 11 | Review software specifications/budget with team | 2018-05-17 → 2019-04-19 (+337d) | 2018-05-17 → 2019-04-19 (+337d) | 1d → 4h |  | 10SS → 10 | resources Steve Masters → Project Manager; Analyst; baseline start 2018-05-16 → none; baseline finish 2018-05-16 → none |
| 12 | Incorporate feedback on software specifications | 2018-05-18 → 2019-04-19 (+336d) | 2018-05-18 → 2019-04-22 (+339d) |  |  |  | resources Kim Ralls → Analyst; baseline start 2018-05-18 → none; baseline finish 2018-05-18 → none |
| 13 | Develop delivery timeline | 2018-05-21 → 2019-04-22 (+336d) | 2018-05-21 → 2019-04-23 (+337d) |  |  |  | resources Kim Ralls → Project Manager; baseline start 2018-05-21 → none; baseline finish 2018-05-21 → none |
| 14 | Obtain approvals to proceed (concept, timeline, budget) | 2018-05-22 → 2019-04-23 (+336d) | 2018-05-22 → 2019-04-23 (+336d) | 1d → 4h |  |  | resources Kim Ralls → Management; Project Manager; baseline start 2018-05-22 → none; baseline finish 2018-05-22 → none |
| 15 | Secure required resources | 2018-05-23 → 2019-04-24 (+336d) | 2018-05-23 → 2019-04-24 (+336d) |  |  |  | resources Kim Ralls → Project Manager; baseline start 2018-05-23 → none; baseline finish 2018-05-23 → none |
| 16 | Analysis complete | 2018-05-23 → 2019-04-24 (+336d) | 2018-05-23 → 2019-04-24 (+336d) |  |  |  | baseline start 2018-05-23 → none; baseline finish 2018-05-23 → none |
| 17 | **Design** | 2018-05-24 → 2019-04-25 (+336d) | 2018-06-13 → 2019-05-15 (+336d) | 15d → 14.5d |  |  | baseline start 2018-05-24 → none; baseline finish 2018-06-13 → none |
| 18 | Review preliminary software specifications | 2018-05-24 → 2019-04-25 (+336d) | 2018-05-25 → 2019-04-26 (+336d) |  |  |  | resources Kim Ralls → Analyst; baseline start 2018-05-24 → none; baseline finish 2018-05-25 → none |
| 19 | Develop functional specifications | 2018-05-28 → 2019-04-29 (+336d) | 2018-06-01 → 2019-05-03 (+336d) |  |  |  | resources Kim Ralls → Analyst; baseline start 2018-05-28 → none; baseline finish 2018-06-01 → none |
| 20 | Develop prototype based on functional specifications | 2018-06-04 → 2019-05-06 (+336d) | 2018-06-07 → 2019-05-09 (+336d) |  |  |  | resources Kim Ralls → Analyst; baseline start 2018-06-04 → none; baseline finish 2018-06-07 → none |
| 21 | Review functional specifications | 2018-06-08 → 2019-05-10 (+336d) | 2018-06-11 → 2019-05-13 (+336d) |  |  |  | resources Kim Ralls → Management; baseline start 2018-06-08 → none; baseline finish 2018-06-11 → none |
| 22 | Incorporate feedback into functional specifications | 2018-06-12 → 2019-05-14 (+336d) | 2018-06-12 → 2019-05-14 (+336d) |  |  |  | resources Kim Ralls → Management; baseline start 2018-06-12 → none; baseline finish 2018-06-12 → none |
| 23 | Obtain approval to proceed | 2018-06-13 → 2019-05-15 (+336d) | 2018-06-13 → 2019-05-15 (+336d) | 1d → 4h |  |  | resources Kim Ralls → Management; Project Manager; baseline start 2018-06-13 → none; baseline finish 2018-06-13 → none |
| 24 | Design complete | 2018-06-13 → 2019-05-15 (+336d) | 2018-06-13 → 2019-05-15 (+336d) |  |  |  | baseline start 2018-06-13 → none; baseline finish 2018-06-13 → none |
| 25 | **Development** | 2018-06-14 → 2019-05-15 (+335d) | 2018-07-30 → 2019-06-14 (+319d) | 33d → 21.75d | 5d → 0d |  | baseline start 2018-06-14 → none; baseline finish 2018-07-30 → none |
| 26 | Review functional specifications | 2018-06-14 → 2019-05-15 (+335d) | 2018-06-14 → 2019-05-16 (+336d) |  | 5d → 0d |  | resources Rob Young → Developer; baseline start 2018-06-14 → none; baseline finish 2018-06-14 → none |
| 27 | Identify modular/tiered design parameters | 2018-06-15 → 2019-05-16 (+335d) | 2018-06-15 → 2019-05-17 (+336d) |  | 5d → 0d |  | resources Rob Young → Developer; baseline start 2018-06-15 → none; baseline finish 2018-06-15 → none |
| 28 | Assign development staff | 2018-06-18 → 2019-05-17 (+333d) | 2018-06-18 → 2019-05-20 (+336d) |  | 5d → 0d |  | resources Rob Young → Developer; baseline start 2018-06-18 → none; baseline finish 2018-06-18 → none |
| 29 | Develop code | 2018-06-19 → 2019-05-20 (+335d) | 2018-07-09 → 2019-06-10 (+336d) |  | 5d → 0d |  | resources Rob Young → Developer; baseline start 2018-06-19 → none; baseline finish 2018-07-09 → none |
| 30 | Developer testing (primary debugging) | 2018-07-10 → 2019-05-24 (+318d) | 2018-07-30 → 2019-06-14 (+319d) |  | 5d → 0d |  | resources Rob Young → Developer; baseline start 2018-07-10 → none; baseline finish 2018-07-30 → none |
| 31 | Development complete | 2018-07-30 → 2019-06-14 (+319d) | 2018-07-30 → 2019-06-14 (+319d) |  | 5d → 0d |  | baseline start 2018-07-30 → none; baseline finish 2018-07-30 → none |
| 32 | **Testing** | 2018-06-14 → 2019-05-15 (+335d) | 2018-09-05 → 2019-07-23 (+321d) | 60d → 48.75d | 20d → 15d |  | baseline start 2018-06-14 → none; baseline finish 2018-09-05 → none |
| 33 | Develop unit test plans using product specifications | 2018-06-14 → 2019-05-15 (+335d) | 2018-06-19 → 2019-05-21 (+336d) |  | 34d → 17.75d |  | resources Steve Masters → Testers; baseline start 2018-06-14 → none; baseline finish 2018-06-19 → none |
| 34 | Develop integration test plans using product specifications | 2018-06-25 → 2019-05-15 (+324d) | 2018-08-22 → 2019-05-21 (+272d) |  | 30d → 59.75d |  | resources Steve Masters → Testers; baseline start 2018-06-25 → none; baseline finish 2018-08-22 → none |
| 35 | **Unit Testing** | 2018-07-31 → 2019-06-14 (+318d) | 2018-08-20 → 2019-07-05 (+319d) |  | 5d → 0d |  | baseline start 2018-07-31 → none; baseline finish 2018-08-20 → none |
| 36 | Review modular code | 2018-07-31 → 2019-06-14 (+318d) | 2018-08-06 → 2019-06-21 (+319d) |  | 5d → 0d |  | resources Kim Ralls → Testers; baseline start 2018-07-31 → none; baseline finish 2018-08-06 → none |
| 37 | Test component modules to product specifications | 2018-08-07 → 2019-06-21 (+318d) | 2018-08-08 → 2019-06-25 (+321d) |  | 5d → 0d |  | resources Kim Ralls → Testers; baseline start 2018-08-07 → none; baseline finish 2018-08-08 → none |
| 38 | Identify anomalies to product specifications | 2018-08-09 → 2019-06-25 (+320d) | 2018-08-13 → 2019-06-28 (+319d) |  | 5d → 0d |  | resources Kim Ralls → Testers; baseline start 2018-08-09 → none; baseline finish 2018-08-13 → none |
| 39 | Modify code | 2018-08-14 → 2019-06-28 (+318d) | 2018-08-16 → 2019-07-03 (+321d) |  | 5d → 0d |  | resources Kim Ralls → Testers; baseline start 2018-08-14 → none; baseline finish 2018-08-16 → none |
| 40 | Re-test modified code | 2018-08-17 → 2019-07-03 (+320d) | 2018-08-20 → 2019-07-05 (+319d) |  | 5d → 0d |  | resources Kim Ralls → Testers; baseline start 2018-08-17 → none; baseline finish 2018-08-20 → none |
| 41 | Unit testing complete | 2018-08-20 → 2019-07-05 (+319d) | 2018-08-20 → 2019-07-05 (+319d) |  | 5d → 0d |  | baseline start 2018-08-20 → none; baseline finish 2018-08-20 → none |
| 42 | **Integration Testing** | 2018-08-21 → 2019-07-05 (+318d) | 2018-09-05 → 2019-07-23 (+321d) |  | 5d → 0d |  | baseline start 2018-08-21 → none; baseline finish 2018-09-05 → none |
| 43 | Test module integration | 2018-08-21 → 2019-07-05 (+318d) | 2018-08-27 → 2019-07-12 (+319d) |  | 5d → 0d |  | resources Kim Ralls → Testers; baseline start 2018-08-21 → none; baseline finish 2018-08-27 → none |
| 44 | Identify anomalies to specifications | 2018-08-28 → 2019-07-12 (+318d) | 2018-08-29 → 2019-07-16 (+321d) |  | 5d → 0d |  | resources Kim Ralls → Testers; baseline start 2018-08-28 → none; baseline finish 2018-08-29 → none |
| 45 | Modify code | 2018-08-30 → 2019-07-16 (+320d) | 2018-09-03 → 2019-07-19 (+319d) |  | 5d → 0d |  | resources Kim Ralls → Testers; baseline start 2018-08-30 → none; baseline finish 2018-09-03 → none |
| 46 | Re-test modified code | 2018-09-04 → 2019-07-19 (+318d) | 2018-09-05 → 2019-07-23 (+321d) |  | 5d → 0d |  | resources Kim Ralls → Testers; baseline start 2018-09-04 → none; baseline finish 2018-09-05 → none |
| 47 | Integration testing complete | 2018-09-05 → 2019-07-23 (+321d) | 2018-09-05 → 2019-07-23 (+321d) |  | 5d → 0d |  | baseline start 2018-09-05 → none; baseline finish 2018-09-05 → none |
| 48 | **Training** | 2018-07-31 → 2019-05-15 (+288d) | 2018-09-12 → 2019-07-18 (+309d) | 32d → 45.75d | 0d → 3d |  | baseline start 2018-07-31 → none; baseline finish 2018-09-12 → none |
| 49 | Develop training specifications for end users | 2018-07-31 → 2019-05-15 (+288d) | 2018-08-02 → 2019-05-20 (+291d) |  | 5d → 21.75d |  | resources Rob Young → Trainers; baseline start 2018-07-31 → none; baseline finish 2018-08-02 → none |
| 50 | Develop training specifications for helpdesk support staff | 2018-08-03 → 2019-05-15 (+285d) | 2018-08-07 → 2019-05-20 (+286d) |  | 2d → 21.75d |  | resources Rob Young → Trainers; baseline start 2018-08-03 → none; baseline finish 2018-08-07 → none |
| 51 | Identify training delivery methodology (computer based training, classroom, etc.) | 2018-08-08 → 2019-05-15 (+280d) | 2018-08-09 → 2019-05-17 (+281d) |  | 0d → 22.75d |  | resources Rob Young → Trainers; baseline start 2018-08-08 → none; baseline finish 2018-08-09 → none |
| 52 | Develop training materials | 2018-08-10 → 2019-06-14 (+308d) | 2018-08-30 → 2019-07-05 (+309d) |  | 0d → 3d |  | resources Rob Young → Trainers; baseline start 2018-08-10 → none; baseline finish 2018-08-30 → none |
| 53 | Conduct training usability study | 2018-08-31 → 2019-07-05 (+308d) | 2018-09-05 → 2019-07-11 (+309d) |  | 0d → 3d |  | resources Rob Young → Trainers; baseline start 2018-08-31 → none; baseline finish 2018-09-05 → none |
| 54 | Finalize training materials | 2018-09-06 → 2019-07-11 (+308d) | 2018-09-10 → 2019-07-16 (+309d) |  | 0d → 3d |  | resources Rob Young → Trainers; baseline start 2018-09-06 → none; baseline finish 2018-09-10 → none |
| 55 | Develop training delivery mechanism | 2018-09-11 → 2019-07-16 (+308d) | 2018-09-12 → 2019-07-18 (+309d) |  | 0d → 3d |  | resources Rob Young → Trainers; baseline start 2018-09-11 → none; baseline finish 2018-09-12 → none |
| 56 | Training materials complete | 2018-09-12 → 2019-07-18 (+309d) | 2018-09-12 → 2019-07-18 (+309d) |  | 0d → 3d |  | baseline start 2018-09-12 → none; baseline finish 2018-09-12 → none |
| 57 | **Documentation** | 2018-06-20 → 2019-05-15 (+329d) | 2018-08-21 → 2019-06-26 (+309d) | 45d → 30.5d | 16d → 18.25d |  | baseline start 2018-06-20 → none; baseline finish 2018-08-21 → none |
| 58 | Develop Help specification | 2018-06-20 → 2019-05-15 (+329d) | 2018-06-20 → 2019-05-16 (+330d) |  | 23d → 27.75d |  | resources Steve Masters → Technical Communicators; baseline start 2018-06-20 → none; baseline finish 2018-06-20 → none |
| 59 | Develop Help system | 2018-06-28 → 2019-05-30 (+336d) | 2018-07-19 → 2019-06-19 (+335d) |  | 17.5d → 18.25d |  | resources Steve Masters → Technical Communicators; baseline start 2018-06-28 → none; baseline finish 2018-07-19 → none |
| 60 | Review Help documentation | 2018-08-09 → 2019-06-20 (+315d) | 2018-08-14 → 2019-06-24 (+314d) |  | 17.5d → 18.25d |  | resources Steve Masters → Technical Communicators; baseline start 2018-08-09 → none; baseline finish 2018-08-14 → none |
| 61 | Incorporate Help documentation feedback | 2018-08-20 → 2019-06-25 (+309d) | 2018-08-21 → 2019-06-26 (+309d) |  | 16d → 18.25d |  | resources Steve Masters → Technical Communicators; baseline start 2018-08-20 → none; baseline finish 2018-08-21 → none |
| 62 | Develop user manuals specifications | 2018-06-21 → 2019-05-15 (+328d) | 2018-06-22 → 2019-05-17 (+329d) |  | 20d → 27.75d |  | resources Steve Masters → Technical Communicators; baseline start 2018-06-21 → none; baseline finish 2018-06-22 → none |
| 63 | Develop user manuals | 2018-07-19 → 2019-05-30 (+315d) | 2018-08-09 → 2019-06-19 (+314d) |  | 16.5d → 19.25d |  | resources Steve Masters → Technical Communicators; baseline start 2018-07-19 → none; baseline finish 2018-08-09 → none |
| 64 | Review all user documentation | 2018-08-14 → 2019-06-20 (+310d) | 2018-08-16 → 2019-06-21 (+309d) |  | 17.5d → 19.25d |  | resources Steve Masters → Technical Communicators; baseline start 2018-08-14 → none; baseline finish 2018-08-16 → none |
| 65 | Incorporate user documentation feedback | 2018-08-16 → 2019-06-24 (+312d) | 2018-08-20 → 2019-06-25 (+309d) |  | 17.5d → 19.25d |  | resources Steve Masters → Technical Communicators; baseline start 2018-08-16 → none; baseline finish 2018-08-20 → none |
| 66 | Documentation complete | 2018-08-21 → 2019-06-26 (+309d) | 2018-08-21 → 2019-06-26 (+309d) |  | 16d → 18.25d |  | baseline start 2018-08-21 → none; baseline finish 2018-08-21 → none |
| 67 | **Pilot** | 2018-05-24 → 2019-04-25 (+336d) | 2018-09-21 → 2019-08-01 (+314d) | 87d → 70.25d |  |  | baseline start 2018-05-24 → none; baseline finish 2018-09-21 → none |
| 68 | Identify test group | 2018-05-24 → 2019-04-25 (+336d) | 2018-05-24 → 2019-04-25 (+336d) |  | 78d → 61.25d |  | resources Rob Young → Project Manager; baseline start 2018-05-24 → none; baseline finish 2018-05-24 → none |
| 69 | Develop software delivery mechanism | 2018-05-25 → 2019-04-26 (+336d) | 2018-05-25 → 2019-04-26 (+336d) |  | 78d → 61.25d |  | resources Rob Young → none; baseline start 2018-05-25 → none; baseline finish 2018-05-25 → none |
| 70 | Install/deploy software | 2018-09-13 → 2019-07-23 (+313d) | 2018-09-13 → 2019-07-24 (+314d) |  |  |  | resources Rob Young → Deployment Team; baseline start 2018-09-13 → none; baseline finish 2018-09-13 → none |

| ID | Task | Start | Finish | Other |
| --- | --- | --- | --- | --- |
| 71 | Obtain user feedback | 2018-09-14 → 2019-07-24 (+313d) | 2018-09-20 → 2019-07-31 (+314d) | resources Rob Young → Deployment Team; baseline start 2018-09-14 → none; baseline finish 2018-09-20 → none |
| 72 | Evaluate testing information | 2018-09-21 → 2019-07-31 (+313d) | 2018-09-21 → 2019-08-01 (+314d) | resources Rob Young → Deployment Team; baseline start 2018-09-21 → none; baseline finish 2018-09-21 → none |
| 73 | Pilot complete | 2018-09-21 → 2019-08-01 (+314d) | 2018-09-21 → 2019-08-01 (+314d) | baseline start 2018-09-21 → none; baseline finish 2018-09-21 → none |
| 74 | **Deployment** | 2018-09-24 → 2019-08-01 (+311d) | 2018-09-28 → 2019-08-08 (+314d) | baseline start 2018-09-24 → none; baseline finish 2018-09-28 → none |
| 75 | Determine final deployment strategy | 2018-09-24 → 2019-08-01 (+311d) | 2018-09-24 → 2019-08-02 (+312d) | resources Kim Ralls → Deployment Team; baseline start 2018-09-24 → none; baseline finish 2018-09-24 → none |
| 76 | Develop deployment methodology | 2018-09-25 → 2019-08-02 (+311d) | 2018-09-25 → 2019-08-05 (+314d) | resources Kim Ralls → Deployment Team; baseline start 2018-09-25 → none; baseline finish 2018-09-25 → none |
| 77 | Secure deployment resources | 2018-09-26 → 2019-08-05 (+313d) | 2018-09-26 → 2019-08-06 (+314d) | resources Kim Ralls → Deployment Team; baseline start 2018-09-26 → none; baseline finish 2018-09-26 → none |
| 78 | Train support staff | 2018-09-27 → 2019-08-06 (+313d) | 2018-09-27 → 2019-08-07 (+314d) | resources Kim Ralls → Deployment Team; baseline start 2018-09-27 → none; baseline finish 2018-09-27 → none |
| 79 | Deploy software | 2018-09-28 → 2019-08-07 (+313d) | 2018-09-28 → 2019-08-08 (+314d) | resources Kim Ralls → Deployment Team; baseline start 2018-09-28 → none; baseline finish 2018-09-28 → none |
| 80 | Deployment complete | 2018-09-28 → 2019-08-08 (+314d) | 2018-09-28 → 2019-08-08 (+314d) | baseline start 2018-09-28 → none; baseline finish 2018-09-28 → none |
| 81 | **Post Implementation Review** | 2018-10-01 → 2019-08-08 (+311d) | 2018-10-03 → 2019-08-13 (+314d) | baseline start 2018-10-01 → none; baseline finish 2018-10-03 → none |
| 82 | Document lessons learned | 2018-10-01 → 2019-08-08 (+311d) | 2018-10-01 → 2019-08-09 (+312d) | resources Rob Young → Project Manager; baseline start 2018-10-01 → none; baseline finish 2018-10-01 → none |
| 83 | Distribute to team members | 2018-10-02 → 2019-08-09 (+311d) | 2018-10-02 → 2019-08-12 (+314d) | resources Rob Young → Project Manager; baseline start 2018-10-02 → none; baseline finish 2018-10-02 → none |
| 84 | Create software maintenance team | 2018-10-03 → 2019-08-12 (+313d) | 2018-10-03 → 2019-08-13 (+314d) | resources Rob Young → Project Manager; baseline start 2018-10-03 → none; baseline finish 2018-10-03 → none |
| 85 | Post implementation review complete | 2018-10-03 → 2019-08-13 (+314d) | 2018-10-03 → 2019-08-13 (+314d) | baseline start 2018-10-03 → none; baseline finish 2018-10-03 → none |
| 86 | Software development template complete | 2018-10-03 → 2019-08-13 (+314d) | 2018-10-03 → 2019-08-13 (+314d) | baseline start 2018-10-03 → none; baseline finish 2018-10-03 → none |

## Version 11 (saved 2019-04-15, file TaskTypeSettings.mpp)

Last finish 2019-08-13 → 2019-06-04 (-70d).

Changed:

| ID | Task | Start | Finish | Duration | Total float | Other |
| --- | --- | --- | --- | --- | --- | --- |
| 1 | **Scope** |  |  | 4d → 4d? |  |  |
| 2 | Determine project scope |  |  | 1d → 1d? |  | resources Management → none |
| 3 | Secure project sponsorship |  |  | 1d → 1d? |  | resources Management → none |
| 4 | Define preliminary resources |  |  | 1d → 1d? |  | resources Project Manager → none |
| 5 | Secure core resources |  |  | 1d → 1d? |  | resources Project Manager → none |
| 6 | Scope complete |  |  | 0d → 0d? |  |  |
| 7 | **Analysis/Software Requirements** |  | 2019-04-24 → 2019-04-16 (-8d) | 14d → 8d? |  |  |
| 8 | Conduct needs analysis |  | 2019-04-11 → 2019-04-05 (-6d) | 5d → 1d? |  | resources Analyst → none |
| 9 | Draft preliminary software specifications | 2019-04-12 → 2019-04-08 (-4d) | 2019-04-16 → 2019-04-08 (-8d) | 3d → 1d? |  | resources Analyst → none |
| 10 | Develop preliminary budget | 2019-04-17 → 2019-04-09 (-8d) | 2019-04-18 → 2019-04-09 (-9d) | 2d → 1d? |  | resources Project Manager → none |
| 11 | Review software specifications/budget with team | 2019-04-19 → 2019-04-10 (-9d) | 2019-04-19 → 2019-04-10 (-9d) | 4h → 1d? |  | resources Project Manager; Analyst → none |
| 12 | Incorporate feedback on software specifications | 2019-04-19 → 2019-04-11 (-8d) | 2019-04-22 → 2019-04-11 (-11d) | 1d → 1d? |  | resources Analyst → none |
| 13 | Develop delivery timeline | 2019-04-22 → 2019-04-12 (-10d) | 2019-04-23 → 2019-04-12 (-11d) | 1d → 1d? |  | resources Project Manager → none |
| 14 | Obtain approvals to proceed (concept, timeline, budget) | 2019-04-23 → 2019-04-15 (-8d) | 2019-04-23 → 2019-04-15 (-8d) | 4h → 1d? |  | resources Management; Project Manager → none |
| 15 | Secure required resources | 2019-04-24 → 2019-04-16 (-8d) | 2019-04-24 → 2019-04-16 (-8d) | 1d → 1d? |  | resources Project Manager → none |
| 16 | Analysis complete | 2019-04-24 → 2019-04-16 (-8d) | 2019-04-24 → 2019-04-16 (-8d) | 0d → 0d? |  |  |
| 17 | **Design** | 2019-04-25 → 2019-04-17 (-8d) | 2019-05-15 → 2019-04-24 (-21d) | 14.5d → 6d? |  |  |
| 18 | Review preliminary software specifications | 2019-04-25 → 2019-04-17 (-8d) | 2019-04-26 → 2019-04-17 (-9d) | 2d → 1d? |  | resources Analyst → none |
| 19 | Develop functional specifications | 2019-04-29 → 2019-04-18 (-11d) | 2019-05-03 → 2019-04-18 (-15d) | 5d → 1d? |  | resources Analyst → none |
| 20 | Develop prototype based on functional specifications | 2019-05-06 → 2019-04-19 (-17d) | 2019-05-09 → 2019-04-19 (-20d) | 4d → 1d? |  | resources Analyst → none |
| 21 | Review functional specifications | 2019-05-10 → 2019-04-22 (-18d) | 2019-05-13 → 2019-04-22 (-21d) | 2d → 1d? |  | resources Management → none |
| 22 | Incorporate feedback into functional specifications | 2019-05-14 → 2019-04-23 (-21d) | 2019-05-14 → 2019-04-23 (-21d) | 1d → 1d? |  | resources Management → none |
| 23 | Obtain approval to proceed | 2019-05-15 → 2019-04-24 (-21d) | 2019-05-15 → 2019-04-24 (-21d) | 4h → 1d? |  | resources Management; Project Manager → none |
| 24 | Design complete | 2019-05-15 → 2019-04-24 (-21d) | 2019-05-15 → 2019-04-24 (-21d) | 0d → 0d? |  |  |
| 25 | **Development** | 2019-05-15 → 2019-04-25 (-20d) | 2019-06-14 → 2019-05-01 (-44d) | 21.75d → 4.25d? |  |  |
| 26 | Review functional specifications | 2019-05-15 → 2019-04-25 (-20d) | 2019-05-16 → 2019-04-25 (-21d) | 1d → 1d? |  | resources Developer → none |
| 27 | Identify modular/tiered design parameters | 2019-05-16 → 2019-04-26 (-20d) | 2019-05-17 → 2019-04-26 (-21d) | 1d → 1d? |  | resources Developer → none |
| 28 | Assign development staff | 2019-05-17 → 2019-04-29 (-18d) | 2019-05-20 → 2019-04-29 (-21d) | 1d → 1d? |  | resources Developer → none |
| 29 | Develop code | 2019-05-20 → 2019-04-30 (-20d) | 2019-06-10 → 2019-04-30 (-41d) | 15d → 1d? |  | resources Developer → none |
| 30 | Developer testing (primary debugging) | 2019-05-24 → 2019-04-30 (-24d) | 2019-06-14 → 2019-05-01 (-44d) | 15d → 1d? |  | resources Developer → none |
| 31 | Development complete | 2019-06-14 → 2019-05-01 (-44d) | 2019-06-14 → 2019-05-01 (-44d) |  |  |  |
| 32 | **Testing** | 2019-05-15 → 2019-04-25 (-20d) | 2019-07-23 → 2019-05-14 (-70d) | 48.75d → 13.25d? | 15d → 3.25d |  |
| 33 | Develop unit test plans using product specifications | 2019-05-15 → 2019-04-25 (-20d) | 2019-05-21 → 2019-04-25 (-26d) | 4d → 1d? | 17.75d → 3.25d | resources Testers → none |
| 34 | Develop integration test plans using product specifications | 2019-05-15 → 2019-04-25 (-20d) | 2019-05-21 → 2019-04-25 (-26d) | 4d → 1d? | 59.75d → 27.25d | resources Testers → none |
| 35 | **Unit Testing** | 2019-06-14 → 2019-05-01 (-44d) | 2019-07-05 → 2019-05-08 (-58d) | 15d → 5d? |  |  |
| 36 | Review modular code | 2019-06-14 → 2019-05-01 (-44d) | 2019-06-21 → 2019-05-02 (-50d) | 5d → 1d? |  | resources Testers → none |
| 37 | Test component modules to product specifications | 2019-06-21 → 2019-05-02 (-50d) | 2019-06-25 → 2019-05-03 (-53d) | 2d → 1d? |  | resources Testers → none |
| 38 | Identify anomalies to product specifications | 2019-06-25 → 2019-05-03 (-53d) | 2019-06-28 → 2019-05-06 (-53d) | 3d → 1d? |  | resources Testers → none |
| 39 | Modify code | 2019-06-28 → 2019-05-06 (-53d) | 2019-07-03 → 2019-05-07 (-57d) | 3d → 1d? |  | resources Testers → none |
| 40 | Re-test modified code | 2019-07-03 → 2019-05-07 (-57d) | 2019-07-05 → 2019-05-08 (-58d) | 2d → 1d? |  | resources Testers → none |
| 41 | Unit testing complete | 2019-07-05 → 2019-05-08 (-58d) | 2019-07-05 → 2019-05-08 (-58d) |  |  |  |
| 42 | **Integration Testing** | 2019-07-05 → 2019-05-08 (-58d) | 2019-07-23 → 2019-05-14 (-70d) | 12d → 4d? |  |  |
| 43 | Test module integration | 2019-07-05 → 2019-05-08 (-58d) | 2019-07-12 → 2019-05-09 (-64d) | 5d → 1d? |  | resources Testers → none |
| 44 | Identify anomalies to specifications | 2019-07-12 → 2019-05-09 (-64d) | 2019-07-16 → 2019-05-10 (-67d) | 2d → 1d? |  | resources Testers → none |
| 45 | Modify code | 2019-07-16 → 2019-05-10 (-67d) | 2019-07-19 → 2019-05-13 (-67d) | 3d → 1d? |  | resources Testers → none |
| 46 | Re-test modified code | 2019-07-19 → 2019-05-13 (-67d) | 2019-07-23 → 2019-05-14 (-70d) | 2d → 1d? |  | resources Testers → none |
| 47 | Integration testing complete | 2019-07-23 → 2019-05-14 (-70d) | 2019-07-23 → 2019-05-14 (-70d) | 0d → 0d? |  |  |
| 48 | **Training** | 2019-05-15 → 2019-04-25 (-20d) | 2019-07-18 → 2019-05-07 (-72d) | 45.75d → 8.25d? | 3d → 5d |  |
| 49 | Develop training specifications for end users | 2019-05-15 → 2019-04-25 (-20d) | 2019-05-20 → 2019-04-25 (-25d) | 3d → 1d? | 21.75d → 8.25d | resources Trainers → none |
| 50 | Develop training specifications for helpdesk support staff | 2019-05-15 → 2019-04-25 (-20d) | 2019-05-20 → 2019-04-25 (-25d) | 3d → 1d? | 21.75d → 8.25d | resources Trainers → none |
| 51 | Identify training delivery methodology (computer based training, classroom, etc.) | 2019-05-15 → 2019-04-25 (-20d) | 2019-05-17 → 2019-04-25 (-22d) | 2d → 1d? | 22.75d → 8.25d | resources Trainers → none |
| 52 | Develop training materials | 2019-06-14 → 2019-05-01 (-44d) | 2019-07-05 → 2019-05-02 (-64d) | 3w → 1d? | 3d → 5d | resources Trainers → none |
| 53 | Conduct training usability study | 2019-07-05 → 2019-05-02 (-64d) | 2019-07-11 → 2019-05-03 (-69d) | 4d → 1d? | 3d → 5d | resources Trainers → none |
| 54 | Finalize training materials | 2019-07-11 → 2019-05-03 (-69d) | 2019-07-16 → 2019-05-06 (-71d) | 3d → 1d? | 3d → 5d | resources Trainers → none |
| 55 | Develop training delivery mechanism | 2019-07-16 → 2019-05-06 (-71d) | 2019-07-18 → 2019-05-07 (-72d) | 2d → 1d? | 3d → 5d | resources Trainers → none |
| 56 | Training materials complete | 2019-07-18 → 2019-05-07 (-72d) | 2019-07-18 → 2019-05-07 (-72d) | 0d → 0d? | 3d → 5d |  |
| 57 | **Documentation** | 2019-05-15 → 2019-04-25 (-20d) | 2019-06-26 → 2019-05-03 (-54d) | 30.5d → 6.5d? | 18.25d → 6.75d |  |
| 58 | Develop Help specification | 2019-05-15 → 2019-04-25 (-20d) | 2019-05-16 → 2019-04-25 (-21d) | 1d → 1d? | 27.75d → 9.25d | resources Technical Communicators → none |
| 59 | Develop Help system | 2019-05-30 → 2019-04-30 (-30d) | 2019-06-19 → 2019-05-01 (-49d) | 3w → 1d? | 18.25d → 6.75d | resources Technical Communicators → none |
| 60 | Review Help documentation | 2019-06-20 → 2019-05-01 (-50d) | 2019-06-24 → 2019-05-02 (-53d) | 3d → 1d? | 18.25d → 6.75d | resources Technical Communicators → none |
| 61 | Incorporate Help documentation feedback | 2019-06-25 → 2019-05-02 (-54d) | 2019-06-26 → 2019-05-03 (-54d) | 2d → 1d? | 18.25d → 6.75d | resources Technical Communicators → none |
| 62 | Develop user manuals specifications | 2019-05-15 → 2019-04-25 (-20d) | 2019-05-17 → 2019-04-25 (-22d) | 2d → 1d? | 27.75d → 9.25d | resources Technical Communicators → none |
| 63 | Develop user manuals | 2019-05-30 → 2019-04-30 (-30d) | 2019-06-19 → 2019-05-01 (-49d) | 3w → 1d? | 19.25d → 6.75d | resources Technical Communicators → none |
| 64 | Review all user documentation | 2019-06-20 → 2019-05-01 (-50d) | 2019-06-21 → 2019-05-02 (-50d) | 2d → 1d? | 19.25d → 6.75d | resources Technical Communicators → none |
| 65 | Incorporate user documentation feedback | 2019-06-24 → 2019-05-02 (-53d) | 2019-06-25 → 2019-05-03 (-53d) | 2d → 1d? | 19.25d → 6.75d | resources Technical Communicators → none |
| 66 | Documentation complete | 2019-06-26 → 2019-05-03 (-54d) | 2019-06-26 → 2019-05-03 (-54d) | 0d → 0d? | 18.25d → 6.75d |  |
| 67 | **Pilot** | 2019-04-25 → 2019-04-17 (-8d) | 2019-08-01 → 2019-05-23 (-70d) | 70.25d → 26.25d? |  |  |
| 68 | Identify test group | 2019-04-25 → 2019-04-17 (-8d) | 2019-04-25 → 2019-04-17 (-8d) | 1d → 1d? | 61.25d → 17.25d | resources Project Manager → none |
| 69 | Develop software delivery mechanism | 2019-04-26 → 2019-04-18 (-8d) | 2019-04-26 → 2019-04-18 (-8d) | 1d → 1d? | 61.25d → 17.25d |  |
| 70 | Install/deploy software | 2019-07-23 → 2019-05-14 (-70d) | 2019-07-24 → 2019-05-15 (-70d) | 1d → 1d? |  | resources Deployment Team → none |

| ID | Task | Start | Finish | Duration | Other |
| --- | --- | --- | --- | --- | --- |
| 71 | Obtain user feedback | 2019-07-24 → 2019-05-15 (-70d) | 2019-07-31 → 2019-05-22 (-70d) | 1w → 1w? | resources Deployment Team → none |
| 72 | Evaluate testing information | 2019-07-31 → 2019-05-22 (-70d) | 2019-08-01 → 2019-05-23 (-70d) | 1d → 1d? | resources Deployment Team → none |
| 73 | Pilot complete | 2019-08-01 → 2019-05-23 (-70d) | 2019-08-01 → 2019-05-23 (-70d) | 0d → 0d? |  |
| 74 | **Deployment** | 2019-08-01 → 2019-05-23 (-70d) | 2019-08-08 → 2019-05-30 (-70d) | 5d → 5d? |  |
| 75 | Determine final deployment strategy | 2019-08-01 → 2019-05-23 (-70d) | 2019-08-02 → 2019-05-24 (-70d) | 1d → 1d? | resources Deployment Team → none |
| 76 | Develop deployment methodology | 2019-08-02 → 2019-05-24 (-70d) | 2019-08-05 → 2019-05-27 (-70d) | 1d → 1d? | resources Deployment Team → none |
| 77 | Secure deployment resources | 2019-08-05 → 2019-05-27 (-70d) | 2019-08-06 → 2019-05-28 (-70d) | 1d → 1d? | resources Deployment Team → none |
| 78 | Train support staff | 2019-08-06 → 2019-05-28 (-70d) | 2019-08-07 → 2019-05-29 (-70d) | 1d → 1d? | resources Deployment Team → none |
| 79 | Deploy software | 2019-08-07 → 2019-05-29 (-70d) | 2019-08-08 → 2019-05-30 (-70d) | 1d → 1d? | resources Deployment Team → none |
| 80 | Deployment complete | 2019-08-08 → 2019-05-30 (-70d) | 2019-08-08 → 2019-05-30 (-70d) | 0d → 0d? |  |
| 81 | **Post Implementation Review** | 2019-08-08 → 2019-05-30 (-70d) | 2019-08-13 → 2019-06-04 (-70d) | 3d → 3d? |  |
| 82 | Document lessons learned | 2019-08-08 → 2019-05-30 (-70d) | 2019-08-09 → 2019-05-31 (-70d) | 1d → 1d? | resources Project Manager → none |
| 83 | Distribute to team members | 2019-08-09 → 2019-05-31 (-70d) | 2019-08-12 → 2019-06-03 (-70d) | 1d → 1d? | resources Project Manager → none |
| 84 | Create software maintenance team | 2019-08-12 → 2019-06-03 (-70d) | 2019-08-13 → 2019-06-04 (-70d) | 1d → 1d? | resources Project Manager → none |
| 85 | Post implementation review complete | 2019-08-13 → 2019-06-04 (-70d) | 2019-08-13 → 2019-06-04 (-70d) | 0d → 0d? |  |
| 86 | Software development template complete | 2019-08-13 → 2019-06-04 (-70d) | 2019-08-13 → 2019-06-04 (-70d) | 0d → 0d? |  |

## Version 12 (saved 2019-04-15, file Constraints.mpp)

Last finish 2019-06-04 → 2019-08-09 (+66d).

Added:

| ID | Task | Duration | Start | Finish | Predecessors |
| --- | --- | --- | --- | --- | --- |
| 16 | Presentation to Leadership | 1d | 2019-04-22 | 2019-04-22 | 15 |

Changed:

| ID | Task | Start | Finish | Duration | Total float | Predecessors | Other |
| --- | --- | --- | --- | --- | --- | --- | --- |
| 1 | **Scope** |  |  | 4d? → 4d |  |  |  |
| 2 | Determine project scope |  |  | 1d? → 1d |  |  | resources none → Suzy Queue |
| 3 | Secure project sponsorship |  |  | 1d? → 1d |  |  | resources none → Suzy Queue |
| 4 | Define preliminary resources |  |  | 1d? → 1d |  |  | resources none → Steve Masters |
| 5 | Secure core resources |  |  | 1d? → 1d |  |  | resources none → Steve Masters |
| 6 | Scope complete |  |  | 0d? → 0d |  |  |  |
| 7 | **Analysis/Software Requirements** |  | 2019-04-16 → 2019-04-22 (+6d) | 8d? → 12d |  |  |  |
| 8 | Conduct needs analysis |  | 2019-04-05 → 2019-04-11 (+6d) | 1d? → 5d |  |  | resources none → Suzy Queue |
| 9 | Draft preliminary software specifications | 2019-04-08 → 2019-04-10 (+2d) | 2019-04-08 → 2019-04-12 (+4d) | 1d? → 3d |  | 8 → 8FS-2d | resources none → Suzy Queue |
| 10 | Develop preliminary budget | 2019-04-09 → 2019-04-05 (-4d) | 2019-04-09 → 2019-04-08 (-1d) | 1d? → 2d | 0d → 4d | 9 → 8SS | resources none → Steve Masters |
| 11 | Review software specifications/budget with team | 2019-04-10 → 2019-04-15 (+5d) | 2019-04-10 → 2019-04-15 (+5d) | 1d? → 1d |  | 10 → 10, 9 | resources none → Steve Masters; Kim Ralls |
| 12 | Incorporate feedback on software specifications | 2019-04-11 → 2019-04-16 (+5d) | 2019-04-11 → 2019-04-16 (+5d) | 1d? → 1d |  |  | resources none → LitWare Development LLC |
| 13 | Develop delivery timeline | 2019-04-12 → 2019-04-17 (+5d) | 2019-04-12 → 2019-04-17 (+5d) | 1d? → 1d |  |  | resources none → Steve Masters |
| 14 | Obtain approvals to proceed (concept, timeline, budget) | 2019-04-15 → 2019-04-18 (+3d) | 2019-04-15 → 2019-04-18 (+3d) | 1d? → 1d |  |  | resources none → Steve Masters; Suzy Queue |
| 15 | Secure required resources | 2019-04-16 → 2019-04-19 (+3d) | 2019-04-16 → 2019-04-19 (+3d) | 1d? → 1d |  |  | resources none → Steve Masters |
| 17 | Analysis complete | 2019-04-16 → 2019-04-22 (+6d) | 2019-04-16 → 2019-04-22 (+6d) | 0d? → 0d |  | 15 → 16 |  |
| 18 | **Design** | 2019-04-17 → 2019-04-23 (+6d) | 2019-04-24 → 2019-05-13 (+19d) | 6d? → 15d |  |  |  |
| 19 | Review preliminary software specifications | 2019-04-17 → 2019-04-23 (+6d) | 2019-04-17 → 2019-04-24 (+7d) | 1d? → 2d |  |  | resources none → Kim Ralls |
| 20 | Develop functional specifications | 2019-04-18 → 2019-04-25 (+7d) | 2019-04-18 → 2019-05-01 (+13d) | 1d? → 5d |  |  | resources none → Kim Ralls |
| 21 | Develop prototype based on functional specifications | 2019-04-19 → 2019-05-02 (+13d) | 2019-04-19 → 2019-05-07 (+18d) | 1d? → 4d |  |  | resources none → Kim Ralls |
| 22 | Review functional specifications | 2019-04-22 → 2019-05-08 (+16d) | 2019-04-22 → 2019-05-09 (+17d) | 1d? → 2d |  |  | resources none → Suzy Queue |
| 23 | Incorporate feedback into functional specifications | 2019-04-23 → 2019-05-10 (+17d) | 2019-04-23 → 2019-05-10 (+17d) | 1d? → 1d |  |  | resources none → Suzy Queue |
| 24 | Obtain approval to proceed | 2019-04-24 → 2019-05-13 (+19d) | 2019-04-24 → 2019-05-13 (+19d) | 1d? → 1d |  |  | resources none → Steve Masters; Suzy Queue |
| 25 | Design complete | 2019-04-24 → 2019-05-13 (+19d) | 2019-04-24 → 2019-05-13 (+19d) | 0d? → 0d |  |  |  |
| 26 | **Development** | 2019-04-25 → 2019-05-14 (+19d) | 2019-05-01 → 2019-06-12 (+42d) | 4.25d? → 21.75d |  |  |  |
| 27 | Review functional specifications | 2019-04-25 → 2019-05-14 (+19d) | 2019-04-25 → 2019-05-14 (+19d) | 1d? → 1d |  |  | resources none → Aaron Painter |
| 28 | Identify modular/tiered design parameters | 2019-04-26 → 2019-05-15 (+19d) | 2019-04-26 → 2019-05-15 (+19d) | 1d? → 1d |  |  | resources none → Aaron Painter |
| 29 | Assign development staff | 2019-04-29 → 2019-05-16 (+17d) | 2019-04-29 → 2019-05-16 (+17d) | 1d? → 1d |  |  | resources none → Aaron Painter |
| 30 | Develop code | 2019-04-30 → 2019-05-17 (+17d) | 2019-04-30 → 2019-06-06 (+37d) | 1d? → 15d |  |  | resources none → Aaron Painter |
| 31 | Developer testing (primary debugging) | 2019-04-30 → 2019-05-22 (+22d) | 2019-05-01 → 2019-06-12 (+42d) | 1d? → 15d |  |  | resources none → Aaron Painter |
| 32 | Development complete | 2019-05-01 → 2019-06-12 (+42d) | 2019-05-01 → 2019-06-12 (+42d) |  |  |  |  |
| 33 | **Testing** | 2019-04-25 → 2019-05-14 (+19d) | 2019-05-14 → 2019-07-19 (+66d) | 13.25d? → 48.75d | 3.25d → 15d |  |  |
| 34 | Develop unit test plans using product specifications | 2019-04-25 → 2019-05-14 (+19d) | 2019-04-25 → 2019-05-17 (+22d) | 1d? → 4d | 3.25d → 17.75d |  | resources none → Tester(s) |
| 35 | Develop integration test plans using product specifications | 2019-04-25 → 2019-05-14 (+19d) | 2019-04-25 → 2019-05-17 (+22d) | 1d? → 4d | 27.25d → 59.75d |  | resources none → Tester(s) |
| 36 | **Unit Testing** | 2019-05-01 → 2019-06-12 (+42d) | 2019-05-08 → 2019-07-03 (+56d) | 5d? → 15d |  |  |  |
| 37 | Review modular code | 2019-05-01 → 2019-06-12 (+42d) | 2019-05-02 → 2019-06-19 (+48d) | 1d? → 5d |  |  | resources none → Tester(s) |
| 38 | Test component modules to product specifications | 2019-05-02 → 2019-06-19 (+48d) | 2019-05-03 → 2019-06-21 (+49d) | 1d? → 2d |  |  | resources none → Tester(s) |
| 39 | Identify anomalies to product specifications | 2019-05-03 → 2019-06-21 (+49d) | 2019-05-06 → 2019-06-26 (+51d) | 1d? → 3d |  |  | resources none → Tester(s) |
| 40 | Modify code | 2019-05-06 → 2019-06-26 (+51d) | 2019-05-07 → 2019-07-01 (+55d) | 1d? → 3d |  |  | resources none → Tester(s) |
| 41 | Re-test modified code | 2019-05-07 → 2019-07-01 (+55d) | 2019-05-08 → 2019-07-03 (+56d) | 1d? → 2d |  |  | resources none → Tester(s) |
| 42 | Unit testing complete | 2019-05-08 → 2019-07-03 (+56d) | 2019-05-08 → 2019-07-03 (+56d) |  |  |  |  |
| 43 | **Integration Testing** | 2019-05-08 → 2019-07-03 (+56d) | 2019-05-14 → 2019-07-19 (+66d) | 4d? → 12d |  |  |  |
| 44 | Test module integration | 2019-05-08 → 2019-07-03 (+56d) | 2019-05-09 → 2019-07-10 (+62d) | 1d? → 5d |  |  | resources none → Tester(s) |
| 45 | Identify anomalies to specifications | 2019-05-09 → 2019-07-10 (+62d) | 2019-05-10 → 2019-07-12 (+63d) | 1d? → 2d |  |  | resources none → Tester(s) |
| 46 | Modify code | 2019-05-10 → 2019-07-12 (+63d) | 2019-05-13 → 2019-07-17 (+65d) | 1d? → 3d |  |  | resources none → Tester(s) |
| 47 | Re-test modified code | 2019-05-13 → 2019-07-17 (+65d) | 2019-05-14 → 2019-07-19 (+66d) | 1d? → 2d |  |  | resources none → Tester(s) |
| 48 | Integration testing complete | 2019-05-14 → 2019-07-19 (+66d) | 2019-05-14 → 2019-07-19 (+66d) | 0d? → 0d |  |  |  |
| 49 | **Training** | 2019-04-25 → 2019-05-14 (+19d) | 2019-05-07 → 2019-07-16 (+70d) | 8.25d? → 45.75d | 5d → 3d |  |  |
| 50 | Develop training specifications for end users | 2019-04-25 → 2019-05-14 (+19d) | 2019-04-25 → 2019-05-16 (+21d) | 1d? → 3d | 8.25d → 21.75d |  | resources none → Trainer(s) |
| 51 | Develop training specifications for helpdesk support staff | 2019-04-25 → 2019-05-14 (+19d) | 2019-04-25 → 2019-05-16 (+21d) | 1d? → 3d | 8.25d → 21.75d |  | resources none → Trainer(s) |
| 52 | Identify training delivery methodology (computer based training, classroom, etc.) | 2019-04-25 → 2019-05-14 (+19d) | 2019-04-25 → 2019-05-15 (+20d) | 1d? → 2d | 8.25d → 22.75d |  | resources none → Trainer(s) |
| 53 | Develop training materials | 2019-05-01 → 2019-06-12 (+42d) | 2019-05-02 → 2019-07-03 (+62d) | 1d? → 3w | 5d → 3d |  | resources none → Trainer(s) |
| 54 | Conduct training usability study | 2019-05-02 → 2019-07-03 (+62d) | 2019-05-03 → 2019-07-09 (+67d) | 1d? → 4d | 5d → 3d |  | resources none → Trainer(s) |
| 55 | Finalize training materials | 2019-05-03 → 2019-07-09 (+67d) | 2019-05-06 → 2019-07-12 (+67d) | 1d? → 3d | 5d → 3d |  | resources none → Trainer(s) |
| 56 | Develop training delivery mechanism | 2019-05-06 → 2019-07-12 (+67d) | 2019-05-07 → 2019-07-16 (+70d) | 1d? → 2d | 5d → 3d |  | resources none → Trainer(s) |
| 57 | Training materials complete | 2019-05-07 → 2019-07-16 (+70d) | 2019-05-07 → 2019-07-16 (+70d) | 0d? → 0d | 5d → 3d |  |  |
| 58 | **Documentation** | 2019-04-25 → 2019-05-14 (+19d) | 2019-05-03 → 2019-06-25 (+53d) | 6.5d? → 30.5d | 6.75d → 18.25d |  | baseline start none → 2018-08-17; baseline finish none → 2018-09-28 |
| 59 | Develop Help specification | 2019-04-25 → 2019-05-14 (+19d) | 2019-04-25 → 2019-05-14 (+19d) | 1d? → 1d | 9.25d → 27.75d |  | resources none → Technical communicator(s) |
| 60 | Develop Help system | 2019-04-30 → 2019-05-28 (+28d) | 2019-05-01 → 2019-06-18 (+48d) | 1d? → 3w | 6.75d → 18.25d |  | resources none → Technical communicator(s) |
| 61 | Review Help documentation | 2019-05-01 → 2019-06-18 (+48d) | 2019-05-02 → 2019-06-21 (+50d) | 1d? → 3d | 6.75d → 18.25d |  | resources none → Technical communicator(s) |
| 62 | Incorporate Help documentation feedback | 2019-05-02 → 2019-06-21 (+50d) | 2019-05-03 → 2019-06-25 (+53d) | 1d? → 2d | 6.75d → 18.25d |  | resources none → Technical communicator(s) |
| 63 | Develop user manuals specifications | 2019-04-25 → 2019-05-14 (+19d) | 2019-04-25 → 2019-05-15 (+20d) | 1d? → 2d | 9.25d → 27.75d |  | resources none → Technical communicator(s) |
| 64 | Develop user manuals | 2019-04-30 → 2019-05-28 (+28d) | 2019-05-01 → 2019-06-18 (+48d) | 1d? → 3w | 6.75d → 19.25d |  | resources none → Technical communicator(s) |
| 65 | Review all user documentation | 2019-05-01 → 2019-06-18 (+48d) | 2019-05-02 → 2019-06-20 (+49d) | 1d? → 2d | 6.75d → 19.25d |  | resources none → Technical communicator(s) |
| 66 | Incorporate user documentation feedback | 2019-05-02 → 2019-06-20 (+49d) | 2019-05-03 → 2019-06-24 (+52d) | 1d? → 2d | 6.75d → 19.25d |  | resources none → Technical communicator(s) |
| 67 | Documentation complete | 2019-05-03 → 2019-06-25 (+53d) | 2019-05-03 → 2019-06-25 (+53d) | 0d? → 0d | 6.75d → 18.25d |  |  |
| 68 | **Pilot** | 2019-04-17 → 2019-04-23 (+6d) | 2019-05-23 → 2019-07-30 (+68d) | 26.25d? → 70.75d |  |  | baseline start none → 2018-07-27; baseline finish none → 2018-11-02 |
| 69 | Identify test group | 2019-04-17 → 2019-04-23 (+6d) | 2019-04-17 → 2019-04-23 (+6d) | 1d? → 1d | 17.25d → 61.75d |  | resources none → Steve Masters |
| 70 | Develop software delivery mechanism | 2019-04-18 → 2019-04-24 (+6d) | 2019-04-18 → 2019-04-24 (+6d) | 1d? → 1d | 17.25d → 61.75d |  |  |
| 71 | Install/deploy software | 2019-05-14 → 2019-07-19 (+66d) | 2019-05-15 → 2019-07-22 (+68d) | 1d? → 1d |  |  | resources none → Deployment team |

| ID | Task | Start | Finish | Duration | Other |
| --- | --- | --- | --- | --- | --- |
| 72 | Obtain user feedback | 2019-05-15 → 2019-07-22 (+68d) | 2019-05-22 → 2019-07-29 (+68d) | 1w? → 1w | resources none → Deployment team |
| 73 | Evaluate testing information | 2019-05-22 → 2019-07-29 (+68d) | 2019-05-23 → 2019-07-30 (+68d) | 1d? → 1d | resources none → Deployment team |
| 74 | Pilot complete | 2019-05-23 → 2019-07-30 (+68d) | 2019-05-23 → 2019-07-30 (+68d) | 0d? → 0d |  |
| 75 | **Deployment** | 2019-05-23 → 2019-07-30 (+68d) | 2019-05-30 → 2019-08-06 (+68d) | 5d? → 5d | baseline start none → 2018-11-02; baseline finish none → 2018-11-09 |
| 76 | Determine final deployment strategy | 2019-05-23 → 2019-07-30 (+68d) | 2019-05-24 → 2019-07-31 (+68d) | 1d? → 1d | resources none → Deployment team |
| 77 | Develop deployment methodology | 2019-05-24 → 2019-07-31 (+68d) | 2019-05-27 → 2019-08-01 (+66d) | 1d? → 1d | resources none → Deployment team |
| 78 | Secure deployment resources | 2019-05-27 → 2019-08-01 (+66d) | 2019-05-28 → 2019-08-02 (+66d) | 1d? → 1d | resources none → Deployment team |
| 79 | Train support staff | 2019-05-28 → 2019-08-02 (+66d) | 2019-05-29 → 2019-08-05 (+68d) | 1d? → 1d | resources none → Deployment team |
| 80 | Deploy software | 2019-05-29 → 2019-08-05 (+68d) | 2019-05-30 → 2019-08-06 (+68d) | 1d? → 1d | resources none → Deployment team |
| 81 | Deployment complete | 2019-05-30 → 2019-08-06 (+68d) | 2019-05-30 → 2019-08-06 (+68d) | 0d? → 0d |  |
| 82 | **Post Implementation Review** | 2019-05-30 → 2019-08-06 (+68d) | 2019-06-04 → 2019-08-09 (+66d) | 3d? → 3d | baseline start none → 2018-11-09; baseline finish none → 2018-11-14 |
| 83 | Document lessons learned | 2019-05-30 → 2019-08-06 (+68d) | 2019-05-31 → 2019-08-07 (+68d) | 1d? → 1d | resources none → Steve Masters |
| 84 | Distribute to team members | 2019-05-31 → 2019-08-07 (+68d) | 2019-06-03 → 2019-08-08 (+66d) | 1d? → 1d | resources none → Steve Masters |
| 85 | Create software maintenance team | 2019-06-03 → 2019-08-08 (+66d) | 2019-06-04 → 2019-08-09 (+66d) | 1d? → 1d | resources none → Steve Masters |
| 86 | Post implementation review complete | 2019-06-04 → 2019-08-09 (+66d) | 2019-06-04 → 2019-08-09 (+66d) | 0d? → 0d |  |
| 87 | Software development template complete | 2019-06-04 → 2019-08-09 (+66d) | 2019-06-04 → 2019-08-09 (+66d) | 0d? → 0d |  |

## Version 13 (saved 2019-04-15, file Tracking.mpp)

Last finish stays 2019-08-09.

Changed:

| ID | Task | Other |
| --- | --- | --- |
| 58 | **Documentation** | baseline start 2018-08-17 → none; baseline finish 2018-09-28 → none |
| 68 | **Pilot** | baseline start 2018-07-27 → none; baseline finish 2018-11-02 → none |
| 75 | **Deployment** | baseline start 2018-11-02 → none; baseline finish 2018-11-09 → none |
| 82 | **Post Implementation Review** | baseline start 2018-11-09 → none; baseline finish 2018-11-14 → none |

## Version 14 (saved 2019-04-15, file FilteringGrouping.mpp)

Last finish stays 2019-08-09. Complete tasks 0 → 5.

Changed:

| ID | Task | Start | Finish | Complete | Total float | Other |
| --- | --- | --- | --- | --- | --- | --- |
| 1 | **Scope** | 2019-04-01 A | 2019-04-04 A | 0% → 100% | 0d → none | baseline start none → 2019-04-01; baseline finish none → 2019-04-04 |
| 2 | Determine project scope | 2019-04-01 A | 2019-04-01 A | 0% → 100% | 0d → none | baseline start none → 2019-04-01; baseline finish none → 2019-04-01 |
| 3 | Secure project sponsorship | 2019-04-02 A | 2019-04-02 A | 0% → 100% | 0d → none | baseline start none → 2019-04-02; baseline finish none → 2019-04-02 |
| 4 | Define preliminary resources | 2019-04-03 A | 2019-04-03 A | 0% → 100% | 0d → none | baseline start none → 2019-04-03; baseline finish none → 2019-04-03 |
| 5 | Secure core resources | 2019-04-04 A | 2019-04-04 A | 0% → 100% | 0d → none | baseline start none → 2019-04-04; baseline finish none → 2019-04-04 |
| 6 | Scope complete | 2019-04-04 A | 2019-04-04 A | 0% → 100% | 0d → none | baseline start none → 2019-04-04; baseline finish none → 2019-04-04 |
| 7 | **Analysis/Software Requirements** |  |  |  |  | baseline start none → 2019-04-05; baseline finish none → 2019-04-22 |
| 8 | Conduct needs analysis |  |  |  |  | baseline start none → 2019-04-05; baseline finish none → 2019-04-11 |
| 9 | Draft preliminary software specifications |  |  |  |  | baseline start none → 2019-04-10; baseline finish none → 2019-04-12 |
| 10 | Develop preliminary budget |  |  |  |  | baseline start none → 2019-04-05; baseline finish none → 2019-04-08 |
| 11 | Review software specifications/budget with team |  |  |  |  | baseline start none → 2019-04-15; baseline finish none → 2019-04-15 |
| 12 | Incorporate feedback on software specifications |  |  |  |  | baseline start none → 2019-04-16; baseline finish none → 2019-04-16 |
| 13 | Develop delivery timeline |  |  |  |  | baseline start none → 2019-04-17; baseline finish none → 2019-04-17 |
| 14 | Obtain approvals to proceed (concept, timeline, budget) |  |  |  |  | baseline start none → 2019-04-18; baseline finish none → 2019-04-18 |
| 15 | Secure required resources |  |  |  |  | baseline start none → 2019-04-19; baseline finish none → 2019-04-19 |
| 16 | Presentation to Leadership |  |  |  |  | baseline start none → 2019-04-22; baseline finish none → 2019-04-22 |
| 17 | Analysis complete |  |  |  |  | baseline start none → 2019-04-22; baseline finish none → 2019-04-22 |
| 18 | **Design** |  |  |  |  | baseline start none → 2019-04-23; baseline finish none → 2019-05-13 |
| 19 | Review preliminary software specifications |  |  |  |  | baseline start none → 2019-04-23; baseline finish none → 2019-04-24 |
| 20 | Develop functional specifications |  |  |  |  | baseline start none → 2019-04-25; baseline finish none → 2019-05-01 |
| 21 | Develop prototype based on functional specifications |  |  |  |  | baseline start none → 2019-05-02; baseline finish none → 2019-05-07 |
| 22 | Review functional specifications |  |  |  |  | baseline start none → 2019-05-08; baseline finish none → 2019-05-09 |
| 23 | Incorporate feedback into functional specifications |  |  |  |  | baseline start none → 2019-05-10; baseline finish none → 2019-05-10 |
| 24 | Obtain approval to proceed |  |  |  |  | baseline start none → 2019-05-13; baseline finish none → 2019-05-13 |
| 25 | Design complete |  |  |  |  | baseline start none → 2019-05-13; baseline finish none → 2019-05-13 |
| 26 | **Development** |  |  |  |  | baseline start none → 2019-05-14; baseline finish none → 2019-06-12 |
| 27 | Review functional specifications |  |  |  |  | baseline start none → 2019-05-14; baseline finish none → 2019-05-14 |
| 28 | Identify modular/tiered design parameters |  |  |  |  | baseline start none → 2019-05-15; baseline finish none → 2019-05-15 |
| 29 | Assign development staff |  |  |  |  | baseline start none → 2019-05-16; baseline finish none → 2019-05-16 |
| 30 | Develop code |  |  |  |  | baseline start none → 2019-05-17; baseline finish none → 2019-06-06 |
| 31 | Developer testing (primary debugging) |  |  |  |  | baseline start none → 2019-05-22; baseline finish none → 2019-06-12 |
| 32 | Development complete |  |  |  |  | baseline start none → 2019-06-12; baseline finish none → 2019-06-12 |
| 33 | **Testing** |  |  |  |  | baseline start none → 2019-05-14; baseline finish none → 2019-07-19 |
| 34 | Develop unit test plans using product specifications |  |  |  |  | baseline start none → 2019-05-14; baseline finish none → 2019-05-17 |
| 35 | Develop integration test plans using product specifications |  |  |  |  | baseline start none → 2019-05-14; baseline finish none → 2019-05-17 |
| 36 | **Unit Testing** |  |  |  |  | baseline start none → 2019-06-12; baseline finish none → 2019-07-03 |
| 37 | Review modular code |  |  |  |  | baseline start none → 2019-06-12; baseline finish none → 2019-06-19 |
| 38 | Test component modules to product specifications |  |  |  |  | baseline start none → 2019-06-19; baseline finish none → 2019-06-21 |
| 39 | Identify anomalies to product specifications |  |  |  |  | baseline start none → 2019-06-21; baseline finish none → 2019-06-26 |
| 40 | Modify code |  |  |  |  | baseline start none → 2019-06-26; baseline finish none → 2019-07-01 |
| 41 | Re-test modified code |  |  |  |  | baseline start none → 2019-07-01; baseline finish none → 2019-07-03 |
| 42 | Unit testing complete |  |  |  |  | baseline start none → 2019-07-03; baseline finish none → 2019-07-03 |
| 43 | **Integration Testing** |  |  |  |  | baseline start none → 2019-07-03; baseline finish none → 2019-07-19 |
| 44 | Test module integration |  |  |  |  | baseline start none → 2019-07-03; baseline finish none → 2019-07-10 |
| 45 | Identify anomalies to specifications |  |  |  |  | baseline start none → 2019-07-10; baseline finish none → 2019-07-12 |
| 46 | Modify code |  |  |  |  | baseline start none → 2019-07-12; baseline finish none → 2019-07-17 |
| 47 | Re-test modified code |  |  |  |  | baseline start none → 2019-07-17; baseline finish none → 2019-07-19 |
| 48 | Integration testing complete |  |  |  |  | baseline start none → 2019-07-19; baseline finish none → 2019-07-19 |
| 49 | **Training** |  |  |  |  | baseline start none → 2019-05-14; baseline finish none → 2019-07-16 |
| 50 | Develop training specifications for end users |  |  |  |  | baseline start none → 2019-05-14; baseline finish none → 2019-05-16 |
| 51 | Develop training specifications for helpdesk support staff |  |  |  |  | baseline start none → 2019-05-14; baseline finish none → 2019-05-16 |
| 52 | Identify training delivery methodology (computer based training, classroom, etc.) |  |  |  |  | baseline start none → 2019-05-14; baseline finish none → 2019-05-15 |
| 53 | Develop training materials |  |  |  |  | baseline start none → 2019-06-12; baseline finish none → 2019-07-03 |
| 54 | Conduct training usability study |  |  |  |  | baseline start none → 2019-07-03; baseline finish none → 2019-07-09 |
| 55 | Finalize training materials |  |  |  |  | baseline start none → 2019-07-09; baseline finish none → 2019-07-12 |
| 56 | Develop training delivery mechanism |  |  |  |  | baseline start none → 2019-07-12; baseline finish none → 2019-07-16 |
| 57 | Training materials complete |  |  |  |  | baseline start none → 2019-07-16; baseline finish none → 2019-07-16 |
| 58 | **Documentation** |  |  |  |  | baseline start none → 2019-05-14; baseline finish none → 2019-06-25 |
| 59 | Develop Help specification |  |  |  |  | baseline start none → 2019-05-14; baseline finish none → 2019-05-14 |
| 60 | Develop Help system |  |  |  |  | baseline start none → 2019-05-28; baseline finish none → 2019-06-18 |
| 61 | Review Help documentation |  |  |  |  | baseline start none → 2019-06-18; baseline finish none → 2019-06-21 |
| 62 | Incorporate Help documentation feedback |  |  |  |  | baseline start none → 2019-06-21; baseline finish none → 2019-06-25 |
| 63 | Develop user manuals specifications |  |  |  |  | baseline start none → 2019-05-14; baseline finish none → 2019-05-15 |
| 64 | Develop user manuals |  |  |  |  | baseline start none → 2019-05-28; baseline finish none → 2019-06-18 |
| 65 | Review all user documentation |  |  |  |  | baseline start none → 2019-06-18; baseline finish none → 2019-06-20 |
| 66 | Incorporate user documentation feedback |  |  |  |  | baseline start none → 2019-06-20; baseline finish none → 2019-06-24 |
| 67 | Documentation complete |  |  |  |  | baseline start none → 2019-06-25; baseline finish none → 2019-06-25 |
| 68 | **Pilot** |  |  |  |  | baseline start none → 2019-04-23; baseline finish none → 2019-07-30 |
| 69 | Identify test group |  |  |  |  | baseline start none → 2019-04-23; baseline finish none → 2019-04-23 |
| 70 | Develop software delivery mechanism |  |  |  |  | baseline start none → 2019-04-24; baseline finish none → 2019-04-24 |

| ID | Task | Other |
| --- | --- | --- |
| 71 | Install/deploy software | baseline start none → 2019-07-19; baseline finish none → 2019-07-22 |
| 72 | Obtain user feedback | baseline start none → 2019-07-22; baseline finish none → 2019-07-29 |
| 73 | Evaluate testing information | baseline start none → 2019-07-29; baseline finish none → 2019-07-30 |
| 74 | Pilot complete | baseline start none → 2019-07-30; baseline finish none → 2019-07-30 |
| 75 | **Deployment** | baseline start none → 2019-07-30; baseline finish none → 2019-08-06 |
| 76 | Determine final deployment strategy | baseline start none → 2019-07-30; baseline finish none → 2019-07-31 |
| 77 | Develop deployment methodology | baseline start none → 2019-07-31; baseline finish none → 2019-08-01 |
| 78 | Secure deployment resources | baseline start none → 2019-08-01; baseline finish none → 2019-08-02 |
| 79 | Train support staff | baseline start none → 2019-08-02; baseline finish none → 2019-08-05 |
| 80 | Deploy software | baseline start none → 2019-08-05; baseline finish none → 2019-08-06 |
| 81 | Deployment complete | baseline start none → 2019-08-06; baseline finish none → 2019-08-06 |
| 82 | **Post Implementation Review** | baseline start none → 2019-08-06; baseline finish none → 2019-08-09 |
| 83 | Document lessons learned | baseline start none → 2019-08-06; baseline finish none → 2019-08-07 |
| 84 | Distribute to team members | baseline start none → 2019-08-07; baseline finish none → 2019-08-08 |
| 85 | Create software maintenance team | baseline start none → 2019-08-08; baseline finish none → 2019-08-09 |
| 86 | Post implementation review complete | baseline start none → 2019-08-09; baseline finish none → 2019-08-09 |
| 87 | Software development template complete | baseline start none → 2019-08-09; baseline finish none → 2019-08-09 |

## Version 15 (saved 2019-04-15, file Contours.mpp)

Last finish 2019-08-09 → 2019-08-19 (+10d). Complete tasks 5 → 0.

Removed: 16 Presentation to Leadership

Changed:

| ID | Task | Start | Finish | Duration | Complete | Total float | Predecessors | Other |
| --- | --- | --- | --- | --- | --- | --- | --- | --- |
| 1 | **Scope** | 2019-04-01 A → 2019-04-01 | 2019-04-04 A → 2019-04-10 (+6d) | 4d → 8d | 100% → 0% | none → 0d |  | baseline start 2019-04-01 → none; baseline finish 2019-04-04 → none |
| 2 | Determine project scope | 2019-04-01 A → 2019-04-01 | 2019-04-01 A → 2019-04-01 |  | 100% → 0% | none → 0d |  | resources Suzy Queue → Management; baseline start 2019-04-01 → none; baseline finish 2019-04-01 → none |
| 3 | Secure project sponsorship | 2019-04-02 A → 2019-04-02 | 2019-04-02 A → 2019-04-02 |  | 100% → 0% | none → 0d |  | resources Suzy Queue → Management; baseline start 2019-04-02 → none; baseline finish 2019-04-02 → none |
| 4 | Define preliminary resources | 2019-04-03 A → 2019-04-03 | 2019-04-03 A → 2019-04-09 (+6d) | 1d → 5d | 100% → 0% | none → 0d |  | resources Steve Masters → Project Manager; baseline start 2019-04-03 → none; baseline finish 2019-04-03 → none |
| 5 | Secure core resources | 2019-04-04 A → 2019-04-10 (+6d) | 2019-04-04 A → 2019-04-10 (+6d) |  | 100% → 0% | none → 0d |  | resources Steve Masters → Project Manager; baseline start 2019-04-04 → none; baseline finish 2019-04-04 → none |
| 6 | Scope complete | 2019-04-04 A → 2019-04-10 (+6d) | 2019-04-04 A → 2019-04-10 (+6d) |  | 100% → 0% | none → 0d |  | baseline start 2019-04-04 → none; baseline finish 2019-04-04 → none |
| 7 | **Analysis/Software Requirements** | 2019-04-05 → 2019-04-11 (+6d) | 2019-04-22 → 2019-04-30 (+8d) | 12d → 14d |  |  |  | baseline start 2019-04-05 → none; baseline finish 2019-04-22 → none |
| 8 | Conduct needs analysis | 2019-04-05 → 2019-04-11 (+6d) | 2019-04-11 → 2019-04-17 (+6d) |  |  |  |  | resources Suzy Queue → Analyst; baseline start 2019-04-05 → none; baseline finish 2019-04-11 → none |
| 9 | Draft preliminary software specifications | 2019-04-10 → 2019-04-18 (+8d) | 2019-04-12 → 2019-04-22 (+10d) |  |  |  | 8FS-2d → 8 | resources Suzy Queue → Analyst; baseline start 2019-04-10 → none; baseline finish 2019-04-12 → none |
| 10 | Develop preliminary budget | 2019-04-05 → 2019-04-23 (+18d) | 2019-04-08 → 2019-04-24 (+16d) |  |  | 4d → 0d | 8SS → 9 | resources Steve Masters → Project Manager; baseline start 2019-04-05 → none; baseline finish 2019-04-08 → none |
| 11 | Review software specifications/budget with team | 2019-04-15 → 2019-04-25 (+10d) | 2019-04-15 → 2019-04-25 (+10d) | 1d → 4h |  |  | 10, 9 → 10 | resources Steve Masters; Kim Ralls → Project Manager; Analyst; baseline start 2019-04-15 → none; baseline finish 2019-04-15 → none |
| 12 | Incorporate feedback on software specifications | 2019-04-16 → 2019-04-25 (+9d) | 2019-04-16 → 2019-04-26 (+10d) |  |  |  |  | resources LitWare Development LLC → Analyst; baseline start 2019-04-16 → none; baseline finish 2019-04-16 → none |
| 13 | Develop delivery timeline | 2019-04-17 → 2019-04-26 (+9d) | 2019-04-17 → 2019-04-29 (+12d) |  |  |  |  | resources Steve Masters → Project Manager; baseline start 2019-04-17 → none; baseline finish 2019-04-17 → none |
| 14 | Obtain approvals to proceed (concept, timeline, budget) | 2019-04-18 → 2019-04-29 (+11d) | 2019-04-18 → 2019-04-29 (+11d) | 1d → 4h |  |  |  | resources Steve Masters; Suzy Queue → Management; Project Manager; baseline start 2019-04-18 → none; baseline finish 2019-04-18 → none |
| 15 | Secure required resources | 2019-04-19 → 2019-04-30 (+11d) | 2019-04-19 → 2019-04-30 (+11d) |  |  |  |  | resources Steve Masters → Project Manager; baseline start 2019-04-19 → none; baseline finish 2019-04-19 → none |
| 16 | Analysis complete | 2019-04-22 → 2019-04-30 (+8d) | 2019-04-22 → 2019-04-30 (+8d) |  |  |  | Presentation to Leadership → 15 | baseline start 2019-04-22 → none; baseline finish 2019-04-22 → none |
| 17 | **Design** | 2019-04-23 → 2019-05-01 (+8d) | 2019-05-13 → 2019-05-21 (+8d) | 15d → 14.5d |  |  |  | baseline start 2019-04-23 → none; baseline finish 2019-05-13 → none |
| 18 | Review preliminary software specifications | 2019-04-23 → 2019-05-01 (+8d) | 2019-04-24 → 2019-05-02 (+8d) |  |  |  |  | resources Kim Ralls → Analyst; baseline start 2019-04-23 → none; baseline finish 2019-04-24 → none |
| 19 | Develop functional specifications | 2019-04-25 → 2019-05-03 (+8d) | 2019-05-01 → 2019-05-09 (+8d) |  |  |  |  | resources Kim Ralls → Analyst; baseline start 2019-04-25 → none; baseline finish 2019-05-01 → none |
| 20 | Develop prototype based on functional specifications | 2019-05-02 → 2019-05-10 (+8d) | 2019-05-07 → 2019-05-15 (+8d) |  |  |  |  | resources Kim Ralls → Analyst; baseline start 2019-05-02 → none; baseline finish 2019-05-07 → none |
| 21 | Review functional specifications | 2019-05-08 → 2019-05-16 (+8d) | 2019-05-09 → 2019-05-17 (+8d) |  |  |  |  | resources Suzy Queue → Management; baseline start 2019-05-08 → none; baseline finish 2019-05-09 → none |
| 22 | Incorporate feedback into functional specifications | 2019-05-10 → 2019-05-20 (+10d) | 2019-05-10 → 2019-05-20 (+10d) |  |  |  |  | resources Suzy Queue → Management; baseline start 2019-05-10 → none; baseline finish 2019-05-10 → none |
| 23 | Obtain approval to proceed | 2019-05-13 → 2019-05-21 (+8d) | 2019-05-13 → 2019-05-21 (+8d) | 1d → 4h |  |  |  | resources Steve Masters; Suzy Queue → Management; Project Manager; baseline start 2019-05-13 → none; baseline finish 2019-05-13 → none |
| 24 | Design complete | 2019-05-13 → 2019-05-21 (+8d) | 2019-05-13 → 2019-05-21 (+8d) |  |  |  |  | baseline start 2019-05-13 → none; baseline finish 2019-05-13 → none |
| 25 | **Development** | 2019-05-14 → 2019-05-21 (+7d) | 2019-06-12 → 2019-06-20 (+8d) |  |  |  |  | baseline start 2019-05-14 → none; baseline finish 2019-06-12 → none |
| 26 | Review functional specifications | 2019-05-14 → 2019-05-21 (+7d) | 2019-05-14 → 2019-05-22 (+8d) |  |  |  |  | resources Aaron Painter → Developer; baseline start 2019-05-14 → none; baseline finish 2019-05-14 → none |
| 27 | Identify modular/tiered design parameters | 2019-05-15 → 2019-05-22 (+7d) | 2019-05-15 → 2019-05-23 (+8d) |  |  |  |  | resources Aaron Painter → Developer; baseline start 2019-05-15 → none; baseline finish 2019-05-15 → none |
| 28 | Assign development staff | 2019-05-16 → 2019-05-23 (+7d) | 2019-05-16 → 2019-05-24 (+8d) |  |  |  |  | resources Aaron Painter → Developer; baseline start 2019-05-16 → none; baseline finish 2019-05-16 → none |
| 29 | Develop code | 2019-05-17 → 2019-05-24 (+7d) | 2019-06-06 → 2019-06-14 (+8d) |  |  |  |  | resources Aaron Painter → Developer; baseline start 2019-05-17 → none; baseline finish 2019-06-06 → none |
| 30 | Developer testing (primary debugging) | 2019-05-22 → 2019-05-30 (+8d) | 2019-06-12 → 2019-06-20 (+8d) |  |  |  |  | resources Aaron Painter → Developer; baseline start 2019-05-22 → none; baseline finish 2019-06-12 → none |
| 31 | Development complete | 2019-06-12 → 2019-06-20 (+8d) | 2019-06-12 → 2019-06-20 (+8d) |  |  |  |  | baseline start 2019-06-12 → none; baseline finish 2019-06-12 → none |
| 32 | **Testing** | 2019-05-14 → 2019-05-21 (+7d) | 2019-07-19 → 2019-07-29 (+10d) |  |  |  |  | baseline start 2019-05-14 → none; baseline finish 2019-07-19 → none |
| 33 | Develop unit test plans using product specifications | 2019-05-14 → 2019-05-21 (+7d) | 2019-05-17 → 2019-05-27 (+10d) |  |  |  |  | resources Tester(s) → Testers; baseline start 2019-05-14 → none; baseline finish 2019-05-17 → none |
| 34 | Develop integration test plans using product specifications | 2019-05-14 → 2019-05-21 (+7d) | 2019-05-17 → 2019-05-27 (+10d) |  |  |  |  | resources Tester(s) → Testers; baseline start 2019-05-14 → none; baseline finish 2019-05-17 → none |
| 35 | **Unit Testing** | 2019-06-12 → 2019-06-20 (+8d) | 2019-07-03 → 2019-07-11 (+8d) |  |  |  |  | baseline start 2019-06-12 → none; baseline finish 2019-07-03 → none |
| 36 | Review modular code | 2019-06-12 → 2019-06-20 (+8d) | 2019-06-19 → 2019-06-27 (+8d) |  |  |  |  | resources Tester(s) → Testers; baseline start 2019-06-12 → none; baseline finish 2019-06-19 → none |
| 37 | Test component modules to product specifications | 2019-06-19 → 2019-06-27 (+8d) | 2019-06-21 → 2019-07-01 (+10d) |  |  |  |  | resources Tester(s) → Testers; baseline start 2019-06-19 → none; baseline finish 2019-06-21 → none |
| 38 | Identify anomalies to product specifications | 2019-06-21 → 2019-07-01 (+10d) | 2019-06-26 → 2019-07-04 (+8d) |  |  |  |  | resources Tester(s) → Testers; baseline start 2019-06-21 → none; baseline finish 2019-06-26 → none |
| 39 | Modify code | 2019-06-26 → 2019-07-04 (+8d) | 2019-07-01 → 2019-07-09 (+8d) |  |  |  |  | resources Tester(s) → Testers; baseline start 2019-06-26 → none; baseline finish 2019-07-01 → none |
| 40 | Re-test modified code | 2019-07-01 → 2019-07-09 (+8d) | 2019-07-03 → 2019-07-11 (+8d) |  |  |  |  | resources Tester(s) → Testers; baseline start 2019-07-01 → none; baseline finish 2019-07-03 → none |
| 41 | Unit testing complete | 2019-07-03 → 2019-07-11 (+8d) | 2019-07-03 → 2019-07-11 (+8d) |  |  |  |  | baseline start 2019-07-03 → none; baseline finish 2019-07-03 → none |
| 42 | **Integration Testing** | 2019-07-03 → 2019-07-11 (+8d) | 2019-07-19 → 2019-07-29 (+10d) |  |  |  |  | baseline start 2019-07-03 → none; baseline finish 2019-07-19 → none |
| 43 | Test module integration | 2019-07-03 → 2019-07-11 (+8d) | 2019-07-10 → 2019-07-18 (+8d) |  |  |  |  | resources Tester(s) → Testers; baseline start 2019-07-03 → none; baseline finish 2019-07-10 → none |
| 44 | Identify anomalies to specifications | 2019-07-10 → 2019-07-18 (+8d) | 2019-07-12 → 2019-07-22 (+10d) |  |  |  |  | resources Tester(s) → Testers; baseline start 2019-07-10 → none; baseline finish 2019-07-12 → none |
| 45 | Modify code | 2019-07-12 → 2019-07-22 (+10d) | 2019-07-17 → 2019-07-25 (+8d) |  |  |  |  | resources Tester(s) → Testers; baseline start 2019-07-12 → none; baseline finish 2019-07-17 → none |
| 46 | Re-test modified code | 2019-07-17 → 2019-07-25 (+8d) | 2019-07-19 → 2019-07-29 (+10d) |  |  |  |  | resources Tester(s) → Testers; baseline start 2019-07-17 → none; baseline finish 2019-07-19 → none |
| 47 | Integration testing complete | 2019-07-19 → 2019-07-29 (+10d) | 2019-07-19 → 2019-07-29 (+10d) |  |  |  |  | baseline start 2019-07-19 → none; baseline finish 2019-07-19 → none |
| 48 | **Training** | 2019-05-14 → 2019-05-21 (+7d) | 2019-07-16 → 2019-07-24 (+8d) |  |  |  |  | baseline start 2019-05-14 → none; baseline finish 2019-07-16 → none |
| 49 | Develop training specifications for end users | 2019-05-14 → 2019-05-21 (+7d) | 2019-05-16 → 2019-05-24 (+8d) |  |  |  |  | resources Trainer(s) → Trainers; baseline start 2019-05-14 → none; baseline finish 2019-05-16 → none |
| 50 | Develop training specifications for helpdesk support staff | 2019-05-14 → 2019-05-21 (+7d) | 2019-05-16 → 2019-05-24 (+8d) |  |  |  |  | resources Trainer(s) → Trainers; baseline start 2019-05-14 → none; baseline finish 2019-05-16 → none |
| 51 | Identify training delivery methodology (computer based training, classroom, etc.) | 2019-05-14 → 2019-05-21 (+7d) | 2019-05-15 → 2019-05-23 (+8d) |  |  |  |  | resources Trainer(s) → Trainers; baseline start 2019-05-14 → none; baseline finish 2019-05-15 → none |
| 52 | Develop training materials | 2019-06-12 → 2019-06-20 (+8d) | 2019-07-03 → 2019-07-11 (+8d) |  |  |  |  | resources Trainer(s) → Trainers; baseline start 2019-06-12 → none; baseline finish 2019-07-03 → none |
| 53 | Conduct training usability study | 2019-07-03 → 2019-07-11 (+8d) | 2019-07-09 → 2019-07-17 (+8d) |  |  |  |  | resources Trainer(s) → Trainers; baseline start 2019-07-03 → none; baseline finish 2019-07-09 → none |
| 54 | Finalize training materials | 2019-07-09 → 2019-07-17 (+8d) | 2019-07-12 → 2019-07-22 (+10d) |  |  |  |  | resources Trainer(s) → Trainers; baseline start 2019-07-09 → none; baseline finish 2019-07-12 → none |
| 55 | Develop training delivery mechanism | 2019-07-12 → 2019-07-22 (+10d) | 2019-07-16 → 2019-07-24 (+8d) |  |  |  |  | resources Trainer(s) → Trainers; baseline start 2019-07-12 → none; baseline finish 2019-07-16 → none |
| 56 | Training materials complete | 2019-07-16 → 2019-07-24 (+8d) | 2019-07-16 → 2019-07-24 (+8d) |  |  |  |  | baseline start 2019-07-16 → none; baseline finish 2019-07-16 → none |
| 57 | **Documentation** | 2019-05-14 → 2019-05-21 (+7d) | 2019-06-25 → 2019-07-02 (+7d) |  |  |  |  | baseline start 2019-05-14 → none; baseline finish 2019-06-25 → none |
| 58 | Develop Help specification | 2019-05-14 → 2019-05-21 (+7d) | 2019-05-14 → 2019-05-22 (+8d) |  |  |  |  | resources Technical communicator(s) → Technical Communicators; baseline start 2019-05-14 → none; baseline finish 2019-05-14 → none |
| 59 | Develop Help system | 2019-05-28 → 2019-06-05 (+8d) | 2019-06-18 → 2019-06-25 (+7d) |  |  |  |  | resources Technical communicator(s) → Technical Communicators; baseline start 2019-05-28 → none; baseline finish 2019-06-18 → none |
| 60 | Review Help documentation | 2019-06-18 → 2019-06-26 (+8d) | 2019-06-21 → 2019-06-28 (+7d) |  |  |  |  | resources Technical communicator(s) → Technical Communicators; baseline start 2019-06-18 → none; baseline finish 2019-06-21 → none |
| 61 | Incorporate Help documentation feedback | 2019-06-21 → 2019-07-01 (+10d) | 2019-06-25 → 2019-07-02 (+7d) |  |  |  |  | resources Technical communicator(s) → Technical Communicators; baseline start 2019-06-21 → none; baseline finish 2019-06-25 → none |
| 62 | Develop user manuals specifications | 2019-05-14 → 2019-05-21 (+7d) | 2019-05-15 → 2019-05-23 (+8d) |  |  |  |  | resources Technical communicator(s) → Technical Communicators; baseline start 2019-05-14 → none; baseline finish 2019-05-15 → none |
| 63 | Develop user manuals | 2019-05-28 → 2019-06-05 (+8d) | 2019-06-18 → 2019-06-25 (+7d) |  |  |  |  | resources Technical communicator(s) → Technical Communicators; baseline start 2019-05-28 → none; baseline finish 2019-06-18 → none |
| 64 | Review all user documentation | 2019-06-18 → 2019-06-26 (+8d) | 2019-06-20 → 2019-06-27 (+7d) |  |  |  |  | resources Technical communicator(s) → Technical Communicators; baseline start 2019-06-18 → none; baseline finish 2019-06-20 → none |
| 65 | Incorporate user documentation feedback | 2019-06-20 → 2019-06-28 (+8d) | 2019-06-24 → 2019-07-01 (+7d) |  |  |  |  | resources Technical communicator(s) → Technical Communicators; baseline start 2019-06-20 → none; baseline finish 2019-06-24 → none |
| 66 | Documentation complete | 2019-06-25 → 2019-07-02 (+7d) | 2019-06-25 → 2019-07-02 (+7d) |  |  |  |  | baseline start 2019-06-25 → none; baseline finish 2019-06-25 → none |
| 67 | **Pilot** | 2019-04-23 → 2019-05-01 (+8d) | 2019-07-30 → 2019-08-07 (+8d) | 70.75d → 70.25d |  |  |  | baseline start 2019-04-23 → none; baseline finish 2019-07-30 → none |
| 68 | Identify test group | 2019-04-23 → 2019-05-01 (+8d) | 2019-04-23 → 2019-05-01 (+8d) |  |  | 61.75d → 61.25d |  | resources Steve Masters → Project Manager; baseline start 2019-04-23 → none; baseline finish 2019-04-23 → none |
| 69 | Develop software delivery mechanism | 2019-04-24 → 2019-05-02 (+8d) | 2019-04-24 → 2019-05-02 (+8d) |  |  | 61.75d → 61.25d |  | baseline start 2019-04-24 → none; baseline finish 2019-04-24 → none |
| 70 | Install/deploy software | 2019-07-19 → 2019-07-29 (+10d) | 2019-07-22 → 2019-07-30 (+8d) |  |  |  |  | resources Deployment team → Deployment Team; baseline start 2019-07-19 → none; baseline finish 2019-07-22 → none |

| ID | Task | Start | Finish | Other |
| --- | --- | --- | --- | --- |
| 71 | Obtain user feedback | 2019-07-22 → 2019-07-30 (+8d) | 2019-07-29 → 2019-08-06 (+8d) | resources Deployment team → Deployment Team; baseline start 2019-07-22 → none; baseline finish 2019-07-29 → none |
| 72 | Evaluate testing information | 2019-07-29 → 2019-08-06 (+8d) | 2019-07-30 → 2019-08-07 (+8d) | resources Deployment team → Deployment Team; baseline start 2019-07-29 → none; baseline finish 2019-07-30 → none |
| 73 | Pilot complete | 2019-07-30 → 2019-08-07 (+8d) | 2019-07-30 → 2019-08-07 (+8d) | baseline start 2019-07-30 → none; baseline finish 2019-07-30 → none |
| 74 | **Deployment** | 2019-07-30 → 2019-08-07 (+8d) | 2019-08-06 → 2019-08-14 (+8d) | baseline start 2019-07-30 → none; baseline finish 2019-08-06 → none |
| 75 | Determine final deployment strategy | 2019-07-30 → 2019-08-07 (+8d) | 2019-07-31 → 2019-08-08 (+8d) | resources Deployment team → Deployment Team; baseline start 2019-07-30 → none; baseline finish 2019-07-31 → none |
| 76 | Develop deployment methodology | 2019-07-31 → 2019-08-08 (+8d) | 2019-08-01 → 2019-08-09 (+8d) | resources Deployment team → Deployment Team; baseline start 2019-07-31 → none; baseline finish 2019-08-01 → none |
| 77 | Secure deployment resources | 2019-08-01 → 2019-08-09 (+8d) | 2019-08-02 → 2019-08-12 (+10d) | resources Deployment team → Deployment Team; baseline start 2019-08-01 → none; baseline finish 2019-08-02 → none |
| 78 | Train support staff | 2019-08-02 → 2019-08-12 (+10d) | 2019-08-05 → 2019-08-13 (+8d) | resources Deployment team → Deployment Team; baseline start 2019-08-02 → none; baseline finish 2019-08-05 → none |
| 79 | Deploy software | 2019-08-05 → 2019-08-13 (+8d) | 2019-08-06 → 2019-08-14 (+8d) | resources Deployment team → Deployment Team; baseline start 2019-08-05 → none; baseline finish 2019-08-06 → none |
| 80 | Deployment complete | 2019-08-06 → 2019-08-14 (+8d) | 2019-08-06 → 2019-08-14 (+8d) | baseline start 2019-08-06 → none; baseline finish 2019-08-06 → none |
| 81 | **Post Implementation Review** | 2019-08-06 → 2019-08-14 (+8d) | 2019-08-09 → 2019-08-19 (+10d) | baseline start 2019-08-06 → none; baseline finish 2019-08-09 → none |
| 82 | Document lessons learned | 2019-08-06 → 2019-08-14 (+8d) | 2019-08-07 → 2019-08-15 (+8d) | resources Steve Masters → Project Manager; baseline start 2019-08-06 → none; baseline finish 2019-08-07 → none |
| 83 | Distribute to team members | 2019-08-07 → 2019-08-15 (+8d) | 2019-08-08 → 2019-08-16 (+8d) | resources Steve Masters → Project Manager; baseline start 2019-08-07 → none; baseline finish 2019-08-08 → none |
| 84 | Create software maintenance team | 2019-08-08 → 2019-08-16 (+8d) | 2019-08-09 → 2019-08-19 (+10d) | resources Steve Masters → Project Manager; baseline start 2019-08-08 → none; baseline finish 2019-08-09 → none |
| 85 | Post implementation review complete | 2019-08-09 → 2019-08-19 (+10d) | 2019-08-09 → 2019-08-19 (+10d) | baseline start 2019-08-09 → none; baseline finish 2019-08-09 → none |
| 86 | Software development template complete | 2019-08-09 → 2019-08-19 (+10d) | 2019-08-09 → 2019-08-19 (+10d) | baseline start 2019-08-09 → none; baseline finish 2019-08-09 → none |

## Version 16 (saved 2019-04-15, file Tracking-Full.mpp)

Last finish 2019-08-19 → 2019-08-09 (-10d).

Added:

| ID | Task | Duration | Start | Finish | Predecessors |
| --- | --- | --- | --- | --- | --- |
| 16 | Presentation to Leadership | 1d | 2019-04-22 | 2019-04-22 | 15 |

Changed:

| ID | Task | Start | Finish | Duration | Total float | Predecessors | Other |
| --- | --- | --- | --- | --- | --- | --- | --- |
| 1 | **Scope** |  | 2019-04-10 → 2019-04-04 (-6d) | 8d → 4d |  |  |  |
| 2 | Determine project scope |  |  |  |  |  | resources Management → Suzy Queue |
| 3 | Secure project sponsorship |  |  |  |  |  | resources Management → Suzy Queue |
| 4 | Define preliminary resources |  | 2019-04-09 → 2019-04-03 (-6d) | 5d → 1d |  |  | resources Project Manager → Steve Masters |
| 5 | Secure core resources | 2019-04-10 → 2019-04-04 (-6d) | 2019-04-10 → 2019-04-04 (-6d) |  |  |  | resources Project Manager → Steve Masters |
| 6 | Scope complete | 2019-04-10 → 2019-04-04 (-6d) | 2019-04-10 → 2019-04-04 (-6d) |  |  |  |  |
| 7 | **Analysis/Software Requirements** | 2019-04-11 → 2019-04-05 (-6d) | 2019-04-30 → 2019-04-22 (-8d) | 14d → 12d |  |  |  |
| 8 | Conduct needs analysis | 2019-04-11 → 2019-04-05 (-6d) | 2019-04-17 → 2019-04-11 (-6d) |  |  |  | resources Analyst → Suzy Queue |
| 9 | Draft preliminary software specifications | 2019-04-18 → 2019-04-10 (-8d) | 2019-04-22 → 2019-04-12 (-10d) |  |  | 8 → 8FS-2d | resources Analyst → Suzy Queue |
| 10 | Develop preliminary budget | 2019-04-23 → 2019-04-05 (-18d) | 2019-04-24 → 2019-04-08 (-16d) |  | 0d → 4d | 9 → 8SS | resources Project Manager → Steve Masters |
| 11 | Review software specifications/budget with team | 2019-04-25 → 2019-04-15 (-10d) | 2019-04-25 → 2019-04-15 (-10d) | 4h → 1d |  | 10 → 10, 9 | resources Project Manager; Analyst → Steve Masters; Kim Ralls |
| 12 | Incorporate feedback on software specifications | 2019-04-25 → 2019-04-16 (-9d) | 2019-04-26 → 2019-04-16 (-10d) |  |  |  | resources Analyst → LitWare Development LLC |
| 13 | Develop delivery timeline | 2019-04-26 → 2019-04-17 (-9d) | 2019-04-29 → 2019-04-17 (-12d) |  |  |  | resources Project Manager → Steve Masters |
| 14 | Obtain approvals to proceed (concept, timeline, budget) | 2019-04-29 → 2019-04-18 (-11d) | 2019-04-29 → 2019-04-18 (-11d) | 4h → 1d |  |  | resources Management; Project Manager → Steve Masters; Suzy Queue |
| 15 | Secure required resources | 2019-04-30 → 2019-04-19 (-11d) | 2019-04-30 → 2019-04-19 (-11d) |  |  |  | resources Project Manager → Steve Masters |
| 17 | Analysis complete | 2019-04-30 → 2019-04-22 (-8d) | 2019-04-30 → 2019-04-22 (-8d) |  |  | 15 → 16 |  |
| 18 | **Design** | 2019-05-01 → 2019-04-23 (-8d) | 2019-05-21 → 2019-05-13 (-8d) | 14.5d → 15d |  |  |  |
| 19 | Review preliminary software specifications | 2019-05-01 → 2019-04-23 (-8d) | 2019-05-02 → 2019-04-24 (-8d) |  |  |  | resources Analyst → Kim Ralls |
| 20 | Develop functional specifications | 2019-05-03 → 2019-04-25 (-8d) | 2019-05-09 → 2019-05-01 (-8d) |  |  |  | resources Analyst → Kim Ralls |
| 21 | Develop prototype based on functional specifications | 2019-05-10 → 2019-05-02 (-8d) | 2019-05-15 → 2019-05-07 (-8d) |  |  |  | resources Analyst → Kim Ralls |
| 22 | Review functional specifications | 2019-05-16 → 2019-05-08 (-8d) | 2019-05-17 → 2019-05-09 (-8d) |  |  |  | resources Management → Suzy Queue |
| 23 | Incorporate feedback into functional specifications | 2019-05-20 → 2019-05-10 (-10d) | 2019-05-20 → 2019-05-10 (-10d) |  |  |  | resources Management → Suzy Queue |
| 24 | Obtain approval to proceed | 2019-05-21 → 2019-05-13 (-8d) | 2019-05-21 → 2019-05-13 (-8d) | 4h → 1d |  |  | resources Management; Project Manager → Steve Masters; Suzy Queue |
| 25 | Design complete | 2019-05-21 → 2019-05-13 (-8d) | 2019-05-21 → 2019-05-13 (-8d) |  |  |  |  |
| 26 | **Development** | 2019-05-21 → 2019-05-14 (-7d) | 2019-06-20 → 2019-06-12 (-8d) |  |  |  |  |
| 27 | Review functional specifications | 2019-05-21 → 2019-05-14 (-7d) | 2019-05-22 → 2019-05-14 (-8d) |  |  |  | resources Developer → Aaron Painter |
| 28 | Identify modular/tiered design parameters | 2019-05-22 → 2019-05-15 (-7d) | 2019-05-23 → 2019-05-15 (-8d) |  |  |  | resources Developer → Aaron Painter |
| 29 | Assign development staff | 2019-05-23 → 2019-05-16 (-7d) | 2019-05-24 → 2019-05-16 (-8d) |  |  |  | resources Developer → Aaron Painter |
| 30 | Develop code | 2019-05-24 → 2019-05-17 (-7d) | 2019-06-14 → 2019-06-06 (-8d) |  |  |  | resources Developer → Aaron Painter |
| 31 | Developer testing (primary debugging) | 2019-05-30 → 2019-05-22 (-8d) | 2019-06-20 → 2019-06-12 (-8d) |  |  |  | resources Developer → Aaron Painter |
| 32 | Development complete | 2019-06-20 → 2019-06-12 (-8d) | 2019-06-20 → 2019-06-12 (-8d) |  |  |  |  |
| 33 | **Testing** | 2019-05-21 → 2019-05-14 (-7d) | 2019-07-29 → 2019-07-19 (-10d) |  |  |  |  |
| 34 | Develop unit test plans using product specifications | 2019-05-21 → 2019-05-14 (-7d) | 2019-05-27 → 2019-05-17 (-10d) |  |  |  | resources Testers → Tester(s) |
| 35 | Develop integration test plans using product specifications | 2019-05-21 → 2019-05-14 (-7d) | 2019-05-27 → 2019-05-17 (-10d) |  |  |  | resources Testers → Tester(s) |
| 36 | **Unit Testing** | 2019-06-20 → 2019-06-12 (-8d) | 2019-07-11 → 2019-07-03 (-8d) |  |  |  |  |
| 37 | Review modular code | 2019-06-20 → 2019-06-12 (-8d) | 2019-06-27 → 2019-06-19 (-8d) |  |  |  | resources Testers → Tester(s) |
| 38 | Test component modules to product specifications | 2019-06-27 → 2019-06-19 (-8d) | 2019-07-01 → 2019-06-21 (-10d) |  |  |  | resources Testers → Tester(s) |
| 39 | Identify anomalies to product specifications | 2019-07-01 → 2019-06-21 (-10d) | 2019-07-04 → 2019-06-26 (-8d) |  |  |  | resources Testers → Tester(s) |
| 40 | Modify code | 2019-07-04 → 2019-06-26 (-8d) | 2019-07-09 → 2019-07-01 (-8d) |  |  |  | resources Testers → Tester(s) |
| 41 | Re-test modified code | 2019-07-09 → 2019-07-01 (-8d) | 2019-07-11 → 2019-07-03 (-8d) |  |  |  | resources Testers → Tester(s) |
| 42 | Unit testing complete | 2019-07-11 → 2019-07-03 (-8d) | 2019-07-11 → 2019-07-03 (-8d) |  |  |  |  |
| 43 | **Integration Testing** | 2019-07-11 → 2019-07-03 (-8d) | 2019-07-29 → 2019-07-19 (-10d) |  |  |  |  |
| 44 | Test module integration | 2019-07-11 → 2019-07-03 (-8d) | 2019-07-18 → 2019-07-10 (-8d) |  |  |  | resources Testers → Tester(s) |
| 45 | Identify anomalies to specifications | 2019-07-18 → 2019-07-10 (-8d) | 2019-07-22 → 2019-07-12 (-10d) |  |  |  | resources Testers → Tester(s) |
| 46 | Modify code | 2019-07-22 → 2019-07-12 (-10d) | 2019-07-25 → 2019-07-17 (-8d) |  |  |  | resources Testers → Tester(s) |
| 47 | Re-test modified code | 2019-07-25 → 2019-07-17 (-8d) | 2019-07-29 → 2019-07-19 (-10d) |  |  |  | resources Testers → Tester(s) |
| 48 | Integration testing complete | 2019-07-29 → 2019-07-19 (-10d) | 2019-07-29 → 2019-07-19 (-10d) |  |  |  |  |
| 49 | **Training** | 2019-05-21 → 2019-05-14 (-7d) | 2019-07-24 → 2019-07-16 (-8d) |  |  |  |  |
| 50 | Develop training specifications for end users | 2019-05-21 → 2019-05-14 (-7d) | 2019-05-24 → 2019-05-16 (-8d) |  |  |  | resources Trainers → Trainer(s) |
| 51 | Develop training specifications for helpdesk support staff | 2019-05-21 → 2019-05-14 (-7d) | 2019-05-24 → 2019-05-16 (-8d) |  |  |  | resources Trainers → Trainer(s) |
| 52 | Identify training delivery methodology (computer based training, classroom, etc.) | 2019-05-21 → 2019-05-14 (-7d) | 2019-05-23 → 2019-05-15 (-8d) |  |  |  | resources Trainers → Trainer(s) |
| 53 | Develop training materials | 2019-06-20 → 2019-06-12 (-8d) | 2019-07-11 → 2019-07-03 (-8d) |  |  |  | resources Trainers → Trainer(s) |
| 54 | Conduct training usability study | 2019-07-11 → 2019-07-03 (-8d) | 2019-07-17 → 2019-07-09 (-8d) |  |  |  | resources Trainers → Trainer(s) |
| 55 | Finalize training materials | 2019-07-17 → 2019-07-09 (-8d) | 2019-07-22 → 2019-07-12 (-10d) |  |  |  | resources Trainers → Trainer(s) |
| 56 | Develop training delivery mechanism | 2019-07-22 → 2019-07-12 (-10d) | 2019-07-24 → 2019-07-16 (-8d) |  |  |  | resources Trainers → Trainer(s) |
| 57 | Training materials complete | 2019-07-24 → 2019-07-16 (-8d) | 2019-07-24 → 2019-07-16 (-8d) |  |  |  |  |
| 58 | **Documentation** | 2019-05-21 → 2019-05-14 (-7d) | 2019-07-02 → 2019-06-25 (-7d) |  |  |  |  |
| 59 | Develop Help specification | 2019-05-21 → 2019-05-14 (-7d) | 2019-05-22 → 2019-05-14 (-8d) |  |  |  | resources Technical Communicators → Technical communicator(s) |
| 60 | Develop Help system | 2019-06-05 → 2019-05-28 (-8d) | 2019-06-25 → 2019-06-18 (-7d) |  |  |  | resources Technical Communicators → Technical communicator(s) |
| 61 | Review Help documentation | 2019-06-26 → 2019-06-18 (-8d) | 2019-06-28 → 2019-06-21 (-7d) |  |  |  | resources Technical Communicators → Technical communicator(s) |
| 62 | Incorporate Help documentation feedback | 2019-07-01 → 2019-06-21 (-10d) | 2019-07-02 → 2019-06-25 (-7d) |  |  |  | resources Technical Communicators → Technical communicator(s) |
| 63 | Develop user manuals specifications | 2019-05-21 → 2019-05-14 (-7d) | 2019-05-23 → 2019-05-15 (-8d) |  |  |  | resources Technical Communicators → Technical communicator(s) |
| 64 | Develop user manuals | 2019-06-05 → 2019-05-28 (-8d) | 2019-06-25 → 2019-06-18 (-7d) |  |  |  | resources Technical Communicators → Technical communicator(s) |
| 65 | Review all user documentation | 2019-06-26 → 2019-06-18 (-8d) | 2019-06-27 → 2019-06-20 (-7d) |  |  |  | resources Technical Communicators → Technical communicator(s) |
| 66 | Incorporate user documentation feedback | 2019-06-28 → 2019-06-20 (-8d) | 2019-07-01 → 2019-06-24 (-7d) |  |  |  | resources Technical Communicators → Technical communicator(s) |
| 67 | Documentation complete | 2019-07-02 → 2019-06-25 (-7d) | 2019-07-02 → 2019-06-25 (-7d) |  |  |  |  |
| 68 | **Pilot** | 2019-05-01 → 2019-04-23 (-8d) | 2019-08-07 → 2019-07-30 (-8d) | 70.25d → 70.75d |  |  |  |
| 69 | Identify test group | 2019-05-01 → 2019-04-23 (-8d) | 2019-05-01 → 2019-04-23 (-8d) |  | 61.25d → 61.75d |  | resources Project Manager → Steve Masters |
| 70 | Develop software delivery mechanism | 2019-05-02 → 2019-04-24 (-8d) | 2019-05-02 → 2019-04-24 (-8d) |  | 61.25d → 61.75d |  |  |
| 71 | Install/deploy software | 2019-07-29 → 2019-07-19 (-10d) | 2019-07-30 → 2019-07-22 (-8d) |  |  |  | resources Deployment Team → Deployment team |

| ID | Task | Start | Finish | Other |
| --- | --- | --- | --- | --- |
| 72 | Obtain user feedback | 2019-07-30 → 2019-07-22 (-8d) | 2019-08-06 → 2019-07-29 (-8d) | resources Deployment Team → Deployment team |
| 73 | Evaluate testing information | 2019-08-06 → 2019-07-29 (-8d) | 2019-08-07 → 2019-07-30 (-8d) | resources Deployment Team → Deployment team |
| 74 | Pilot complete | 2019-08-07 → 2019-07-30 (-8d) | 2019-08-07 → 2019-07-30 (-8d) |  |
| 75 | **Deployment** | 2019-08-07 → 2019-07-30 (-8d) | 2019-08-14 → 2019-08-06 (-8d) |  |
| 76 | Determine final deployment strategy | 2019-08-07 → 2019-07-30 (-8d) | 2019-08-08 → 2019-07-31 (-8d) | resources Deployment Team → Deployment team |
| 77 | Develop deployment methodology | 2019-08-08 → 2019-07-31 (-8d) | 2019-08-09 → 2019-08-01 (-8d) | resources Deployment Team → Deployment team |
| 78 | Secure deployment resources | 2019-08-09 → 2019-08-01 (-8d) | 2019-08-12 → 2019-08-02 (-10d) | resources Deployment Team → Deployment team |
| 79 | Train support staff | 2019-08-12 → 2019-08-02 (-10d) | 2019-08-13 → 2019-08-05 (-8d) | resources Deployment Team → Deployment team |
| 80 | Deploy software | 2019-08-13 → 2019-08-05 (-8d) | 2019-08-14 → 2019-08-06 (-8d) | resources Deployment Team → Deployment team |
| 81 | Deployment complete | 2019-08-14 → 2019-08-06 (-8d) | 2019-08-14 → 2019-08-06 (-8d) |  |
| 82 | **Post Implementation Review** | 2019-08-14 → 2019-08-06 (-8d) | 2019-08-19 → 2019-08-09 (-10d) |  |
| 83 | Document lessons learned | 2019-08-14 → 2019-08-06 (-8d) | 2019-08-15 → 2019-08-07 (-8d) | resources Project Manager → Steve Masters |
| 84 | Distribute to team members | 2019-08-15 → 2019-08-07 (-8d) | 2019-08-16 → 2019-08-08 (-8d) | resources Project Manager → Steve Masters |
| 85 | Create software maintenance team | 2019-08-16 → 2019-08-08 (-8d) | 2019-08-19 → 2019-08-09 (-10d) | resources Project Manager → Steve Masters |
| 86 | Post implementation review complete | 2019-08-19 → 2019-08-09 (-10d) | 2019-08-19 → 2019-08-09 (-10d) |  |
| 87 | Software development template complete | 2019-08-19 → 2019-08-09 (-10d) | 2019-08-19 → 2019-08-09 (-10d) |  |

## Version 17 (saved 2019-04-15, file Reporting.mpp)

Last finish stays 2019-08-09. Complete tasks 0 → 5.

Changed:

| ID | Task | Start | Finish | Complete | Total float | Other |
| --- | --- | --- | --- | --- | --- | --- |
| 1 | **Scope** | 2019-04-01 A | 2019-04-04 A | 0% → 100% | 0d → none | baseline start none → 2019-04-01; baseline finish none → 2019-04-04 |
| 2 | Determine project scope | 2019-04-01 A | 2019-04-01 A | 0% → 100% | 0d → none | baseline start none → 2019-04-01; baseline finish none → 2019-04-01 |
| 3 | Secure project sponsorship | 2019-04-02 A | 2019-04-02 A | 0% → 100% | 0d → none | baseline start none → 2019-04-02; baseline finish none → 2019-04-02 |
| 4 | Define preliminary resources | 2019-04-03 A | 2019-04-03 A | 0% → 100% | 0d → none | baseline start none → 2019-04-03; baseline finish none → 2019-04-03 |
| 5 | Secure core resources | 2019-04-04 A | 2019-04-04 A | 0% → 100% | 0d → none | baseline start none → 2019-04-04; baseline finish none → 2019-04-04 |
| 6 | Scope complete | 2019-04-04 A | 2019-04-04 A | 0% → 100% | 0d → none | baseline start none → 2019-04-04; baseline finish none → 2019-04-04 |
| 7 | **Analysis/Software Requirements** |  |  |  |  | baseline start none → 2019-04-05; baseline finish none → 2019-04-22 |
| 8 | Conduct needs analysis |  |  |  |  | baseline start none → 2019-04-05; baseline finish none → 2019-04-11 |
| 9 | Draft preliminary software specifications |  |  |  |  | baseline start none → 2019-04-10; baseline finish none → 2019-04-12 |
| 10 | Develop preliminary budget |  |  |  |  | baseline start none → 2019-04-05; baseline finish none → 2019-04-08 |
| 11 | Review software specifications/budget with team |  |  |  |  | baseline start none → 2019-04-15; baseline finish none → 2019-04-15 |
| 12 | Incorporate feedback on software specifications |  |  |  |  | baseline start none → 2019-04-16; baseline finish none → 2019-04-16 |
| 13 | Develop delivery timeline |  |  |  |  | baseline start none → 2019-04-17; baseline finish none → 2019-04-17 |
| 14 | Obtain approvals to proceed (concept, timeline, budget) |  |  |  |  | baseline start none → 2019-04-18; baseline finish none → 2019-04-18 |
| 15 | Secure required resources |  |  |  |  | baseline start none → 2019-04-19; baseline finish none → 2019-04-19 |
| 16 | Presentation to Leadership |  |  |  |  | baseline start none → 2019-04-22; baseline finish none → 2019-04-22 |
| 17 | Analysis complete |  |  |  |  | baseline start none → 2019-04-22; baseline finish none → 2019-04-22 |
| 18 | **Design** |  |  |  |  | baseline start none → 2019-04-23; baseline finish none → 2019-05-13 |
| 19 | Review preliminary software specifications |  |  |  |  | baseline start none → 2019-04-23; baseline finish none → 2019-04-24 |
| 20 | Develop functional specifications |  |  |  |  | baseline start none → 2019-04-25; baseline finish none → 2019-05-01 |
| 21 | Develop prototype based on functional specifications |  |  |  |  | baseline start none → 2019-05-02; baseline finish none → 2019-05-07 |
| 22 | Review functional specifications |  |  |  |  | baseline start none → 2019-05-08; baseline finish none → 2019-05-09 |
| 23 | Incorporate feedback into functional specifications |  |  |  |  | baseline start none → 2019-05-10; baseline finish none → 2019-05-10 |
| 24 | Obtain approval to proceed |  |  |  |  | baseline start none → 2019-05-13; baseline finish none → 2019-05-13 |
| 25 | Design complete |  |  |  |  | baseline start none → 2019-05-13; baseline finish none → 2019-05-13 |
| 26 | **Development** |  |  |  |  | baseline start none → 2019-05-14; baseline finish none → 2019-06-12 |
| 27 | Review functional specifications |  |  |  |  | baseline start none → 2019-05-14; baseline finish none → 2019-05-14 |
| 28 | Identify modular/tiered design parameters |  |  |  |  | baseline start none → 2019-05-15; baseline finish none → 2019-05-15 |
| 29 | Assign development staff |  |  |  |  | baseline start none → 2019-05-16; baseline finish none → 2019-05-16 |
| 30 | Develop code |  |  |  |  | baseline start none → 2019-05-17; baseline finish none → 2019-06-06 |
| 31 | Developer testing (primary debugging) |  |  |  |  | baseline start none → 2019-05-22; baseline finish none → 2019-06-12 |
| 32 | Development complete |  |  |  |  | baseline start none → 2019-06-12; baseline finish none → 2019-06-12 |
| 33 | **Testing** |  |  |  |  | baseline start none → 2019-05-14; baseline finish none → 2019-07-19 |
| 34 | Develop unit test plans using product specifications |  |  |  |  | baseline start none → 2019-05-14; baseline finish none → 2019-05-17 |
| 35 | Develop integration test plans using product specifications |  |  |  |  | baseline start none → 2019-05-14; baseline finish none → 2019-05-17 |
| 36 | **Unit Testing** |  |  |  |  | baseline start none → 2019-06-12; baseline finish none → 2019-07-03 |
| 37 | Review modular code |  |  |  |  | baseline start none → 2019-06-12; baseline finish none → 2019-06-19 |
| 38 | Test component modules to product specifications |  |  |  |  | baseline start none → 2019-06-19; baseline finish none → 2019-06-21 |
| 39 | Identify anomalies to product specifications |  |  |  |  | baseline start none → 2019-06-21; baseline finish none → 2019-06-26 |
| 40 | Modify code |  |  |  |  | baseline start none → 2019-06-26; baseline finish none → 2019-07-01 |
| 41 | Re-test modified code |  |  |  |  | baseline start none → 2019-07-01; baseline finish none → 2019-07-03 |
| 42 | Unit testing complete |  |  |  |  | baseline start none → 2019-07-03; baseline finish none → 2019-07-03 |
| 43 | **Integration Testing** |  |  |  |  | baseline start none → 2019-07-03; baseline finish none → 2019-07-19 |
| 44 | Test module integration |  |  |  |  | baseline start none → 2019-07-03; baseline finish none → 2019-07-10 |
| 45 | Identify anomalies to specifications |  |  |  |  | baseline start none → 2019-07-10; baseline finish none → 2019-07-12 |
| 46 | Modify code |  |  |  |  | baseline start none → 2019-07-12; baseline finish none → 2019-07-17 |
| 47 | Re-test modified code |  |  |  |  | baseline start none → 2019-07-17; baseline finish none → 2019-07-19 |
| 48 | Integration testing complete |  |  |  |  | baseline start none → 2019-07-19; baseline finish none → 2019-07-19 |
| 49 | **Training** |  |  |  |  | baseline start none → 2019-05-14; baseline finish none → 2019-07-16 |
| 50 | Develop training specifications for end users |  |  |  |  | baseline start none → 2019-05-14; baseline finish none → 2019-05-16 |
| 51 | Develop training specifications for helpdesk support staff |  |  |  |  | baseline start none → 2019-05-14; baseline finish none → 2019-05-16 |
| 52 | Identify training delivery methodology (computer based training, classroom, etc.) |  |  |  |  | baseline start none → 2019-05-14; baseline finish none → 2019-05-15 |
| 53 | Develop training materials |  |  |  |  | baseline start none → 2019-06-12; baseline finish none → 2019-07-03 |
| 54 | Conduct training usability study |  |  |  |  | baseline start none → 2019-07-03; baseline finish none → 2019-07-09 |
| 55 | Finalize training materials |  |  |  |  | baseline start none → 2019-07-09; baseline finish none → 2019-07-12 |
| 56 | Develop training delivery mechanism |  |  |  |  | baseline start none → 2019-07-12; baseline finish none → 2019-07-16 |
| 57 | Training materials complete |  |  |  |  | baseline start none → 2019-07-16; baseline finish none → 2019-07-16 |
| 58 | **Documentation** |  |  |  |  | baseline start none → 2019-05-14; baseline finish none → 2019-06-25 |
| 59 | Develop Help specification |  |  |  |  | baseline start none → 2019-05-14; baseline finish none → 2019-05-14 |
| 60 | Develop Help system |  |  |  |  | baseline start none → 2019-05-28; baseline finish none → 2019-06-18 |
| 61 | Review Help documentation |  |  |  |  | baseline start none → 2019-06-18; baseline finish none → 2019-06-21 |
| 62 | Incorporate Help documentation feedback |  |  |  |  | baseline start none → 2019-06-21; baseline finish none → 2019-06-25 |
| 63 | Develop user manuals specifications |  |  |  |  | baseline start none → 2019-05-14; baseline finish none → 2019-05-15 |
| 64 | Develop user manuals |  |  |  |  | baseline start none → 2019-05-28; baseline finish none → 2019-06-18 |
| 65 | Review all user documentation |  |  |  |  | baseline start none → 2019-06-18; baseline finish none → 2019-06-20 |
| 66 | Incorporate user documentation feedback |  |  |  |  | baseline start none → 2019-06-20; baseline finish none → 2019-06-24 |
| 67 | Documentation complete |  |  |  |  | baseline start none → 2019-06-25; baseline finish none → 2019-06-25 |
| 68 | **Pilot** |  |  |  |  | baseline start none → 2019-04-23; baseline finish none → 2019-07-30 |
| 69 | Identify test group |  |  |  |  | baseline start none → 2019-04-23; baseline finish none → 2019-04-23 |
| 70 | Develop software delivery mechanism |  |  |  |  | baseline start none → 2019-04-24; baseline finish none → 2019-04-24 |

| ID | Task | Other |
| --- | --- | --- |
| 71 | Install/deploy software | baseline start none → 2019-07-19; baseline finish none → 2019-07-22 |
| 72 | Obtain user feedback | baseline start none → 2019-07-22; baseline finish none → 2019-07-29 |
| 73 | Evaluate testing information | baseline start none → 2019-07-29; baseline finish none → 2019-07-30 |
| 74 | Pilot complete | baseline start none → 2019-07-30; baseline finish none → 2019-07-30 |
| 75 | **Deployment** | baseline start none → 2019-07-30; baseline finish none → 2019-08-06 |
| 76 | Determine final deployment strategy | baseline start none → 2019-07-30; baseline finish none → 2019-07-31 |
| 77 | Develop deployment methodology | baseline start none → 2019-07-31; baseline finish none → 2019-08-01 |
| 78 | Secure deployment resources | baseline start none → 2019-08-01; baseline finish none → 2019-08-02 |
| 79 | Train support staff | baseline start none → 2019-08-02; baseline finish none → 2019-08-05 |
| 80 | Deploy software | baseline start none → 2019-08-05; baseline finish none → 2019-08-06 |
| 81 | Deployment complete | baseline start none → 2019-08-06; baseline finish none → 2019-08-06 |
| 82 | **Post Implementation Review** | baseline start none → 2019-08-06; baseline finish none → 2019-08-09 |
| 83 | Document lessons learned | baseline start none → 2019-08-06; baseline finish none → 2019-08-07 |
| 84 | Distribute to team members | baseline start none → 2019-08-07; baseline finish none → 2019-08-08 |
| 85 | Create software maintenance team | baseline start none → 2019-08-08; baseline finish none → 2019-08-09 |
| 86 | Post implementation review complete | baseline start none → 2019-08-09; baseline finish none → 2019-08-09 |
| 87 | Software development template complete | baseline start none → 2019-08-09; baseline finish none → 2019-08-09 |
